# MAPS Inner Barrel

Schedule from MS Project, 2016-10-01 to 2021-06-01, costs in $.
Guest Scientist, LANL

## Calendars

- Standard: Mon-Fri 08:00-12:00, 13:00-17:00; Sat-Sun off.

## Resources

| Resource | Rate | Cost per use |
| --- | --- | --- |
| Mech Liason Eng | 230 |  |
| Elec Liason Eng | 230 |  |
| Project Manager |  |  |
| Physicist |  |  |
| Elec tech | 200 |  |
| Mech Tech | 200 |  |
| Electronics Engineer | 250 |  |
| Mechanical Engineer | 250 |  |
| M&S |  | 1 |
| Electrical Engineer |  |  |

## Schedule

| ID | WBS | Task | Type | Duration | Start | Finish | Predecessors | Total slack | Free slack | Constraint | Resources | Work | Cost |
| --- | --- | --- | --- | --- | --- | --- | --- | --- | --- | --- | --- | --- | --- |
| 1 | 1 | **MAPS Inner Barrel** |  | 1218d | 2016-10-01 | 2021-06-01 |  |  |  | start no earlier than 2005-10-21 |  | 18108.6h | 4,009,412.85 |
| 2 | 1.1 | **Milestones** |  | 1216d | 2016-10-01 | 2021-06-01 |  | 0d |  |  |  |  |  |
| 3 | 1.1.1 | sPHENIX Conceptual Design (CD-0) | milestone, manual | 0d | 2016-10-01 | 2016-10-01 |  |  |  | start no earlier than 2016-10-01 |  |  |  |
| 4 | 1.1.2 | sPHENIX Technical Design (CD-1) | milestone, manual | 0d | 2017-11-01 | 2017-11-01 |  |  |  | start no earlier than 2017-11-01 |  |  |  |
| 5 | 1.1.3 | sPHENIX Final Design (CD-2/CD-3a) | milestone, manual | 0d | 2018-06-01 | 2018-06-01 | 96 |  |  | start no earlier than 2018-06-01 |  |  |  |
| 6 | 1.1.4 | sPHENIX Start Construction (CD-3b) | milestone, manual | 0d | 2018-08-01 | 2018-08-01 |  |  |  | start no earlier than 2018-08-01 |  |  |  |
| 7 | 1.1.5 | sPHENIX Installation | milestone, manual | 0d | 2021-06-01 | 2021-06-01 | 122 |  |  | start no earlier than 2021-06-01 |  |  |  |
| 8 | 1.1.6 | ALICE ITS Inner Barrel Construction | manual | 261d | 2017-01-02 | 2018-01-01 |  |  |  | finish no earlier than 2018-01-01 |  |  |  |
| 9 | 1.1.7 | ALICE ITS Electronics Pre-Production | manual | 100d | 2017-02-22 | 2017-07-11 |  |  |  | finish no earlier than 2017-07-11 |  |  |  |
| 10 | 1.1.8 | ALICE ITS Electronics Production | manual | 240d | 2017-07-13 | 2018-06-13 | 9 |  |  | start no earlier than 2017-07-12 |  |  |  |
| 11 | 1.1.9 | LANL LDRD | manual | 781d | 2016-10-03 | 2019-09-30 |  |  |  | finish no earlier than 2019-09-30 |  |  |  |
| 12 | 1.1.10 | sPHENIX Test Beam | manual | 21d | 2019-02-01 | 2019-03-01 |  |  |  |  |  |  |  |
| 13 | 1.2 | **Project Management** |  | 1217d | 2016-10-03 | 2021-06-01 |  | 0d |  |  |  | 2920.8h | 223,928 |
| 14 | 1.2.1 | Level 3 Project Manager |  | 1217d | 2016-10-03 | 2021-06-01 |  | 0d |  | finish no earlier than 2021-06-01 | Project Manager [20%] | 1947.2h |  |
| 15 | 1.2.2 | Mechanical Liason Engineer |  | 1217d | 2016-10-03 | 2021-06-01 |  | 0d |  | finish no earlier than 2021-06-01 | Mech Liason Eng [5%] | 486.8h | 111,964 |
| 16 | 1.2.3 | Electronics Liason Engineer |  | 1217d | 2016-10-03 | 2021-06-01 |  | 0d |  | finish no earlier than 2021-06-01 | Elec Liason Eng [5%] | 486.8h | 111,964 |
| 17 | 1.3 | **Design & Prototyping** |  | 363d | 2016-10-03 | 2018-02-21 |  | 333d |  |  |  | 7555.49h | 1,220,498.18 |
| 18 | 1.3.1 | **Readout Test Stand** |  | 35d | 2016-10-03 | 2016-11-18 |  | 414d | 0d |  |  | 88h | 36,400 |
| 19 | 1.3.1.1 | Design | milestone | 0d | 2016-10-03 | 2016-10-03 |  | 414d | 0d | start no earlier than 2016-10-03 |  |  |  |
| 20 | 1.3.1.2 | Procure 2 Stands |  | 30d | 2016-10-03 | 2016-11-11 | 19 | 414d | 0d |  | Elec tech [10%]; Physicist [20%] | 40h | 34,800 |
| 21 | 1.3.1.3 | Setup |  | 5d | 2016-11-14 | 2016-11-18 | 20 | 414d |  |  | Physicist; Elec tech [20%] | 48h | 1,600 |
| 22 | 1.3.2 | **Detector Staves** |  | 95d | 2017-07-31 | 2017-12-08 | 8SS+150d, 18 | 234d | 0d |  |  | 2200h | 199,000 |
| 23 | 1.3.2.1 | Procure 4 Staves |  | 90d | 2017-07-31 | 2017-12-01 |  | 234d | 0d |  | Physicist [200%]; Elec tech | 2160h | 199,000 |
| 24 | 1.3.2.2 | Test Staves |  | 5d | 2017-12-04 | 2017-12-08 | 23 | 234d |  |  | Physicist | 40h |  |

Notes:
- 19: The readout test stand design has already been completed by ALICE.
- 20: Cost from Leo. Only a few custom boards, standard items standard: power supplies, etc. One stand would be procured early, one late, both under LDRD.

| ID | WBS | Task | Duration | Start | Finish | Predecessors | Total slack | Free slack | Resources | Work | Cost |
| --- | --- | --- | --- | --- | --- | --- | --- | --- | --- | --- | --- |
| 25 | 1.3.3 | **Electronics** | 363d | 2016-10-03 | 2018-02-21 |  | 333d | 0d |  | 3141.09h | 474,218.18 |
| 26 | 1.3.3.1 | **ALICE Readout Electronics** | 264d | 2016-10-03 | 2017-10-05 |  | 929d | 87d |  | 605.09h | 49,418.18 |
| 27 | 1.3.3.1.1 | **SamTec Cables** | 62d | 2016-10-03 | 2016-12-27 |  | 1007d | 0d |  | 141.09h | 7,818.18 |
| 28 | 1.3.3.1.1.1 | Procure 7 SamTec Cables | 60d | 2016-10-03 | 2016-12-23 |  | 1007d | 0d | Physicist [20%]; Elec tech [10%] | 125.09h | 7,818.18 |
| 29 | 1.3.3.1.1.2 | Test Cables | 2d | 2016-12-26 | 2016-12-27 | 28 | 1007d |  | Physicist | 16h |  |
| 30 | 1.3.3.1.2 | **Readout Units (RDOs)** | 62d | 2017-07-12 | 2017-10-05 | 9 | 929d |  |  | 144h | 11,400 |
| 31 | 1.3.3.1.2.1 | Procure 4 RDOs | 60d | 2017-07-12 | 2017-10-03 |  | 929d | 0d | Physicist [20%]; Elec tech [10%] | 128h | 11,400 |
| 32 | 1.3.3.1.2.2 | Test RDOs | 2d | 2017-10-04 | 2017-10-05 | 31 | 929d |  | Physicist | 16h |  |
| 33 | 1.3.3.1.3 | **Optical Cables** | 62d | 2016-12-28 | 2017-03-23 | 27 | 1007d | 0d |  | 160h | 10,600 |
| 34 | 1.3.3.1.3.1 | Procure 4 Optical Cables | 60d | 2016-12-28 | 2017-03-21 |  | 1007d | 0d | Physicist [20%]; Elec tech [10%] | 144h | 10,600 |
| 35 | 1.3.3.1.3.2 | Test Optical Cables | 2d | 2017-03-22 | 2017-03-23 | 34 | 1007d |  | Physicist | 16h |  |
| 36 | 1.3.3.1.4 | **Common Readout Units (CRUs)** | 62d | 2017-03-24 | 2017-06-19 | 33 | 1007d |  |  | 160h | 19,600 |
| 37 | 1.3.3.1.4.1 | Procure 2 CRUs | 60d | 2017-03-24 | 2017-06-15 |  | 1007d | 0d | Physicist [20%]; Elec tech [10%] | 144h | 19,600 |
| 38 | 1.3.3.1.4.2 | Test CRUs | 2d | 2017-06-16 | 2017-06-19 | 37 | 1007d |  | Physicist | 16h |  |
| 39 | 1.3.3.2 | **sPHENIX Readout Electronics** | 351d | 2016-10-03 | 2018-02-05 |  | 333d | 0d |  | 2424h | 404,800 |
| 40 | 1.3.3.2.1 | obtain ALICE Readout Unit design | 1d | 2016-10-03 | 2016-10-03 |  | 333d | 0d | Physicist; Electrical Engineer | 8h |  |
| 41 | 1.3.3.2.2 | initial design | 40d | 2016-10-04 | 2016-11-28 | 40 | 333d | 0d | Electronics Engineer | 320h | 80,000 |
| 42 | 1.3.3.2.3 | prototype | 60d | 2016-11-29 | 2017-02-20 | 41 | 333d | 0d | Physicist [20%]; Elec tech [10%] | 144h | 14,600 |
| 43 | 1.3.3.2.4 | test | 20d | 2017-02-21 | 2017-03-20 | 42 | 333d | 0d | Electronics Engineer [33%]; Physicist [33%] | 64h | 2,800 |
| 44 | 1.3.3.2.5 | revised design | 30d | 2017-03-21 | 2017-05-01 | 43 | 333d | 0d | Electronics Engineer | 240h | 60,000 |
| 45 | 1.3.3.2.6 | prototype | 60d | 2017-05-02 | 2017-07-24 | 44 | 333d | 0d | Physicist [20%]; Elec tech [10%] | 144h | 14,600 |
| 46 | 1.3.3.2.7 | test | 20d | 2017-07-25 | 2017-08-21 | 45 | 842d | 0d | Electronics Engineer [33%]; Physicist [33%] | 64h | 2,800 |
| 47 | 1.3.3.2.8 | final design | 30d | 2017-08-22 | 2017-10-02 | 46 | 842d | 0d | Electronics Engineer | 240h | 60,000 |
| 48 | 1.3.3.2.9 | Procure 4 FEMs | 60d | 2017-10-03 | 2017-12-25 | 47 | 842d | 0d | Physicist [20%]; Elec tech [10%] | 144h | 29,600 |
| 49 | 1.3.3.2.10 | System Test | 30d | 2017-12-26 | 2018-02-05 | 48 | 842d |  | Electronics Engineer [33%]; Physicist [33%] | 105.6h | 6,600 |

| ID | WBS | Task | Duration | Start | Finish | Predecessors | Total slack | Free slack | Constraint | Resources | Work | Cost |
| --- | --- | --- | --- | --- | --- | --- | --- | --- | --- | --- | --- | --- |
| 50 | 1.3.3.2.11 | **sPHENIX Integration** | 180d | 2016-10-03 | 2017-06-09 |  | 364d |  |  |  | 950.4h | 133,800 |
| 51 | 1.3.3.2.11.1 | Slow Control Design | 60d | 2016-10-03 | 2016-12-23 |  | 364d | 0d |  | Physicist [33%]; Electronics Engineer [33%] | 316.8h | 44,600 |
| 52 | 1.3.3.2.11.2 | Trigger Interface Design | 60d | 2016-12-26 | 2017-03-17 | 51 | 364d | 0d |  | Physicist [33%]; Electronics Engineer [33%] | 316.8h | 44,600 |
| 53 | 1.3.3.2.11.3 | DAQ Interface Design | 60d | 2017-03-20 | 2017-06-09 | 52 | 364d | 130d |  | Physicist [33%]; Electronics Engineer [33%] | 316.8h | 44,600 |
| 54 | 1.3.3.3 | **Electronics Final Design Review** | 12d | 2018-02-06 | 2018-02-21 | 26, 39 | 842d |  |  |  | 112h | 20,000 |
| 55 | 1.3.3.3.1 | Electronics Design Review | 1d | 2018-02-06 | 2018-02-06 |  | 842d | 0d |  | Electronics Engineer; Physicist | 16h | 2,000 |
| 56 | 1.3.3.3.2 | Incorporate Review Comments | 10d | 2018-02-07 | 2018-02-20 | 55 | 842d | 0d |  | Elec tech | 80h | 16,000 |
| 57 | 1.3.3.3.3 | Electronics Design Review | 1d | 2018-02-21 | 2018-02-21 | 56 | 842d |  |  | Electronics Engineer; Physicist | 16h | 2,000 |
| 58 | 1.3.4 | **Ancillaries** | 60d | 2016-11-21 | 2017-02-10 | 18 | 449d | 215d |  |  | 432h | 65,800 |
| 59 | 1.3.4.1 | Procure LV,HV,etc | 60d | 2016-11-21 | 2017-02-10 |  | 449d |  | start no earlier than 2016-10-03 | Physicist [20%]; Elec tech [10%] | 144h | 34,600 |
| 60 | 1.3.4.2 | Procure Racks | 60d | 2016-11-21 | 2017-02-10 |  | 449d |  | start no earlier than 2016-10-03 | Physicist [20%]; Elec tech [10%] | 144h | 14,600 |
| 61 | 1.3.4.3 | Procure Chiller | 60d | 2016-11-21 | 2017-02-10 |  | 449d |  |  | Physicist [20%]; Elec tech [10%] | 144h | 16,600 |
| 62 | 1.3.5 | **Mechanics** | 218d | 2016-10-03 | 2017-08-02 |  | 987d | 145d |  |  | 1694.4h | 445,080 |
| 63 | 1.3.5.1 | obtain ALICE CAD model | 1d | 2016-10-03 | 2016-10-03 |  | 987d | 0d | start no earlier than 2016-06-01 | Physicist; Mechanical Engineer | 16h | 2,000 |
| 64 | 1.3.5.2 | **Specifications** | 15d | 2016-10-04 | 2016-10-24 | 63 | 987d | 0d |  |  | 80h | 20,000 |
| 65 | 1.3.5.2.1 | review heat load | 5d | 2016-10-04 | 2016-10-10 |  | 987d | 0d | start no earlier than 2016-10-03 | Mechanical Engineer | 40h | 10,000 |
| 66 | 1.3.5.2.2 | review mechanical tolerances/distortions | 5d | 2016-10-11 | 2016-10-17 | 65 | 987d | 0d | start no earlier than 2004-10-01 | Mechanical Engineer [50%] | 20h | 5,000 |
| 67 | 1.3.5.2.3 | review disassembly/repair options | 5d | 2016-10-18 | 2016-10-24 | 66 | 987d | 0d | start no earlier than 2004-10-01 | Mechanical Engineer [50%] | 20h | 5,000 |
| 68 | 1.3.5.3 | **Support Structure & Global Interface to sPHENIX** | 145d | 2016-10-25 | 2017-05-15 | 64 | 987d | 0d |  |  | 680h | 191,000 |
| 69 | 1.3.5.3.1 | design | 60d | 2016-10-25 | 2017-01-16 | 67 | 987d | 0d | start no earlier than 2007-10-01 | Mechanical Engineer | 480h | 120,000 |
| 70 | 1.3.5.3.2 | prototype | 60d | 2017-01-17 | 2017-04-10 | 69 | 987d | 0d |  |  |  | 25,000 |
| 71 | 1.3.5.3.3 | test | 10d | 2017-04-11 | 2017-04-24 | 70 | 987d | 0d |  | Mech Tech | 80h | 16,000 |
| 72 | 1.3.5.3.4 | final design | 15d | 2017-04-25 | 2017-05-15 | 71 | 987d |  |  | Mechanical Engineer | 120h | 30,000 |
| 73 | 1.3.5.4 | **Cooling System** | 20d | 2016-10-25 | 2016-11-21 | 64 | 1092d | 0d |  |  | 106.4h | 35,280 |
| 74 | 1.3.5.4.1 | Design | 10d | 2016-10-25 | 2016-11-07 | 65 | 1092d | 0d |  | Mechanical Engineer | 80h | 20,000 |
| 75 | 1.3.5.4.2 | Mock up Testing | 10d | 2016-11-08 | 2016-11-21 | 74 | 1092d |  |  | Mech Tech [33%] | 26.4h | 15,280 |

| ID | WBS | Task | Duration | Start | Finish | Predecessors | Total slack | Free slack | Constraint | Resources | Work | Cost |
| --- | --- | --- | --- | --- | --- | --- | --- | --- | --- | --- | --- | --- |
| 76 | 1.3.5.5 | **Safety Systems** | 65d | 2016-11-22 | 2017-02-20 | 73 | 1092d | 105d |  |  | 520h | 140,000 |
| 77 | 1.3.5.5.1 | review sensors & interlocks | 5d | 2016-11-22 | 2016-11-28 |  | 1092d | 0d |  | Mechanical Engineer | 40h | 10,000 |
| 78 | 1.3.5.5.2 | electrical interlock design | 30d | 2016-11-29 | 2017-01-09 | 77 | 1092d | 0d |  | Electronics Engineer | 240h | 65,000 |
| 79 | 1.3.5.5.3 | cooling interlocks design | 30d | 2017-01-10 | 2017-02-20 | 78 | 1092d |  |  | Mechanical Engineer | 240h | 65,000 |
| 80 | 1.3.5.6 | **Tooling** | 45d | 2017-05-16 | 2017-07-17 | 68 | 987d | 0d |  |  | 180h | 36,800 |
| 81 | 1.3.5.6.1 | design | 10d | 2017-05-16 | 2017-05-29 |  | 987d | 0d |  | Mechanical Engineer | 80h | 20,000 |
| 82 | 1.3.5.6.2 | prototype | 30d | 2017-05-30 | 2017-07-10 | 81 | 987d | 0d |  | Physicist [20%]; Mech Tech [10%] | 60h | 6,800 |
| 83 | 1.3.5.6.3 | final design | 5d | 2017-07-11 | 2017-07-17 | 82 | 987d |  |  | Mechanical Engineer | 40h | 10,000 |
| 84 | 1.3.5.7 | **Mechanics Final Design Review** | 12d | 2017-07-18 | 2017-08-02 | 68, 73, 76, 80 | 987d |  |  |  | 112h | 20,000 |
| 85 | 1.3.5.7.1 | Mechanics Final Design Review | 1d | 2017-07-18 | 2017-07-18 |  | 987d | 0d |  | Mechanical Engineer; Physicist | 16h | 2,000 |
| 86 | 1.3.5.7.2 | Incorporate Review Comments | 10d | 2017-07-19 | 2017-08-01 | 85 | 987d | 0d |  | Mech Tech | 80h | 16,000 |
| 87 | 1.3.5.7.3 | Mechanical Design Review Complete | 1d | 2017-08-02 | 2017-08-02 | 86 | 987d |  |  | Physicist; Mechanical Engineer | 16h | 2,000 |
| 88 | 1.4 | **Prototype Assembly** | 50d | 2017-12-11 | 2018-02-16 | 22, 58, 45 | 234d | 3d |  |  | 386.4h | 40,160 |
| 89 | 1.4.1 | Framing | 10d | 2017-12-11 | 2017-12-22 | 53 | 234d | 0d |  | Mech Tech [20%]; Physicist | 96h | 3,200 |
| 90 | 1.4.2 | Assemble prototype | 30d | 2017-12-25 | 2018-02-02 | 89 | 234d | 0d |  | Elec tech [33%]; Mech Tech [33%]; Physicist [33%] | 237.6h | 31,680 |
| 91 | 1.4.3 | Test prototype | 10d | 2018-02-02 | 2018-02-16 | 90 | 234d |  |  | Physicist [33%]; Elec tech [33%]; Mech Tech [33%] | 52.8h | 5,280 |
| 92 | 1.5 | **Test Beam Operation** | 35d | 2019-01-11 | 2019-02-28 | 88 | 0d |  |  |  | 290.67h | 30,800 |
| 93 | 1.5.1 | Shipping/Transport | 10d | 2019-01-11 | 2019-01-24 |  | 0d |  | as late as possible | Elec tech [20%]; Mech Tech [20%] | 18.67h | 13,733.33 |
| 94 | 1.5.2 | Setup | 5d | 2019-01-25 | 2019-01-31 | 93 | 0d |  | as late as possible | Physicist; Elec tech; Mech Tech | 80h | 10,666.67 |
| 95 | 1.5.3 | Operations | 20d | 2019-02-01 | 2019-02-28 | 94 | 0d |  | must start on 2019-02-01 | Physicist [200%]; Elec tech [20%] | 192h | 6,400 |
| 96 | 1.6 | **MAPS Inner Barrel Review** | 12d | 2018-02-22 | 2018-03-09 | 62, 25, 88 | 842d | 59d |  |  | 208h | 34,666.67 |
| 97 | 1.6.1 | Final Design Review | 1d | 2018-02-22 | 2018-02-22 |  | 842d | 0d |  | Electronics Engineer; Mechanical Engineer; Physicist | 24h | 4,000 |
| 98 | 1.6.2 | Incorporate Review Comments | 10d | 2018-02-23 | 2018-03-08 | 97 | 842d | 0d |  | Electronics Engineer; Mechanical Engineer; Physicist | 160h | 26,666.67 |
| 99 | 1.6.3 | Final Design Review | 1d | 2018-03-09 | 2018-03-09 | 98 | 842d |  |  | Electronics Engineer; Mechanical Engineer; Physicist | 24h | 4,000 |

| ID | WBS | Task | Duration | Start | Finish | Predecessors | Total slack | Free slack | Constraint | Resources | Work | Cost |
| --- | --- | --- | --- | --- | --- | --- | --- | --- | --- | --- | --- | --- |
| 100 | 1.7 | **Procurements** | 480d | 2018-08-01 | 2020-06-02 | 6 | 134d | 0d |  |  | 5616h | 2,312,800 |
| 101 | 1.7.1 | Produce 58 Inner Staves | 150d | 2018-08-01 | 2019-02-26 |  | 344d | 0d | start no earlier than 2018-01-01 | Physicist [200%]; Elec tech | 3600h | 1,025,000 |
| 102 | 1.7.2 | Procure 100 SamTec Cables | 60d | 2018-08-01 | 2018-10-23 |  | 374d | 0d |  | Physicist [10%]; Elec tech [20%] | 144h | 46,200 |
| 103 | 1.7.3 | Procure 58 Readout / FEM Units | 60d | 2019-02-27 | 2019-05-21 | 101 | 344d | 0d |  | Physicist [10%]; Elec tech [20%] | 144h | 294,200 |
| 104 | 1.7.4 | Procure Optical Links | 60d | 2018-10-24 | 2019-01-15 | 102 | 374d | 0d |  | Physicist [10%]; Elec tech [20%] | 144h | 55,200 |
| 105 | 1.7.5 | Procure 29 Common Readout Units | 60d | 2019-05-22 | 2019-08-13 | 103 | 344d |  |  | Physicist [10%]; Elec tech [20%] | 144h | 174,200 |
| 106 | 1.7.6 | Procure Ancillary Materials | 60d | 2019-01-16 | 2019-04-09 | 104 | 374d | 0d |  | Physicist [10%]; Mech Tech [20%] | 144h | 79,200 |
| 107 | 1.7.7 | Procure Cooling Plant | 60d | 2019-04-10 | 2019-07-02 | 106 | 374d |  |  | Physicist [10%]; Mech Tech [20%] | 144h | 136,200 |
| 108 | 1.7.8 | Procure Assembly Fixtures & Jigs | 60d | 2018-08-01 | 2018-10-23 |  | 134d | 0d |  | Physicist [10%]; Mech Tech [20%] | 144h | 119,200 |
| 109 | 1.7.9 | Procure End Wheels | 60d | 2018-10-24 | 2019-01-15 | 108 | 134d | 0d |  | Physicist [10%]; Mech Tech [20%] | 144h | 53,200 |
| 110 | 1.7.10 | Procure Cylindrical Structural Shells | 60d | 2019-01-16 | 2019-04-09 | 109 | 134d | 0d |  | Physicist [10%]; Mech Tech [20%] | 144h | 30,200 |
| 111 | 1.7.11 | Procure Detector Half Barrels | 60d | 2019-04-10 | 2019-07-02 | 110 | 134d | 0d |  | Physicist [10%]; Mech Tech [20%] | 144h | 32,200 |
| 112 | 1.7.12 | Procure Service Half Barrels | 60d | 2019-07-03 | 2019-09-24 | 111 | 134d | 0d |  | Physicist [10%]; Mech Tech [20%] | 144h | 139,200 |
| 113 | 1.7.13 | Procure Detector and Service Half Barrels | 60d | 2019-09-25 | 2019-12-17 | 112 | 134d | 0d |  | Physicist [10%]; Mech Tech [20%] | 144h | 40,200 |
| 114 | 1.7.14 | Procure Two Half Support Structures | 120d | 2019-12-18 | 2020-06-02 | 113 | 134d |  |  | Physicist [10%]; Mech Tech [20%] | 288h | 88,400 |
| 115 | 1.8 | **Assembly and Testing** | 450d | 2019-02-27 | 2020-11-17 |  | 134d |  |  |  | 1083.2h | 138,560 |
| 116 | 1.8.1 | Stave Reciept Inspection | 10d | 2019-02-27 | 2019-03-12 | 101 | 374d | 0d |  | Physicist; Elec tech [33%] | 106.4h | 5,280 |
| 117 | 1.8.2 | Individual Stave Readout Test | 60d | 2019-03-13 | 2019-06-04 | 116 | 374d | 0d |  | Physicist; Elec tech [33%] | 238.4h | 31,680 |
| 118 | 1.8.3 | Metrology on Stave Assemblies | 20d | 2019-06-05 | 2019-07-02 | 117 | 374d | 240d |  | Mechanical Engineer | 160h | 40,000 |
| 119 | 1.8.4 | Assemble full Ladders into Half support | 100d | 2020-06-03 | 2020-10-20 | 118, 100 | 134d | 0d |  | Mech Tech; Physicist [33%] | 392h | 25,600 |
| 120 | 1.8.5 | Metrology on Final Assembly | 10d | 2020-10-21 | 2020-11-03 | 119 | 134d | 0d |  | Mechanical Engineer | 80h | 20,000 |
| 121 | 1.8.6 | Test Half detector Assembly | 10d | 2020-11-04 | 2020-11-17 | 120 | 134d | 0d |  | Physicist [33%]; Mech Tech | 106.4h | 16,000 |
| 122 | 1.9 | **Installation** | 6d | 2020-11-18 | 2020-11-25 | 121 | 134d | 133d |  |  | 48h | 8,000 |
| 123 | 1.9.1 | Installation Prep | 5d | 2020-11-18 | 2020-11-24 | 121 | 134d | 0d |  | Mech Tech | 40h | 8,000 |
| 124 | 1.9.2 | Installation Review | 1d | 2020-11-25 | 2020-11-25 | 123 | 134d |  |  | Physicist | 8h |  |
