# MAPS Inner Barrel

Schedule from MS Project, 2016-10-01 to 2021-06-01, costs in $, A marks actual dates.
Guest Scientist, LANL

## Calendars

- Standard: Mon-Fri 08:00-12:00, 13:00-17:00; Sat-Sun off.

## Resources

| Resource | Rate | Cost per use |
| --- | --- | --- |
| Mech Liason Eng | 230 |  |
| Elec Liason Eng | 230 |  |
| Project Manager | 230 |  |
| Physicist |  |  |
| Elec tech | 200 |  |
| Mech Tech | 200 |  |
| Electronics Engineer | 250 |  |
| Mechanical Engineer | 250 |  |
| M&S |  | 1 |
| Electrical Engineer |  |  |

## Schedule

| ID | WBS | Task | Type | Duration | Start | Finish | Predecessors | Complete | Remaining | Actual start | Total slack | Free slack | Constraint | Resources | Work | Actual work | Cost | Actual cost | DOE Cost | Text10 | Cost Center |
| --- | --- | --- | --- | --- | --- | --- | --- | --- | --- | --- | --- | --- | --- | --- | --- | --- | --- | --- | --- | --- | --- |
| 1 | 1 | **MAPS Inner Barrel** |  | 1217d | 2016-10-03 | 2021-06-01 |  |  | 1212.8d | 2016-10-01 |  |  | start no earlier than 2005-10-21 |  | 26237h | 40h | 4,779,548.24 | 19,800 |  |  |  |
| 2 | 1.1 | MAPS Inner Barrel Starts | milestone | 0d | 2016-10-01 | 2016-10-01 |  |  |  |  | 0d |  | must start on 2016-10-01 |  |  |  |  |  | DOE |  |  |
| 3 | 1.2 | MAPS Inner Barrel Ends | milestone | 0d | 2021-06-01 | 2021-06-01 |  |  |  |  | 0d |  | must finish on 2021-06-01 |  |  |  |  |  | DOE |  |  |
| 4 | 1.3 | **Milestones of sPHENIX** |  | 1216d | 2016-10-03 | 2021-06-01 |  |  |  |  | 1d |  |  |  |  |  |  |  |  |  |  |
| 5 | 1.3.1 | sPHENIX Technical Design CD-0 | milestone | 0d | 2016-11-01 | 2016-11-01 |  |  |  |  | 1196d |  | start no earlier than 2016-11-01 |  |  |  |  |  |  | CD-0 (11/2016) |  |
| 6 | 1.3.2 | sPHENIX Technical Design (CD-1/CD-3a) | milestone | 0d | 2017-11-01 | 2017-11-01 |  |  |  |  | 155d | 81d | start no earlier than 2017-11-01 |  |  |  |  |  |  | CD-1 (11/2017) |  |
| 7 | 1.3.3 | sPHENIX Technical Dewsgin (CD-2) | milestone | 0d | 2018-06-01 | 2018-06-01 | 104 |  |  |  | 783d |  | start no earlier than 2018-06-01 |  |  |  |  |  |  | CD-2 (6/2018) |  |
| 8 | 1.3.4 | sPHENIX Start Construction (CD-3b) | milestone | 0d | 2018-08-01 | 2018-08-01 |  |  |  |  | 3d | 0d | start no earlier than 2018-08-01 |  |  |  |  |  |  | CD-3b (8/2018) |  |
| 9 | 1.3.5 | sPHENIX Installation | milestone | 0d | 2021-06-01 | 2021-06-01 | 136 |  |  |  | 1d |  | start no earlier than 2021-06-01 |  |  |  |  |  |  | Installation (6/2021) |  |
| 10 | 1.3.6 | ALICE ITS Inner Barrel Construction |  | 261d | 2017-01-02 | 2018-01-01 |  |  |  |  | 234d | 0d | start no earlier than 2017-01-02 |  |  |  |  |  |  |  |  |
| 11 | 1.3.7 | ALICE ITS Electronics Pre-Production |  | 100d | 2017-02-22 | 2017-07-11 |  |  |  |  | 421d | 0d | start no earlier than 2017-02-22 |  |  |  |  |  |  |  |  |
| 12 | 1.3.8 | ALICE ITS Electronics Production |  | 240d | 2017-07-13 | 2018-06-13 | 11 |  |  |  | 774d |  | start no earlier than 2017-07-13 |  |  |  |  |  |  |  |  |
| 13 | 1.3.9 | LANL LDRD |  | 781d | 2016-10-03 | 2019-09-30 |  |  |  |  | 436d |  | start no earlier than 2016-10-03 |  |  |  |  |  |  | LDRD | LDRD |
| 14 | 1.3.10 | sPHENIX Test Beam |  | 21d | 2019-02-01 | 2019-03-01 |  |  |  |  | 587d |  | start no earlier than 2019-02-01 |  |  |  |  |  |  |  | LDRD |
| 15 | 1.4 | **Project Management** |  | 1217d | 2016-10-03 | 2021-06-01 |  |  |  |  | 0d |  |  |  | 2920.8h |  | 671,784 |  |  | sPHENIX MAPS Project |  |
| 16 | 1.4.1 | Level 3 Project Manager |  | 1217d | 2016-10-03 | 2021-06-01 |  |  |  |  | 0d |  | start no earlier than 2016-10-03 | Project Manager [20%] | 1947.2h |  | 447,856 |  |  |  |  |
| 17 | 1.4.2 | Mechanical Liason Engineer |  | 1217d | 2016-10-03 | 2021-06-01 |  |  |  |  | 0d |  | finish no earlier than 2021-06-01 | Mech Liason Eng [5%] | 486.8h |  | 111,964 |  | DOE |  |  |
| 18 | 1.4.3 | Electronics Liason Engineer |  | 1217d | 2016-10-03 | 2021-06-01 |  |  |  |  | 0d |  | finish no earlier than 2021-06-01 | Elec Liason Eng [5%] | 486.8h |  | 111,964 |  | DOE |  |  |
| 19 | 1.5 | **Design & Prototyping** |  | 363d | 2016-10-03 A | 2018-02-21 |  | 2% | 354.99d |  | 105d |  |  |  | 7792.36h | 40h | 959,690.91 | 19,800 |  | LDRD/R&D |  |
| 20 | 1.5.1 | **Readout Test Stand** |  | 65d | 2016-10-03 A | 2016-12-30 |  | 43% | 37.14d |  | 227d | 0d |  |  | 132h | 40h | 45,600 | 19,800 |  |  | LDRD |
| 21 | 1.5.1.1 | Obtain Design from CERN |  | 5d | 2016-10-03 | 2016-10-07 |  |  |  |  | 25d | 0d | start no earlier than 2016-10-03 | Electronics Engineer [20%] | 8h |  | 2,000 |  |  |  | LDRD |
| 22 | 1.5.1.2 | Procure 2 Test Stands |  | 60d | 2016-10-03 A | 2016-12-23 | 21 | 50% | 30d |  | 384d | 0d |  | Elec tech [10%]; Physicist [20%] | 64h | 40h | 39,600 | 19,800 |  |  | LDRD |
| 23 | 1.5.1.3 | Setup Test Stands |  | 5d | 2016-12-26 | 2016-12-30 | 22 |  |  |  | 384d |  |  | Physicist; Elec tech [50%] | 60h |  | 4,000 |  |  |  | LDRD |
| 24 | 1.5.2 | **Detector Staves** |  | 95d | 2017-07-31 | 2017-12-08 | 10SS+150d, 20 |  |  |  | 77d | 0d |  |  | 1880h |  | 127,000 |  |  |  | LDRD |
| 25 | 1.5.2.1 | Procure and Produce 4 Staves |  | 90d | 2017-07-31 | 2017-12-01 |  |  |  |  | 234d | 0d |  | Physicist [200%]; Elec tech [50%] | 1800h |  | 127,000 |  |  |  | LDRD |
| 26 | 1.5.2.2 | Test Staves |  | 5d | 2017-12-04 | 2017-12-08 | 25 |  |  |  | 234d |  |  | Physicist [200%] | 80h |  |  |  |  |  | LDRD |

Notes:
- 6: critical and lond lead time items can be purchased at CD3a
- 8: constructino fund available at CD-3b
- 21: The readout test stand design has already been completed by ALICE.
- 22: Cost from Leo. Only a few custom boards, standard items standard: power supplies, etc. One stand would be procured early, one late, both under LDRD. / CERN-LANL MOU comes later in 2016, ~Dec. 2016? / Time needed to setup an CERN accout etc. may delay the actual procument date. MXL

| ID | WBS | Task | Type | Duration | Start | Finish | Predecessors | Total slack | Free slack | Resources | Work | Cost | Cost Center |
| --- | --- | --- | --- | --- | --- | --- | --- | --- | --- | --- | --- | --- | --- |
| 27 | 1.5.3 | **Electronics** |  | 363d | 2016-10-03 | 2018-02-21 |  | 105d | 31d |  | 3480.36h | 358,490.91 | LDRD |
| 28 | 1.5.3.1 | **ALICE Readout Electronics** |  | 267d | 2016-10-03 | 2017-10-10 |  | 189d | 84d |  | 384h | 37,200 |  |
| 29 | 1.5.3.1.1 | **SamTec Cables** |  | 12d | 2016-10-03 | 2016-10-18 |  | 367d | 0d |  | 48h | 5,200 |  |
| 30 | 1.5.3.1.1.1 | Procure 7 SamTec Cables |  | 10d | 2016-10-03 | 2016-10-14 |  | 599d | 0d | Physicist [20%]; Elec tech [20%] | 32h | 5,200 | LDRD |
| 31 | 1.5.3.1.1.2 | Test Cables |  | 2d | 2016-10-17 | 2016-10-18 | 30 | 599d |  | Physicist | 16h |  | LDRD |
| 32 | 1.5.3.1.2 | **Readout Units (RDOs)** |  | 65d | 2017-07-12 | 2017-10-10 | 11 | 189d |  |  | 116h | 10,600 |  |
| 33 | 1.5.3.1.2.1 | Procure 4 RDOs |  | 60d | 2017-07-12 | 2017-10-03 |  | 421d | 0d | Physicist [10%]; Elec tech [5%] | 64h | 8,200 | LDRD |
| 34 | 1.5.3.1.2.2 | Test RDOs |  | 5d | 2017-10-04 | 2017-10-10 | 33 | 421d |  | Physicist; Elec tech [30%] | 52h | 2,400 | LDRD |
| 35 | 1.5.3.1.3 | **Optical Cables** |  | 12d | 2016-10-19 | 2016-11-03 | 29 | 367d | 0d |  | 40h | 2,600 |  |
| 36 | 1.5.3.1.3.1 | Procure 4 Optical Cables |  | 10d | 2016-10-19 | 2016-11-01 |  | 599d | 0d | Physicist [20%]; Elec tech [10%] | 24h | 2,600 | LDRD |
| 37 | 1.5.3.1.3.2 | Test Optical Cables |  | 2d | 2016-11-02 | 2016-11-03 | 36 | 599d |  | Physicist | 16h |  | LDRD |
| 38 | 1.5.3.1.4 | **Common Readout Units (CRUs)** |  | 65d | 2016-11-04 | 2017-02-02 | 35 | 367d |  |  | 180h | 18,800 |  |
| 39 | 1.5.3.1.4.1 | Procure 2 CRUs |  | 60d | 2016-11-04 | 2017-01-26 |  | 599d | 0d | Physicist [20%]; Elec tech [5%] | 120h | 14,800 | LDRD |
| 40 | 1.5.3.1.4.2 | Test CRUs |  | 5d | 2017-01-27 | 2017-02-02 | 39 | 599d |  | Physicist; Elec tech [50%] | 60h | 4,000 | LDRD |
| 41 | 1.5.3.2 | **sPHENIX Readout Electronics Integration (FEM)** |  | 351d | 2016-10-03 | 2018-02-05 |  | 105d | 0d |  | 3008.36h | 309,290.91 |  |
| 42 | 1.5.3.2.1 | obtain ALICE Readout Unit design |  | 1d | 2016-10-03 | 2016-10-03 |  | 333d | 0d | Physicist; Electronics Engineer | 12h | 2,000 | LDRD |
| 43 | 1.5.3.2.2 | initial design |  | 40d | 2016-10-04 | 2016-11-28 | 42 | 333d | 0d | Electronics Engineer; Physicist [10%] | 192h | 40,000 | LDRD |
| 44 | 1.5.3.2.3 | prototype |  | 60d | 2016-11-29 | 2017-02-20 | 43 | 333d | 0d | Physicist [50%]; Elec tech [20%] | 336h | 24,200 | LDRD |
| 45 | 1.5.3.2.4 | test-I |  | 20d | 2017-02-21 | 2017-03-20 | 44 | 333d | 0d | Electronics Engineer [30%]; Physicist [50%] | 90.18h | 2,545.45 | LDRD |
| 46 | 1.5.3.2.5 | revised design |  | 30d | 2017-03-21 | 2017-05-01 | 45 | 333d | 0d | Electronics Engineer; Physicist [20%] | 168h | 30,000 | LDRD |
| 47 | 1.5.3.2.6 | prototype |  | 60d | 2017-05-02 | 2017-07-24 | 46 | 333d | 0d | Physicist [50%]; Elec tech [20%] | 336h | 24,200 | LDRD |
| 48 | 1.5.3.2.7 | test-II |  | 20d | 2017-07-25 | 2017-08-21 | 47 | 337d | 0d | Electronics Engineer [30%]; Physicist | 170.18h | 2,545.45 | LDRD |
| 49 | 1.5.3.2.8 | final design | milestone | 30d | 2017-08-22 | 2017-10-02 | 48 | 337d | 0d | Electronics Engineer; Physicist [20%] | 168h | 30,000 | LDRD |
| 50 | 1.5.3.2.9 | Procure 4 FEMs |  | 60d | 2017-10-03 | 2017-12-25 | 49 | 337d | 0d | Physicist [20%]; Elec tech [5%] | 120h | 24,800 | LDRD |
| 51 | 1.5.3.2.10 | System Test |  | 30d | 2017-12-26 | 2018-02-05 | 50 | 337d |  | Electronics Engineer [30%]; Physicist | 264h | 6,000 | LDRD |

| ID | WBS | Task | Type | Duration | Start | Finish | Predecessors | Total slack | Free slack | Constraint | Resources | Work | Cost | Cost Center |
| --- | --- | --- | --- | --- | --- | --- | --- | --- | --- | --- | --- | --- | --- | --- |
| 52 | 1.5.3.2.11 | **sPHENIX DAQ System Integration** |  | 180d | 2016-10-03 | 2017-06-09 |  | 207d |  |  |  | 1152h | 123,000 |  |
| 53 | 1.5.3.2.11.1 | Slow Control Design |  | 60d | 2016-10-03 | 2016-12-23 |  | 364d | 0d |  | Physicist [50%]; Electronics Engineer [30%] | 384h | 41,000 | LDRD |
| 54 | 1.5.3.2.11.2 | Trigger Interface Design |  | 60d | 2016-12-26 | 2017-03-17 | 53 | 364d | 0d |  | Physicist [50%]; Electronics Engineer [30%] | 384h | 41,000 | LDRD |
| 55 | 1.5.3.2.11.3 | DAQ Interface Design |  | 60d | 2017-03-20 | 2017-06-09 | 54 | 364d | 130d |  | Physicist [50%]; Electronics Engineer [30%] | 384h | 41,000 | LDRD |
| 56 | 1.5.3.3 | **Electronics Final Design Review** |  | 12d | 2018-02-06 | 2018-02-21 | 28, 41 | 105d |  |  |  | 88h | 12,000 |  |
| 57 | 1.5.3.3.1 | Electronics Design Review |  | 1d | 2018-02-06 | 2018-02-06 |  | 337d | 0d |  | Electronics Engineer; Physicist | 16h | 2,000 | LDRD |
| 58 | 1.5.3.3.2 | Incorporate Review Comments |  | 10d | 2018-02-07 | 2018-02-20 | 57 | 337d | 0d |  | Elec tech; Physicist [20%] | 56h | 8,000 | LDRD |
| 59 | 1.5.3.3.3 | Complete Final Electronics Design | milestone | 1d | 2018-02-21 | 2018-02-21 | 58 | 337d | 114d |  | Electronics Engineer; Physicist | 16h | 2,000 | LDRD |
| 60 | 1.5.4 | **Ancillaries** |  | 64d | 2017-01-02 | 2017-03-30 | 20 | 258d | 181d |  |  | 240h | 56,200 | LDRD |
| 61 | 1.5.4.1 | Procure LV,HV,etc |  | 60d | 2017-01-02 | 2017-03-24 |  | 258d | 0d | start no earlier than 2016-10-03 | Physicist [10%]; Elec tech [10%] | 96h | 34,600 | LDRD |
| 62 | 1.5.4.2 | Procure Racks |  | 60d | 2017-01-04 | 2017-03-28 | 61SS+2d | 258d | 0d | start no earlier than 2016-10-03 | Physicist [10%]; Elec tech [5%] | 72h | 9,800 | LDRD |
| 63 | 1.5.4.3 | Procure Chiller |  | 60d | 2017-01-06 | 2017-03-30 | 62SS+2d | 258d |  |  | Physicist [10%]; Elec tech [5%] | 72h | 11,800 | LDRD |
| 64 | 1.5.5 | **Mechanics** |  | 228d | 2016-10-03 | 2017-08-16 |  | 240d | 166d |  |  | 2060h | 372,400 | LDRD |
| 65 | 1.5.5.1 | obtain ALICE CAD model |  | 1d | 2016-10-03 | 2016-10-03 |  | 977d | 0d | start no earlier than 2016-06-01 | Physicist; Mechanical Engineer | 16h | 2,000 | LDRD |
| 66 | 1.5.5.2 | **Specifications** |  | 55d | 2016-10-04 | 2016-12-19 | 65 | 240d | 0d |  |  | 220h | 55,000 |  |
| 67 | 1.5.5.2.1 | review heat load |  | 40d | 2016-10-04 | 2016-11-28 |  | 977d | 0d | start no earlier than 2016-10-03 | Mechanical Engineer [50%] | 160h | 40,000 | LDRD |
| 68 | 1.5.5.2.2 | review mechanical tolerances/distortions |  | 10d | 2016-11-29 | 2016-12-12 | 67 | 977d | 0d | start no earlier than 2004-10-01 | Mechanical Engineer [50%] | 40h | 10,000 | LDRD |
| 69 | 1.5.5.2.3 | review disassembly/repair options |  | 5d | 2016-12-13 | 2016-12-19 | 68 | 977d | 0d | start no earlier than 2004-10-01 | Mechanical Engineer [50%] | 20h | 5,000 | LDRD |
| 70 | 1.5.5.3 | **Stave Support Frame & Global Interface to sPHENIX** |  | 115d | 2016-12-20 | 2017-05-29 | 66 | 240d | 0d |  |  | 1152h | 159,800 |  |
| 71 | 1.5.5.3.1 | initial design |  | 30d | 2016-12-20 | 2017-01-30 | 69 | 977d | 0d | start no earlier than 2007-10-01 | Mechanical Engineer; Physicist [20%] | 288h | 60,000 | LDRD |
| 72 | 1.5.5.3.2 | prototype |  | 60d | 2017-01-31 | 2017-04-24 | 71 | 977d | 0d |  | Mech Tech [30%]; Physicist | 624h | 53,800 | LDRD |
| 73 | 1.5.5.3.3 | test |  | 10d | 2017-04-25 | 2017-05-08 | 72 | 977d | 0d |  | Mech Tech; Physicist [50%] | 120h | 16,000 | LDRD |
| 74 | 1.5.5.3.4 | final design |  | 15d | 2017-05-09 | 2017-05-29 | 73 | 977d |  |  | Mechanical Engineer | 120h | 30,000 | LDRD |
| 75 | 1.5.5.4 | **Cooling System** |  | 20d | 2016-12-20 | 2017-01-16 | 66 | 310d | 0d |  |  | 120h | 38,000 |  |
| 76 | 1.5.5.4.1 | Design |  | 10d | 2016-12-20 | 2017-01-02 | 67 | 1047d | 0d |  | Mechanical Engineer | 80h | 20,000 | LDRD |
| 77 | 1.5.5.4.2 | Mock up Testing |  | 10d | 2017-01-03 | 2017-01-16 | 76 | 1047d |  |  | Mech Tech [50%] | 40h | 18,000 | LDRD |

Notes:
- 64: initial design by LDRD for CD-1 review; / Final desgin by DOE

| ID | WBS | Task | Type | Duration | Start | Finish | Predecessors | Total slack | Free slack | Constraint | Resources | Work | Cost | Cost Center |
| --- | --- | --- | --- | --- | --- | --- | --- | --- | --- | --- | --- | --- | --- | --- |
| 78 | 1.5.5.5 | **Safety Systems** |  | 70d | 2017-01-17 | 2017-04-24 | 75 | 310d | 70d |  |  | 184h | 56,000 |  |
| 79 | 1.5.5.5.1 | review sensors & interlocks |  | 10d | 2017-01-17 | 2017-01-30 |  | 1047d | 0d |  | Mechanical Engineer [50%] | 40h | 10,000 | LDRD |
| 80 | 1.5.5.5.2 | electrical interlock design |  | 30d | 2017-01-31 | 2017-03-13 | 79 | 1047d | 0d |  | Electronics Engineer [30%] | 72h | 23,000 | LDRD |
| 81 | 1.5.5.5.3 | cooling interlocks design |  | 30d | 2017-03-14 | 2017-04-24 | 80 | 1047d |  |  | Mechanical Engineer [30%] | 72h | 23,000 | LDRD |
| 82 | 1.5.5.6 | **Stave Assembly Tooling** |  | 45d | 2017-05-30 | 2017-07-31 | 70 | 240d | 0d |  |  | 240h | 41,600 |  |
| 83 | 1.5.5.6.1 | design |  | 10d | 2017-05-30 | 2017-06-12 |  | 977d | 0d |  | Mechanical Engineer | 80h | 20,000 | LDRD |
| 84 | 1.5.5.6.2 | prototype |  | 30d | 2017-06-13 | 2017-07-24 | 83 | 977d | 0d |  | Physicist [30%]; Mech Tech [20%] | 120h | 11,600 | LDRD |
| 85 | 1.5.5.6.3 | final design |  | 5d | 2017-07-25 | 2017-07-31 | 84 | 977d |  |  | Mechanical Engineer | 40h | 10,000 | LDRD |
| 86 | 1.5.5.7 | **Mechanics Coneptual Design Review** |  | 12d | 2017-08-01 | 2017-08-16 | 70, 75, 78, 82 | 240d |  |  |  | 128h | 20,000 |  |
| 87 | 1.5.5.7.1 | Mechanics Design Review |  | 1d | 2017-08-01 | 2017-08-01 |  | 977d | 0d |  | Mechanical Engineer; Physicist | 16h | 2,000 | LDRD |
| 88 | 1.5.5.7.2 | Incorporate Review Comments |  | 10d | 2017-08-02 | 2017-08-15 | 87 | 977d | 0d |  | Mech Tech; Physicist [20%] | 96h | 16,000 | LDRD |
| 89 | 1.5.5.7.3 | Complete Initall Mechanical Design (for CD-1) | milestone | 1d | 2017-08-16 | 2017-08-16 | 88 | 977d |  |  | Physicist; Mechanical Engineer | 16h | 2,000 | LDRD |
| 90 | 1.6 | **Prototype Assembly** |  | 50d | 2017-12-11 | 2018-02-16 | 24, 60, 47 | 77d | 34d |  |  | 784h | 72,000 | LDRD |
| 91 | 1.6.1 | Stave Framing Design |  | 10d | 2017-12-11 | 2017-12-22 | 55 | 234d | 0d |  | Mech Tech [50%]; Physicist [30%] | 64h | 8,000 | LDRD |
| 92 | 1.6.2 | Assemble prototype |  | 30d | 2017-12-25 | 2018-02-02 | 91 | 234d | 0d |  | Elec tech [50%]; Mech Tech [50%]; Physicist | 480h | 48,000 | LDRD |
| 93 | 1.6.3 | Prototype Full System Test |  | 10d | 2018-02-05 | 2018-02-16 | 92 | 234d | 0d |  | Physicist [200%]; Elec tech [50%]; Mech Tech [50%] | 240h | 16,000 | LDRD |
| 94 | 1.7 | **Test Beam Operation** |  | 35d | 2019-01-11 | 2019-02-28 | 90 | 0d |  |  |  | 290.67h | 30,800 | LDRD |
| 95 | 1.7.1 | Shipping/Transport |  | 10d | 2019-01-11 | 2019-01-24 |  | 0d |  | as late as possible | Elec tech [20%]; Mech Tech [20%] | 18.67h | 13,733.33 | LDRD |
| 96 | 1.7.2 | Setup |  | 5d | 2019-01-25 | 2019-01-31 | 95 | 0d |  | as late as possible | Physicist; Elec tech; Mech Tech | 80h | 10,666.67 | LDRD |
| 97 | 1.7.3 | Operations |  | 20d | 2019-02-01 | 2019-02-28 | 96 | 0d |  | must start on 2019-02-01 | Physicist [200%]; Elec tech [20%] | 192h | 6,400 | LDRD |
| 98 | 1.8 | **sPHENIX Mechanics Integration** |  | 34d? | 2018-02-19 | 2018-04-05 | 93 | 74d | 0d |  |  | 256h | 50,000 |  |
| 99 | 1.8.1 | Final Mechanics Desgin |  | 30d? | 2018-02-23 | 2018-04-05 | 6SS+1d, 93FS+1d | 811d |  | start no earlier than 2018-02-23 | Mechanical Engineer [50%]; Physicist [10%] | 144h | 30,000 | LDRD |
| 100 | 1.8.2 | **Mechanics Final Design Review** |  | 12d | 2018-02-19 | 2018-03-06 | 70, 75, 78, 82 | 96d |  |  |  | 112h | 20,000 |  |
| 101 | 1.8.2.1 | Mechanics Final Design Review |  | 1d | 2018-02-19 | 2018-02-19 |  | 833d | 0d |  | Mechanical Engineer; Physicist | 16h | 2,000 | LDRD |
| 102 | 1.8.2.2 | Incorporate Review Comments |  | 10d | 2018-02-20 | 2018-03-05 | 101 | 833d | 0d |  | Mech Tech | 80h | 16,000 | LDRD |
| 103 | 1.8.2.3 | Complete Final Mechanical Design | milestone | 1d | 2018-03-06 | 2018-03-06 | 102 | 833d | 22d |  | Physicist; Mechanical Engineer | 16h | 2,000 | LDRD |

Notes:
- 78: monitoring temp, flow rates, I, V etc.
- 86: For CD-1 review, 11/2017, conceptuall design of mechanis system
- 99: DOE project fund available

| ID | WBS | Task | Type | Duration | Start | Finish | Predecessors | Total slack | Free slack | Constraint | Resources | Work | Cost | DOE Cost | Text10 |
| --- | --- | --- | --- | --- | --- | --- | --- | --- | --- | --- | --- | --- | --- | --- | --- |
| 104 | 1.9 | **MAPS Inner Barrel Review** |  | 12d | 2018-04-06 | 2018-04-23 | 64, 27, 90, 103 | 74d | 28d |  |  | 181.33h | 28,000 |  |  |
| 105 | 1.9.1 | Final Design Review |  | 1d | 2018-04-06 | 2018-04-06 | 98 | 74d | 0d |  | Electronics Engineer; Mechanical Engineer; Physicist | 24h | 4,000 | DOE |  |
| 106 | 1.9.2 | Incorporate Review Comments |  | 10d | 2018-04-09 | 2018-04-20 | 105 | 74d | 0d |  | Electronics Engineer [50%]; Mechanical Engineer [50%]; Physicist | 133.33h | 20,000 | DOE |  |
| 107 | 1.9.3 | Complete Final Design | milestone | 1d | 2018-04-23 | 2018-04-23 | 106 | 74d | 71d |  | Electronics Engineer; Mechanical Engineer; Physicist | 24h | 4,000 | DOE |  |
| 108 | 1.10 | **Productions** |  | 642d | 2018-08-01 | 2021-01-14 | 8, 107 | 3d |  |  |  | 14011.9h | 2,967,273.33 |  | Production |
| 109 | 1.10.1 | Full Mechnicas System pre-Production Mock Up and Test Beam Analysis |  | 100d | 2019-03-01 | 2019-07-18 | 8, 97 | 139d | 0d |  | Mechanical Engineer [20%]; Mech Tech [30%]; Physicist | 464h | 88,000 |  |  |
| 110 | 1.10.2 | **Procurements** |  | 359d | 2018-08-01 | 2019-12-16 | 8 | 3d |  |  |  | 5267.2h | 2,279,140 |  |  |
| 111 | 1.10.2.1 | **CERN Procuments** |  | 180d | 2018-08-01 | 2019-04-09 | 8SS | 98d | 0d |  |  | 3811.2h | 1,077,840 |  |  |
| 112 | 1.10.2.1.1 | Produce 68 Inner Staves |  | 180d | 2018-08-01 | 2019-04-09 | 59, 8 | 223d | 0d | start no earlier than 2018-02-22 | Physicist [200%]; Elec tech [50%] | 3600h | 1,064,000 | DOE |  |
| 113 | 1.10.2.1.2 | Other ITS/CERN items |  | 120d | 2018-08-01 | 2019-01-15 | 8 | 353d |  |  | Physicist [20%]; Mech Tech [2%] | 211.2h | 13,840 |  |  |
| 114 | 1.10.2.2 | Procure 68 Readout / FEM Units |  | 100d | 2018-08-02 | 2018-12-19 | 8, 112SS+1d | 370d | 0d |  | Physicist [10%]; Elec tech [10%] | 160h | 338,000 | DOE |  |
| 115 | 1.10.2.3 | Procure Optical Links 68 |  | 60d | 2018-08-03 | 2018-10-25 | 8, 114SS+1d | 370d | 0d |  | Physicist [10%]; Elec tech [5%] | 72h | 47,000 | DOE |  |
| 116 | 1.10.2.4 | Procure 34 Common Readout Units | manual | 100d | 2018-08-06 | 2018-12-21 | 8, 115SS+1d |  |  |  | Physicist [10%]; Elec tech [5%] | 120h | 189,700 | DOE |  |
| 117 | 1.10.2.5 | Procure 100 SamTec Cables | manual | 60d | 2018-08-07 | 2018-10-29 | 8SS, 116SS+1d |  |  |  | Physicist [10%]; Elec tech [5%] | 72h | 31,800 | DOE |  |
| 118 | 1.10.2.6 | Procure Ancillary Materials (LVPS and cables etc) |  | 100d | 2018-08-08 | 2018-12-25 | 117SS+1d, 8 | 368d | 75d |  | Physicist [10%]; Mech Tech [5%] | 120h | 68,000 | DOE |  |
| 119 | 1.10.2.7 | Procure Cooling Plant |  | 100d | 2019-07-19 | 2019-12-05 | 109, 8 | 139d | 0d |  | Physicist [10%]; Mech Tech [5%] | 120h | 125,000 | DOE |  |
| 120 | 1.10.2.8 | Procure Assembly Fixtures & Jigs |  | 60d | 2019-07-22 | 2019-10-11 | 109, 119SS+1d | 139d | 0d |  | Physicist [10%]; Mech Tech [5%] | 72h | 104,800 | DOE |  |
| 121 | 1.10.2.9 | Procure End Wheels |  | 100d | 2019-07-23 | 2019-12-09 | 109, 120SS+1d | 139d | 0d |  | Physicist [10%]; Mech Tech [5%] | 120h | 42,000 | DOE |  |
| 122 | 1.10.2.10 | Procure Cylindrical Structural Shells |  | 100d | 2019-07-24 | 2019-12-10 | 121SS+1d | 139d | 0d |  | Physicist [10%]; Mech Tech [5%] | 120h | 19,000 | DOE |  |
| 123 | 1.10.2.11 | Procure Detector Half Barrels |  | 100d | 2019-07-25 | 2019-12-11 | 122SS+1d | 139d | 0d |  | Physicist [10%]; Mech Tech [5%] | 120h | 21,000 | DOE |  |
| 124 | 1.10.2.12 | Procure Service Half Barrels |  | 100d | 2019-07-26 | 2019-12-12 | 123SS+1d | 139d | 0d |  | Physicist [10%]; Mech Tech [5%] | 120h | 128,000 | DOE |  |
| 125 | 1.10.2.13 | Procure Detector and Service Half Barrels |  | 100d | 2019-07-29 | 2019-12-13 | 124SS+1d | 139d | 0d |  | Physicist [10%]; Mech Tech [5%] | 120h | 29,000 | DOE |  |
| 126 | 1.10.2.14 | Procure Two Half Support Structures |  | 100d | 2019-07-30 | 2019-12-16 | 125SS+1d | 139d | 41d |  | Physicist [10%]; Mech Tech [5%] | 120h | 58,000 | DOE |  |
| 127 | 1.10.3 | **Assembly and Testing at BNL** |  | 391d | 2019-04-10 | 2020-10-07 | 8, 111 | 98d |  |  |  | 6184.67h | 390,133.33 |  |  |
| 128 | 1.10.3.1 | Test Production FEMS, e-Links, CRU, LV, optical links |  | 90d | 2019-04-10 | 2019-08-13 | 114, 115, 116, 117, 118, 111 | 228d | 130d |  | Elec tech [30%]; Physicist [200%] | 1656h | 43,200 |  |  |
| 129 | 1.10.3.2 | Test Cooling System |  | 10d | 2019-12-06 | 2019-12-19 | 119 | 378d |  |  | Mech Tech [50%]; Physicist [50%] | 80h | 8,000 |  |  |
| 130 | 1.10.3.3 | Stave Reciept Inspection |  | 10d | 2019-04-10 | 2019-04-23 | 112 | 98d | 0d |  | Physicist [20%]; Elec tech [10.8%] | 24.67h | 1,733.33 | DOE |  |
| 131 | 1.10.3.4 | Individual Stave Readout Test |  | 140d | 2019-04-24 | 2019-11-05 | 130 | 98d | 0d |  | Physicist [300%]; Elec tech [20%] | 464h | 44,800 | DOE |  |
| 132 | 1.10.3.5 | Metrology on Stave Assemblies |  | 70d | 2019-11-06 | 2020-02-11 | 131 | 98d | 0d |  | Mechanical Engineer [30%] | 168h | 42,000 | DOE |  |
| 133 | 1.10.3.6 | Assemble full Ladders into Half support |  | 100d | 2020-02-12 | 2020-06-30 | 132, 110, 126, 125, 124, 123, 122, 121, 120, 128 | 98d | 0d |  | Mech Tech [150%]; Physicist [200%] | 1792h | 38,400 | DOE |  |
| 134 | 1.10.3.7 | Metrology on Final Assembly |  | 10d | 2020-07-01 | 2020-07-14 | 133 | 98d | 0d |  | Mechanical Engineer | 80h | 20,000 | DOE |  |
| 135 | 1.10.3.8 | Test Half detector Assembly |  | 60d | 2020-07-16 | 2020-10-07 | 134FS+1d, 128FS+1d | 98d | 0d |  | Physicist [200%]; Mech Tech; Elec tech | 1920h | 192,000 | DOE |  |

Notes:
- 109: Mechnics production test run; / may not needed?
- 112: 48+20% = 58; consider to have 40% spare: 68 in total / could start early right after ITS production end, ~2/23/18 (final electronics review finished) assuming sPHENIX can morgage with CERN to produce staves, can gain 6 months of advanced production; / production length ~ 6 months = 20x6days
- 113: other small items related to MAPS testing etc.
- 114: 48+40% spares; / obtain desgin files and produce them in US
- 130: start the assembly at partrial delivery of staves, 60days from the start of stave production ; / allow 10days for shipping from CERN to BNL; / partial delivery every month
- 131: Statve test starts 10 days after reciept of staves
- 133: can start earlier if procument (stave production) can be morgaged, by up to ~ 1 month in time.! / can start work as early as 2 days after the start of metrologly on stave assembly;

| ID | WBS | Task | Duration | Start | Finish | Predecessors | Total slack | Free slack | Resources | Work | Cost | DOE Cost |
| --- | --- | --- | --- | --- | --- | --- | --- | --- | --- | --- | --- | --- |
| 136 | 1.10.4 | **Installation** | 71d | 2020-10-08 | 2021-01-14 | 135 | 98d | 97d |  | 2096h | 210,000 |  |
| 137 | 1.10.4.1 | Installation Prep | 10d | 2020-10-08 | 2020-10-21 | 135 | 98d | 0d | Mech Tech; Physicist | 160h | 16,000 | DOE |
| 138 | 1.10.4.2 | Installation Review | 1d | 2020-10-22 | 2020-10-22 | 137 | 98d | 0d | Physicist; Mechanical Engineer | 16h | 2,000 | DOE |
| 139 | 1.10.4.3 | Installation | 60d | 2020-10-23 | 2021-01-14 | 138 | 98d |  | Physicist [200%]; Mech Tech; Elec tech | 1920h | 192,000 |  |

Notes:
- 136: installatino by 6/2021
