# MAPS Inner Barrel

Schedule from MS Project, 2016-10-01 to 2021-06-01, costs in $, A marks actual dates.
Guest Scientist, LANL

## Calendars

- Standard: Mon-Fri 08:00-12:00, 13:00-17:00; Sat-Sun off.

## Resources

| Resource | Rate | Cost per use |
| --- | --- | --- |
| Mech Liason Eng | 230 |  |
| Elec Liason Eng | 230 |  |
| Project Manager | 230 |  |
| Physicist |  |  |
| Elec tech | 200 |  |
| Mech Tech | 200 |  |
| Electronics Engineer | 250 |  |
| Mechanical Engineer | 250 |  |
| M&S |  | 1 |
| Electrical Engineer |  |  |

## Schedule

| ID | WBS | Task | Type | Duration | Start | Finish | Predecessors | Complete | Remaining | Actual start | Total slack | Free slack | Constraint | Resources | Work | Actual work | Cost | Actual cost | DOE Cost | Text10 | Cost Center |
| --- | --- | --- | --- | --- | --- | --- | --- | --- | --- | --- | --- | --- | --- | --- | --- | --- | --- | --- | --- | --- | --- |
| 1 | 1 | **MAPS Inner Barrel** |  | 1217d | 2016-10-03 | 2021-06-01 |  |  | 1213.05d | 2016-10-01 |  |  | start no earlier than 2005-10-21 |  | 27489h | 40h | 4,846,988.24 | 19,800 |  |  |  |
| 2 | 1.1 | MAPS Inner Barrel Starts | milestone | 0d | 2016-10-01 | 2016-10-01 |  |  |  |  | 0d |  | must start on 2016-10-01 |  |  |  |  |  | DOE |  |  |
| 3 | 1.2 | MAPS Inner Barrel Ends | milestone | 0d | 2021-06-01 | 2021-06-01 |  |  |  |  | 0d |  | must finish on 2021-06-01 |  |  |  |  |  | DOE |  |  |
| 4 | 1.3 | **Milestones of sPHENIX** |  | 1216d | 2016-10-03 | 2021-06-01 |  |  |  |  | 1d |  |  |  |  |  |  |  |  |  |  |
| 5 | 1.3.1 | sPHENIX Technical Design CD-0 | milestone | 0d | 2016-11-01 | 2016-11-01 |  |  |  |  | 1196d |  | start no earlier than 2016-11-01 |  |  |  |  |  |  | CD-0 (11/2016) |  |
| 6 | 1.3.2 | sPHENIX Technical Design (CD-1/CD-3a) | milestone | 0d | 2017-11-01 | 2017-11-01 |  |  |  |  | 155d |  | start no earlier than 2017-11-01 |  |  |  |  |  |  | CD-1 (11/2017) |  |
| 7 | 1.3.3 | sPHENIX Technical Dewsgin (CD-2) | milestone | 0d | 2018-08-13 | 2018-08-13 | 106 |  |  |  | 731d |  | start no earlier than 2018-06-01 |  |  |  |  |  |  | CD-2 (6/2018) |  |
| 8 | 1.3.4 | sPHENIX Start Construction (CD-3b) | milestone | 0d | 2018-08-01 | 2018-08-01 |  |  |  |  | 3d |  | start no earlier than 2018-08-01 |  |  |  |  |  |  | CD-3b (8/2018) |  |
| 9 | 1.3.5 | sPHENIX Installation | milestone | 0d | 2021-06-01 | 2021-06-01 | 140 |  |  |  | 1d |  | start no earlier than 2021-06-01 |  |  |  |  |  |  | ready for beam (6/2021) |  |
| 10 | 1.3.6 | ALICE ITS Inner Barrel Construction |  | 261d | 2017-01-02 | 2018-01-01 |  |  |  |  | 891d |  | start no earlier than 2017-01-02 |  |  |  |  |  |  | ITS construction |  |
| 11 | 1.3.7 | ALICE ITS Electronics Pre-Production |  | 100d | 2017-02-22 | 2017-07-11 |  |  |  |  | 184d | 0d | start no earlier than 2017-02-22 |  |  |  |  |  |  | ITS Electronics Pre-Production |  |
| 12 | 1.3.8 | ALICE ITS Electronics Production |  | 240d | 2017-07-13 | 2018-06-13 | 11 |  |  |  | 774d |  | start no earlier than 2017-07-13 |  |  |  |  |  |  | ITS Electronics Production |  |
| 13 | 1.3.9 | LANL LDRD |  | 781d | 2016-10-03 | 2019-09-30 |  |  |  |  | 436d |  | start no earlier than 2016-10-03 |  |  |  |  |  |  | LDRD | LDRD |
| 14 | 1.3.10 | sPHENIX Test Beam |  | 21d | 2019-02-01 | 2019-03-01 |  |  |  |  | 587d |  | start no earlier than 2019-02-01 |  |  |  |  |  |  |  | LDRD |
| 15 | 1.4 | **Project Management** |  | 1217d | 2016-10-03 | 2021-06-01 |  |  |  |  | 0d |  |  |  | 2920.8h |  | 671,784 |  |  | sPHENIX MAPS Project |  |
| 16 | 1.4.1 | Level 3 Project Manager |  | 1217d | 2016-10-03 | 2021-06-01 |  |  |  |  | 0d |  | start no earlier than 2016-10-03 | Project Manager [20%] | 1947.2h |  | 447,856 |  |  |  |  |
| 17 | 1.4.2 | Mechanical Liason Engineer |  | 1217d | 2016-10-03 | 2021-06-01 |  |  |  |  | 0d |  | finish no earlier than 2021-06-01 | Mech Liason Eng [5%] | 486.8h |  | 111,964 |  | DOE |  |  |
| 18 | 1.4.3 | Electronics Liason Engineer |  | 1217d | 2016-10-03 | 2021-06-01 |  |  |  |  | 0d |  | finish no earlier than 2021-06-01 | Elec Liason Eng [5%] | 486.8h |  | 111,964 |  | DOE |  |  |
| 19 | 1.5 | **Design & Prototyping** |  | 363d? | 2016-10-03 A | 2018-02-21 |  | 2% | 356.59d? |  | 854d |  |  |  | 7956.36h | 40h | 980,090.91 | 19,800 |  | LDRD/R&D | LDRD |
| 20 | 1.5.1 | MOU btw LANL/sPHENIX and ALICE | milestone | 60d? | 2016-10-03 | 2016-12-23 |  |  |  |  | 125d | 0d |  | Physicist [10%] | 48h |  |  |  |  |  |  |
| 21 | 1.5.2 | **Readout Test Stand** |  | 65d | 2016-10-03 A | 2016-12-30 |  | 43% | 37.14d |  | 1152d | 0d |  |  | 132h | 40h | 45,600 | 19,800 |  |  | LDRD |
| 22 | 1.5.2.1 | Obtain Design from CERN |  | 5d | 2016-10-03 | 2016-10-07 |  |  |  |  | 25d | 0d | start no earlier than 2016-10-03 | Electronics Engineer [20%] | 8h |  | 2,000 |  |  |  | LDRD |
| 23 | 1.5.2.2 | Procure 2 Test Stands |  | 60d | 2016-10-03 A | 2016-12-23 | 22 | 50% | 30d |  | 1152d | 0d |  | Elec tech [10%]; Physicist [20%] | 64h | 40h | 39,600 | 19,800 |  |  | LDRD |
| 24 | 1.5.2.3 | Setup Test Stands |  | 5d | 2016-12-26 | 2016-12-30 | 23 |  |  |  | 1152d |  |  | Physicist; Elec tech [50%] | 60h |  | 4,000 |  |  |  | LDRD |

Notes:
- 6: critical and lond lead time items can be purchased at CD3a
- 8: constructino fund available at CD-3b
- 9: commissioning 4/1-6/1, 2021; / ready for beam 6/1/2021
- 20: Use ITS production line to train local people and produce staves for sPHENIX; / provide 1 FTE from 1/2017 - 6/2018+ for LDRD and later for sPHENIX
- 22: The readout test stand design has already been completed by ALICE.
- 23: Cost from Leo. Only a few custom boards, standard items standard: power supplies, etc. One stand would be procured early, one late, both under LDRD. / CERN-LANL MOU comes later in 2016, ~Dec. 2016? / Time needed to setup an CERN accout etc. may delay the actual procument date. MXL

| ID | WBS | Task | Type | Duration | Start | Finish | Predecessors | Total slack | Free slack | Resources | Work | Cost | Cost Center |
| --- | --- | --- | --- | --- | --- | --- | --- | --- | --- | --- | --- | --- | --- |
| 25 | 1.5.3 | **Detector Staves** |  | 190d? | 2016-12-26 | 2017-09-15 |  | 125d |  |  | 1960h | 147,000 | LDRD |
| 26 | 1.5.3.1 | Procure and Produce 4 Staves |  | 180d | 2016-12-26 | 2017-09-01 | 20, 21SS | 125d | 0d | Physicist; Elec tech | 1800h | 127,000 | LDRD |
| 27 | 1.5.3.2 | Test Staves |  | 10d | 2017-09-04 | 2017-09-15 | 26 | 125d | 101d | Physicist [200%] | 160h |  | LDRD |
| 28 | 1.5.3.3 | Travel and Per Diem Support |  | 180d? | 2016-12-26 | 2017-09-01 | 26SS | 147d |  |  |  | 20,000 | LDRD |
| 29 | 1.5.4 | **Electronics** |  | 363d | 2016-10-03 | 2018-02-21 |  | 24d |  |  | 3532.36h | 360,890.91 | LDRD |
| 30 | 1.5.4.1 | **ALICE Readout Electronics** |  | 272d | 2016-10-03 | 2017-10-17 |  | 184d | 79d |  | 436h | 39,600 |  |
| 31 | 1.5.4.1.1 | **SamTec Cables** |  | 12d | 2016-10-03 | 2016-10-18 |  | 385d |  |  | 48h | 5,200 |  |
| 32 | 1.5.4.1.1.1 | Procure 7 SamTec Cables |  | 10d | 2016-10-03 | 2016-10-14 |  | 385d | 0d | Physicist [20%]; Elec tech [20%] | 32h | 5,200 | LDRD |
| 33 | 1.5.4.1.1.2 | Test Cables |  | 2d | 2016-10-17 | 2016-10-18 | 32 | 444d |  | Physicist | 16h |  | LDRD |
| 34 | 1.5.4.1.2 | **Readout Units (RDOs)** |  | 70d | 2017-07-12 | 2017-10-17 |  | 184d |  |  | 168h | 13,000 |  |
| 35 | 1.5.4.1.2.1 | Procure 4 RDOs |  | 60d | 2017-07-12 | 2017-10-03 | 32SS+1d, 11 | 184d | 0d | Physicist [10%]; Elec tech [5%] | 64h | 8,200 | LDRD |
| 36 | 1.5.4.1.2.2 | Test RDOs |  | 10d | 2017-10-04 | 2017-10-17 | 35 | 184d |  | Physicist; Elec tech [30%] | 104h | 4,800 | LDRD |
| 37 | 1.5.4.1.3 | **Optical Cables** |  | 12d | 2016-10-04 | 2016-10-19 |  | 443d | 0d |  | 40h | 2,600 |  |
| 38 | 1.5.4.1.3.1 | Procure 4 Optical Cables |  | 10d | 2016-10-04 | 2016-10-17 | 32SS+1d | 443d | 0d | Physicist [20%]; Elec tech [10%] | 24h | 2,600 | LDRD |
| 39 | 1.5.4.1.3.2 | Test Optical Cables |  | 2d | 2016-10-18 | 2016-10-19 | 38 | 443d |  | Physicist | 16h |  | LDRD |
| 40 | 1.5.4.1.4 | **Common Readout Units (CRUs)** |  | 65d | 2016-10-05 | 2017-01-03 |  | 389d |  |  | 180h | 18,800 |  |
| 41 | 1.5.4.1.4.1 | Procure 2 CRUs |  | 60d | 2016-10-05 | 2016-12-27 | 37SS+1d | 389d | 0d | Physicist [20%]; Elec tech [5%] | 120h | 14,800 | LDRD |
| 42 | 1.5.4.1.4.2 | Test CRUs |  | 5d | 2016-12-28 | 2017-01-03 | 41 | 389d |  | Physicist; Elec tech [50%] | 60h | 4,000 | LDRD |
| 43 | 1.5.4.2 | **sPHENIX Readout Electronics Integration (FEM)** |  | 351d | 2016-10-03 | 2018-02-05 |  | 24d |  |  | 3008.36h | 309,290.91 |  |
| 44 | 1.5.4.2.1 | obtain ALICE Readout Unit design |  | 1d | 2016-10-03 | 2016-10-03 |  | 24d | 0d | Physicist; Electronics Engineer | 12h | 2,000 | LDRD |
| 45 | 1.5.4.2.2 | initial design |  | 40d | 2016-10-04 | 2016-11-28 | 44 | 24d | 0d | Electronics Engineer; Physicist [10%] | 192h | 40,000 | LDRD |
| 46 | 1.5.4.2.3 | prototype |  | 60d | 2016-11-29 | 2017-02-20 | 45 | 24d | 0d | Physicist [50%]; Elec tech [20%] | 336h | 24,200 | LDRD |
| 47 | 1.5.4.2.4 | test-I |  | 20d | 2017-02-21 | 2017-03-20 | 46 | 24d | 0d | Electronics Engineer [30%]; Physicist [50%] | 90.18h | 2,545.45 | LDRD |
| 48 | 1.5.4.2.5 | revised design |  | 30d | 2017-03-21 | 2017-05-01 | 47 | 24d | 0d | Electronics Engineer; Physicist [20%] | 168h | 30,000 | LDRD |
| 49 | 1.5.4.2.6 | prototype |  | 60d | 2017-05-02 | 2017-07-24 | 48 | 24d | 0d | Physicist [50%]; Elec tech [20%] | 336h | 24,200 | LDRD |
| 50 | 1.5.4.2.7 | test-II |  | 20d | 2017-07-25 | 2017-08-21 | 49 | 24d | 0d | Electronics Engineer [30%]; Physicist | 170.18h | 2,545.45 | LDRD |
| 51 | 1.5.4.2.8 | final design | milestone | 30d | 2017-08-22 | 2017-10-02 | 50 | 24d | 0d | Electronics Engineer; Physicist [20%] | 168h | 30,000 | LDRD |
| 52 | 1.5.4.2.9 | Procure 4 FEMs |  | 60d | 2017-10-03 | 2017-12-25 | 51 | 24d | 0d | Physicist [20%]; Elec tech [5%] | 120h | 24,800 | LDRD |
| 53 | 1.5.4.2.10 | System Test |  | 30d | 2017-12-26 | 2018-02-05 | 52 | 24d | 0d | Electronics Engineer [30%]; Physicist | 264h | 6,000 | LDRD |

Notes:
- 26: work on MOU to get 4 staves as early as possible; / train LANL staff for MAPS assembly and test. M&S $10K for 4 months
- 27: assume testing 1 stave every two days;
- 28: $3K/month including lodging and per diem 1 FTE / for 6 months;
- 30: critical tasks
- 32: from DigiKey?
- 43: critical tasks

| ID | WBS | Task | Type | Duration | Start | Finish | Predecessors | Total slack | Free slack | Constraint | Resources | Work | Cost | Cost Center | Text10 |
| --- | --- | --- | --- | --- | --- | --- | --- | --- | --- | --- | --- | --- | --- | --- | --- |
| 54 | 1.5.4.2.11 | **sPHENIX DAQ System Integration** |  | 180d | 2016-10-03 | 2017-06-09 |  | 195d |  |  |  | 1152h | 123,000 |  |  |
| 55 | 1.5.4.2.11.1 | Slow Control Design |  | 60d | 2016-10-03 | 2016-12-23 |  | 195d | 0d |  | Physicist [50%]; Electronics Engineer [30%] | 384h | 41,000 | LDRD |  |
| 56 | 1.5.4.2.11.2 | Trigger Interface Design |  | 60d | 2016-12-26 | 2017-03-17 | 55 | 195d | 0d |  | Physicist [50%]; Electronics Engineer [30%] | 384h | 41,000 | LDRD |  |
| 57 | 1.5.4.2.11.3 | DAQ Interface Design |  | 60d | 2017-03-20 | 2017-06-09 | 56 | 195d | 171d |  | Physicist [50%]; Electronics Engineer [30%] | 384h | 41,000 | LDRD |  |
| 58 | 1.5.4.3 | **Electronics Final Design Review** |  | 12d | 2018-02-06 | 2018-02-21 |  | 105d |  |  |  | 88h | 12,000 |  |  |
| 59 | 1.5.4.3.1 | Electronics Design Review |  | 1d | 2018-02-06 | 2018-02-06 | 30, 53 | 105d | 0d |  | Electronics Engineer; Physicist | 16h | 2,000 | LDRD |  |
| 60 | 1.5.4.3.2 | Incorporate Review Comments |  | 10d | 2018-02-07 | 2018-02-20 | 59 | 105d | 0d |  | Elec tech; Physicist [20%] | 56h | 8,000 | LDRD |  |
| 61 | 1.5.4.3.3 | Complete Final Electronics Design | milestone | 1d | 2018-02-21 | 2018-02-21 | 60 | 105d | 81d |  | Electronics Engineer; Physicist | 16h | 2,000 | LDRD |  |
| 62 | 1.5.5 | **Ancillaries** |  | 64d | 2016-10-04 | 2016-12-30 |  | 310d |  |  |  | 240h | 56,200 | LDRD |  |
| 63 | 1.5.5.1 | Procure LV,HV,etc |  | 60d | 2016-10-04 | 2016-12-26 | 21SS+1d | 310d | 0d | start no earlier than 2016-10-03 | Physicist [10%]; Elec tech [10%] | 96h | 34,600 | LDRD |  |
| 64 | 1.5.5.2 | Procure Racks |  | 60d | 2016-10-06 | 2016-12-28 | 63SS+2d | 310d | 0d | start no earlier than 2016-10-03 | Physicist [10%]; Elec tech [5%] | 72h | 9,800 | LDRD |  |
| 65 | 1.5.5.3 | Procure Chiller |  | 60d | 2016-10-10 | 2016-12-30 | 64SS+2d | 310d | 286d |  | Physicist [10%]; Elec tech [5%] | 72h | 11,800 | LDRD |  |
| 66 | 1.5.6 | **Mechanics** |  | 227d | 2016-10-03 | 2017-08-15 |  | 211d |  |  |  | 2044h | 370,400 | LDRD |  |
| 67 | 1.5.6.1 | obtain ALICE CAD model | milestone | 0d | 2016-10-03 | 2016-10-03 |  | 211d | 0d | start no earlier than 2016-06-01 | Physicist; Mechanical Engineer |  |  | LDRD | ALICE CAD model |
| 68 | 1.5.6.2 | **Specifications** |  | 55d | 2016-10-03 | 2016-12-16 |  | 211d |  |  |  | 220h | 55,000 |  |  |
| 69 | 1.5.6.2.1 | review heat load |  | 40d | 2016-10-03 | 2016-11-25 | 67 | 211d | 0d | start no earlier than 2016-10-03 | Mechanical Engineer [50%] | 160h | 40,000 | LDRD |  |
| 70 | 1.5.6.2.2 | review mechanical tolerances/distortions |  | 10d | 2016-11-28 | 2016-12-09 | 69 | 211d | 0d | start no earlier than 2004-10-01 | Mechanical Engineer [50%] | 40h | 10,000 | LDRD |  |
| 71 | 1.5.6.2.3 | review disassembly/repair options |  | 5d | 2016-12-12 | 2016-12-16 | 70 | 211d | 0d | start no earlier than 2004-10-01 | Mechanical Engineer [50%] | 20h | 5,000 | LDRD |  |
| 72 | 1.5.6.3 | **Stave Support Frame & Global Interface to sPHENIX** |  | 115d | 2016-12-19 | 2017-05-26 |  | 211d |  |  |  | 1152h | 159,800 |  |  |
| 73 | 1.5.6.3.1 | initial design |  | 30d | 2016-12-19 | 2017-01-27 | 71 | 211d | 0d | start no earlier than 2007-10-01 | Mechanical Engineer; Physicist [20%] | 288h | 60,000 | LDRD |  |
| 74 | 1.5.6.3.2 | prototype |  | 60d | 2017-01-30 | 2017-04-21 | 73 | 211d | 0d |  | Mech Tech [30%]; Physicist | 624h | 53,800 | LDRD |  |
| 75 | 1.5.6.3.3 | test |  | 10d | 2017-04-24 | 2017-05-05 | 74 | 211d | 0d |  | Mech Tech; Physicist [50%] | 120h | 16,000 | LDRD |  |
| 76 | 1.5.6.3.4 | final design |  | 15d | 2017-05-08 | 2017-05-26 | 75 | 211d | 0d |  | Mechanical Engineer | 120h | 30,000 | LDRD |  |
| 77 | 1.5.6.4 | **Cooling System** |  | 20d | 2016-11-28 | 2016-12-23 |  | 296d |  |  |  | 120h | 38,000 |  |  |
| 78 | 1.5.6.4.1 | Design |  | 10d | 2016-11-28 | 2016-12-09 | 69 | 296d | 0d |  | Mechanical Engineer | 80h | 20,000 | LDRD |  |
| 79 | 1.5.6.4.2 | Mock up Testing |  | 10d | 2016-12-12 | 2016-12-23 | 78 | 296d | 0d |  | Mech Tech [50%] | 40h | 18,000 | LDRD |  |

Notes:
- 66: initial design by LDRD for CD-1 review; / Final desgin by DOE
- 67: Walt already obtained CAD model

| ID | WBS | Task | Type | Duration | Start | Finish | Predecessors | Total slack | Free slack | Constraint | Resources | Work | Cost | Cost Center |
| --- | --- | --- | --- | --- | --- | --- | --- | --- | --- | --- | --- | --- | --- | --- |
| 80 | 1.5.6.5 | **Safety Systems** |  | 70d | 2016-12-26 | 2017-03-31 |  | 296d |  |  |  | 184h | 56,000 |  |
| 81 | 1.5.6.5.1 | review sensors & interlocks |  | 10d | 2016-12-26 | 2017-01-06 | 79 | 296d | 0d |  | Mechanical Engineer [50%] | 40h | 10,000 | LDRD |
| 82 | 1.5.6.5.2 | electrical interlock design |  | 30d | 2017-01-09 | 2017-02-17 | 81 | 296d | 0d |  | Electronics Engineer [30%] | 72h | 23,000 | LDRD |
| 83 | 1.5.6.5.3 | cooling interlocks design |  | 30d | 2017-02-20 | 2017-03-31 | 82 | 296d | 85d |  | Mechanical Engineer [30%] | 72h | 23,000 | LDRD |
| 84 | 1.5.6.6 | **Stave Assembly Tooling** |  | 45d | 2017-05-29 | 2017-07-28 |  | 211d |  |  |  | 240h | 41,600 |  |
| 85 | 1.5.6.6.1 | design |  | 10d | 2017-05-29 | 2017-06-09 | 76 | 211d | 0d |  | Mechanical Engineer | 80h | 20,000 | LDRD |
| 86 | 1.5.6.6.2 | prototype |  | 30d | 2017-06-12 | 2017-07-21 | 85 | 211d | 0d |  | Physicist [30%]; Mech Tech [20%] | 120h | 11,600 | LDRD |
| 87 | 1.5.6.6.3 | final design |  | 5d | 2017-07-24 | 2017-07-28 | 86 | 211d | 0d |  | Mechanical Engineer | 40h | 10,000 | LDRD |
| 88 | 1.5.6.7 | **Mechanics Coneptual Design Review** |  | 12d | 2017-07-31 | 2017-08-15 |  | 241d |  |  |  | 128h | 20,000 |  |
| 89 | 1.5.6.7.1 | Mechanics Design Review |  | 1d | 2017-07-31 | 2017-07-31 | 76, 79, 83, 87 | 241d | 0d |  | Mechanical Engineer; Physicist | 16h | 2,000 | LDRD |
| 90 | 1.5.6.7.2 | Incorporate Review Comments |  | 10d | 2017-08-01 | 2017-08-14 | 89 | 241d | 0d |  | Mech Tech; Physicist [20%] | 96h | 16,000 | LDRD |
| 91 | 1.5.6.7.3 | Complete Initall Mechanical Design (for CD-1) | milestone | 1d | 2017-08-15 | 2017-08-15 | 90 | 241d | 217d |  | Physicist; Mechanical Engineer | 16h | 2,000 | LDRD |
| 92 | 1.6 | **Prototype Assembly** |  | 50d | 2018-02-06 | 2018-04-16 |  | 24d |  |  |  | 784h | 72,000 | LDRD |
| 93 | 1.6.1 | Stave Framing Design |  | 10d | 2018-02-06 | 2018-02-19 | 57, 27, 65, 53 | 24d | 0d |  | Mech Tech [50%]; Physicist [30%] | 64h | 8,000 | LDRD |
| 94 | 1.6.2 | Assemble prototype |  | 30d | 2018-02-20 | 2018-04-02 | 93 | 24d | 0d |  | Elec tech [50%]; Mech Tech [50%]; Physicist | 480h | 48,000 | LDRD |
| 95 | 1.6.3 | Prototype Full System Test |  | 10d | 2018-04-03 | 2018-04-16 | 94 | 24d | 0d |  | Physicist [200%]; Elec tech [50%]; Mech Tech [50%] | 240h | 16,000 | LDRD |
| 96 | 1.7 | **Test Beam Operation** |  | 35d | 2019-01-11 | 2019-02-28 |  | 0d |  |  |  | 290.67h | 30,800 | LDRD |
| 97 | 1.7.1 | Shipping/Transport |  | 10d | 2019-01-11 | 2019-01-24 | 95 | 0d |  | as late as possible | Elec tech [20%]; Mech Tech [20%] | 18.67h | 13,733.33 | LDRD |
| 98 | 1.7.2 | Setup |  | 5d | 2019-01-25 | 2019-01-31 | 97 | 0d |  | as late as possible | Physicist; Elec tech; Mech Tech | 80h | 10,666.67 | LDRD |
| 99 | 1.7.3 | Operations |  | 20d | 2019-02-01 | 2019-02-28 | 98 | 0d |  | must start on 2019-02-01 | Physicist [200%]; Elec tech [20%] | 192h | 6,400 | LDRD |
| 100 | 1.8 | **sPHENIX Mechanics Integration** |  | 42d? | 2018-04-18 | 2018-06-14 |  | 24d |  |  |  | 256h | 50,000 |  |
| 101 | 1.8.1 | Final Mechanics Desgin |  | 30d? | 2018-04-18 | 2018-05-29 | 6SS+1d, 95FS+1d, 76, 79, 83, 87 | 24d | 0d | start no earlier than 2018-02-23 | Mechanical Engineer [50%]; Physicist [10%] | 144h | 30,000 | LDRD |
| 102 | 1.8.2 | **Mechanics Final Design Review** |  | 12d | 2018-05-30 | 2018-06-14 |  | 24d |  |  |  | 112h | 20,000 |  |
| 103 | 1.8.2.1 | Mechanics Final Design Review |  | 1d | 2018-05-30 | 2018-05-30 | 101 | 24d | 0d |  | Mechanical Engineer; Physicist | 16h | 2,000 | LDRD |
| 104 | 1.8.2.2 | Incorporate Review Comments |  | 10d | 2018-05-31 | 2018-06-13 | 103 | 24d | 0d |  | Mech Tech | 80h | 16,000 | LDRD |
| 105 | 1.8.2.3 | Complete Final Mechanical Design | milestone | 1d | 2018-06-14 | 2018-06-14 | 104 | 24d | 0d |  | Physicist; Mechanical Engineer | 16h | 2,000 | LDRD |

Notes:
- 80: monitoring temp, flow rates, I, V etc.
- 88: For CD-1 review, 11/2017, conceptuall design of mechanis system
- 101: DOE project fund available

| ID | WBS | Task | Type | Duration | Start | Finish | Predecessors | Total slack | Free slack | Constraint | Resources | Work | Cost | DOE Cost | Text10 |
| --- | --- | --- | --- | --- | --- | --- | --- | --- | --- | --- | --- | --- | --- | --- | --- |
| 106 | 1.9 | **MAPS Inner Barrel Review** |  | 42d? | 2018-06-15 | 2018-08-13 |  | 24d | 0d |  |  | 229.33h | 39,040 |  |  |
| 107 | 1.9.1 | Final Design Review |  | 1d | 2018-06-15 | 2018-06-15 | 91, 61, 95, 105 | 24d | 0d |  | Electronics Engineer; Mechanical Engineer; Physicist | 24h | 4,000 | DOE |  |
| 108 | 1.9.2 | Incorporate Review Comments |  | 10d | 2018-06-18 | 2018-06-29 | 107 | 24d | 0d |  | Electronics Engineer [50%]; Mechanical Engineer [50%]; Physicist | 133.33h | 20,000 | DOE |  |
| 109 | 1.9.3 | Complete Final Design (CD-2) | milestone | 1d | 2018-07-02 | 2018-07-02 | 108 | 24d | 0d |  | Electronics Engineer; Mechanical Engineer; Physicist | 24h | 4,000 | DOE |  |
| 110 | 1.9.4 | Update MOU for Staev Production Extension ? |  | 30d? | 2018-07-03 | 2018-08-13 | 109 | 731d |  |  | Project Manager [20%] | 48h | 11,040 |  |  |
| 111 | 1.10 | **Productions** |  | 661d? | 2018-08-01 | 2021-02-10 | 8, 109 | 3d |  |  |  | 15051.9h | 3,003,273.33 |  | Production |
| 112 | 1.10.1 | Full Mechnicas System pre-Production Mock Up and Test Beam Analysis |  | 100d | 2019-03-01 | 2019-07-18 | 8, 99, 109 | 79d | 0d |  | Mechanical Engineer [20%]; Mech Tech [30%]; Physicist | 464h | 88,000 |  |  |
| 113 | 1.10.2 | **Procurements** |  | 359d? | 2018-08-01 | 2019-12-16 |  | 3d | 0d |  |  | 5267.2h | 2,299,140 |  |  |
| 114 | 1.10.2.1 | **CERN Procuments** |  | 180d? | 2018-08-01 | 2019-04-09 |  | 108d |  |  |  | 3811.2h | 1,097,840 |  |  |
| 115 | 1.10.2.1.1 | Produce 68 Inner Staves |  | 180d | 2018-08-01 | 2019-04-09 | 61, 8 | 108d | 0d | start no earlier than 2018-02-22 | Physicist [200%]; Elec tech [50%] | 3600h | 1,064,000 | DOE |  |
| 116 | 1.10.2.1.2 | Other ITS/CERN items |  | 120d | 2018-08-01 | 2019-01-15 | 8 | 318d |  |  | Physicist [20%]; Mech Tech [2%] | 211.2h | 13,840 |  |  |
| 117 | 1.10.2.1.3 | Travel and Per Diem at CERN |  | 180d? | 2018-08-01 | 2019-04-09 | 115SS, 8 | 258d |  |  |  |  | 20,000 |  |  |
| 118 | 1.10.2.2 | Procure 68 Readout / FEM Units |  | 100d | 2018-08-02 | 2018-12-19 | 8, 115SS+1d | 245d | 0d |  | Physicist [10%]; Elec tech [10%] | 160h | 338,000 | DOE |  |
| 119 | 1.10.2.3 | Procure Optical Links 68 |  | 60d | 2018-08-03 | 2018-10-25 | 8, 118SS+1d | 245d | 0d |  | Physicist [10%]; Elec tech [5%] | 72h | 47,000 | DOE |  |
| 120 | 1.10.2.4 | Procure 34 Common Readout Units | manual | 100d | 2018-08-06 | 2018-12-21 | 8, 119SS+1d |  |  |  | Physicist [10%]; Elec tech [5%] | 120h | 189,700 | DOE |  |
| 121 | 1.10.2.5 | Procure 100 SamTec Cables | manual | 60d | 2018-08-07 | 2018-10-29 | 8SS, 120SS+1d |  |  |  | Physicist [10%]; Elec tech [5%] | 72h | 31,800 | DOE |  |
| 122 | 1.10.2.6 | Procure Ancillary Materials (LVPS and cables etc) |  | 100d | 2018-08-08 | 2018-12-25 | 121SS+1d, 8 | 243d | 0d |  | Physicist [10%]; Mech Tech [5%] | 120h | 68,000 | DOE |  |
| 123 | 1.10.2.7 | Procure Cooling Plant |  | 100d | 2019-07-19 | 2019-12-05 | 112, 8 | 79d | 0d |  | Physicist [10%]; Mech Tech [5%] | 120h | 125,000 | DOE |  |
| 124 | 1.10.2.8 | Procure Assembly Fixtures & Jigs |  | 60d | 2019-07-22 | 2019-10-11 | 112, 123SS+1d | 79d | 0d |  | Physicist [10%]; Mech Tech [5%] | 72h | 104,800 | DOE |  |
| 125 | 1.10.2.9 | Procure End Wheels |  | 100d | 2019-07-23 | 2019-12-09 | 112, 124SS+1d | 79d | 0d |  | Physicist [10%]; Mech Tech [5%] | 120h | 42,000 | DOE |  |
| 126 | 1.10.2.10 | Procure Cylindrical Structural Shells |  | 100d | 2019-07-24 | 2019-12-10 | 125SS+1d | 79d | 0d |  | Physicist [10%]; Mech Tech [5%] | 120h | 19,000 | DOE |  |
| 127 | 1.10.2.11 | Procure Detector Half Barrels |  | 100d | 2019-07-25 | 2019-12-11 | 126SS+1d | 79d | 0d |  | Physicist [10%]; Mech Tech [5%] | 120h | 21,000 | DOE |  |
| 128 | 1.10.2.12 | Procure Service Half Barrels |  | 100d | 2019-07-26 | 2019-12-12 | 127SS+1d | 79d | 0d |  | Physicist [10%]; Mech Tech [5%] | 120h | 128,000 | DOE |  |
| 129 | 1.10.2.13 | Procure Detector and Service Half Barrels |  | 100d | 2019-07-29 | 2019-12-13 | 128SS+1d | 79d | 0d |  | Physicist [10%]; Mech Tech [5%] | 120h | 29,000 | DOE |  |
| 130 | 1.10.2.14 | Procure Two Half Support Structures |  | 100d | 2019-07-30 | 2019-12-16 | 129SS+1d | 79d | 0d |  | Physicist [10%]; Mech Tech [5%] | 120h | 58,000 | DOE |  |

Notes:
- 112: Mechnics production test run; / may not needed?
- 115: 48+20% = 58; consider to have 40% spare: 68 in total / could start early right after ITS production end, ~2/23/18 (final electronics review finished) assuming sPHENIX can morgage with CERN to produce staves, can gain 6 months of advanced production; / production length ~ 6 months = 20x6days
- 116: other small items related to MAPS testing etc.
- 117: 1 FTE lodging and per diem for 6 months; / $3K/month
- 118: 48+40% spares; / obtain desgin files and produce them in US

| ID | WBS | Task | Type | Duration | Start | Finish | Predecessors | Total slack | Free slack | Resources | Work | Cost | DOE Cost |
| --- | --- | --- | --- | --- | --- | --- | --- | --- | --- | --- | --- | --- | --- |
| 131 | 1.10.3 | **Assembly and Testing at BNL** |  | 425d | 2018-12-26 | 2020-08-11 |  | 183d |  |  | 6072.67h | 367,733.33 |  |
| 132 | 1.10.3.1 | Test Production FEMS, e-Links, CRU, LV, optical links |  | 90d | 2018-12-26 | 2019-04-30 | 118, 119, 120, 121, 122 | 243d | 164d | Elec tech [30%]; Physicist [200%] | 1656h | 43,200 |  |
| 133 | 1.10.3.2 | Test Cooling System |  | 10d | 2019-12-06 | 2019-12-19 | 123 | 378d |  | Mech Tech [50%]; Physicist [50%] | 80h | 8,000 |  |
| 134 | 1.10.3.3 | Stave Reciept Inspection |  | 10d | 2019-04-10 | 2019-04-23 | 115 | 108d | 0d | Physicist [20%]; Elec tech [10.8%] | 24.67h | 1,733.33 | DOE |
| 135 | 1.10.3.4 | Individual Stave Readout Test |  | 70d | 2019-04-24 | 2019-07-30 | 134 | 108d | 0d | Physicist [300%]; Elec tech [20%] | 352h | 22,400 | DOE |
| 136 | 1.10.3.5 | Metrology on Stave Assemblies |  | 70d | 2019-07-31 | 2019-11-05 | 135 | 108d | 29d | Mechanical Engineer [30%] | 168h | 42,000 | DOE |
| 137 | 1.10.3.6 | Assemble full Ladders into Half support |  | 100d | 2019-12-17 | 2020-05-04 | 136, 113, 130, 129, 128, 127, 126, 125, 124, 132 | 79d | 0d | Mech Tech [150%]; Physicist [200%] | 1792h | 38,400 | DOE |
| 138 | 1.10.3.7 | Metrology on Final Assembly |  | 10d | 2020-05-05 | 2020-05-18 | 137 | 79d | 0d | Mechanical Engineer | 80h | 20,000 | DOE |
| 139 | 1.10.3.8 | Test Half detector Assembly |  | 60d | 2020-05-20 | 2020-08-11 | 138FS+1d, 132FS+1d | 79d | 0d | Physicist [200%]; Mech Tech; Elec tech | 1920h | 192,000 | DOE |
| 140 | 1.10.4 | **Installation** |  | 131d | 2020-08-12 | 2021-02-10 |  | 79d | 78d |  | 3248h | 248,400 |  |
| 141 | 1.10.4.1 | Installation Prep |  | 10d | 2020-08-12 | 2020-08-25 | 139 | 79d | 0d | Mech Tech; Physicist | 160h | 16,000 | DOE |
| 142 | 1.10.4.2 | Installation Review |  | 1d | 2020-08-26 | 2020-08-26 | 141 | 79d | 0d | Physicist; Mechanical Engineer | 16h | 2,000 | DOE |
| 143 | 1.10.4.3 | Installation |  | 60d | 2020-08-27 | 2020-11-18 | 142 | 79d | 0d | Physicist [200%]; Mech Tech; Elec tech | 1920h | 192,000 |  |
| 144 | 1.10.4.4 | Commissioning |  | 60d | 2020-11-19 | 2021-02-10 | 143 | 79d | 0d | Physicist [200%]; Mech Tech [20%]; Elec tech [20%] | 1152h | 38,400 |  |
| 145 | 1.11 | Ready for beam | milestone | 0d | 2021-02-10 | 2021-02-10 | 144 | 79d |  |  |  |  |  |

Notes:
- 134: start the assembly at partrial delivery of staves, 60days from the start of stave production ; / allow 10days for shipping from CERN to BNL; / partial delivery every month
- 135: Statve test starts 10 days after reciept of staves
- 137: can start earlier if procument (stave production) can be morgaged, by up to ~ 1 month in time.! / can start work as early as 2 days after the start of metrologly on stave assembly;
- 140: installatino by 6/2021
- 143: commissioning starts 4/1/2021, last 2 months, ends on 6/1/2021 to be ready for beam
