# MAPS Inner Barrel

Schedule from MS Project, 2016-08-01 to 2021-06-01, costs in $, A marks actual dates.
Guest Scientist, LANL

## Calendars

- Standard: Mon-Fri 08:00-12:00, 13:00-17:00; Sat-Sun off.

## Resources

| Resource | Rate | Cost per use |
| --- | --- | --- |
| Mech Liason Eng | 230 |  |
| Elec Liason Eng | 230 |  |
| Project Manager | 230 |  |
| Physicist |  |  |
| Elec tech | 200 |  |
| Mech Tech | 200 |  |
| Electronics Engineer | 250 |  |
| Mechanical Engineer | 250 |  |
| M&S |  | 1 |
| Electrical Engineer |  |  |
| LDRD Physicist | 200 |  |
| LDRD PostDoc | 100 |  |
| LDRD Electronics Engineer | 200 |  |
| LDRD Mechnical Engineer | 200 |  |
| LDRD Mechnical Tech | 150 |  |
| LDRD Electronics Tech | 100 |  |

## Schedule

| ID | WBS | Task | Type | Duration | Start | Finish | Predecessors | Remaining | Actual start | Total slack | Free slack | Constraint | Resources | Work | Actual work | Cost | Actual cost | DOE Cost | Activity | Cost Center |
| --- | --- | --- | --- | --- | --- | --- | --- | --- | --- | --- | --- | --- | --- | --- | --- | --- | --- | --- | --- | --- |
| 1 | 1 | **MAPS Inner Barrel** |  | 1217d | 2016-10-03 | 2021-06-01 |  | 1213.42d | 2016-08-01 |  |  | start no earlier than 2005-10-21 |  | 27897.6h | 40h | 5,305,297.33 | 14,700 |  |  |  |
| 2 | 1.1 | MAPS Inner Barrel Starts | milestone | 0d | 2016-10-01 | 2016-10-01 |  |  |  | 0d |  | must start on 2016-10-01 |  |  |  |  |  | DOE |  |  |
| 3 | 1.2 | MAPS Inner Barrel Ends | milestone | 0d | 2021-06-01 | 2021-06-01 |  |  |  | 0d |  | must finish on 2021-06-01 |  |  |  |  |  | DOE |  |  |
| 4 | 1.3 | **Milestones & Key Tasks** |  | 0d | 2016-10-03 | 2016-10-03 |  |  |  |  |  |  |  | 32h |  | 6,400 |  |  |  |  |
| 5 | 1.3.1 | **ALICE ITS Key Tasks** |  | 0d | 2017-01-02 | 2017-01-02 |  |  |  |  |  |  |  |  |  |  |  |  |  |  |
| 6 | 1.3.1.1 | ALICE MAPS Production (7/17) |  | 240d? | 2016-08-01 | 2017-06-30 |  |  |  | 1022d |  | finish no earlier than 2017-06-30 |  |  |  |  |  |  |  |  |
| 7 | 1.3.1.2 | ALICE ITS IB FPC Production (9/17) |  | 90d | 2017-05-01 | 2017-09-01 |  |  |  | 977d |  | finish no earlier than 2017-09-01 |  |  |  |  |  |  |  |  |
| 8 | 1.3.1.3 | ALICE ITS IB Stave Production (1/18) |  | 1d? | 2018-01-02 | 2018-01-02 |  |  |  | 890d |  | finish no earlier than 2018-01-02 |  |  |  |  |  |  |  |  |
| 9 | 1.3.1.4 | ALICE ITS IB Stave Assembly (3/18) |  | 262d | 2017-01-02 | 2018-01-02 |  |  |  | -139d | 0d | start no earlier than 2017-01-01 |  |  |  |  |  |  | ITS construction |  |
| 10 | 1.3.1.5 | ALICE ITS Electronics Pre-Production (7/17) |  | 100d | 2017-02-22 | 2017-07-11 |  |  |  | -181d | 0d | start no earlier than 2017-02-22 |  |  |  |  |  |  | ITS Electronics Pre-Production |  |
| 11 | 1.3.1.6 | ALICE ITS Electronics Production (6/18) |  | 240d | 2017-07-13 | 2018-06-13 | 10 |  |  | 774d |  | start no earlier than 2017-07-13 |  |  |  |  |  |  | ITS Electronics Production |  |
| 12 | 1.3.2 | **sPHENIX Milestones** |  | 1195d | 2016-11-01 | 2021-06-01 |  |  |  |  |  |  |  |  |  |  |  |  |  |  |
| 13 | 1.3.2.1 | sPHENIX Technical Design CD-0 | milestone | 0d | 2016-11-01 | 2016-11-01 |  |  |  | 1196d |  | start no earlier than 2016-11-01 |  |  |  |  |  |  | CD-0 (11/2016) |  |
| 14 | 1.3.2.2 | sPHENIX Technical Design (CD-1/CD-3a) | milestone | 0d | 2017-11-01 | 2017-11-01 |  |  |  | 119d | 0d | start no earlier than 2017-11-01 |  |  |  |  |  |  | CD-1 (11/2017) |  |
| 15 | 1.3.2.3 | sPHENIX Technical Dewsgin (CD-2) | milestone | 0d | 2018-07-02 | 2018-07-02 | 139 |  |  | 761d |  | start no earlier than 2018-06-01 |  |  |  |  |  |  | CD-2 (7/2018) |  |
| 16 | 1.3.2.4 | sPHENIX Start Construction (CD-3b) | milestone | 0d | 2018-08-01 | 2018-08-01 |  |  |  | 109d | 0d | start no earlier than 2018-08-01 |  |  |  |  |  |  | CD-3b (8/2018) |  |
| 17 | 1.3.2.5 | sPHENIX Installed and Ready for Beam | milestone | 0d | 2021-06-01 | 2021-06-01 | 171 |  |  | 1d |  | start no earlier than 2021-06-01 |  |  |  |  |  |  | ready for beam (6/2021) |  |
| 18 | 1.3.3 | **LDRD Milestones & Critical Tasks** |  | 781d | 2016-10-03 | 2019-09-30 |  |  |  | -781d | 0d |  |  | 32h |  | 6,400 |  |  |  |  |
| 19 | 1.3.3.1 | LDRD Start and End |  | 781d | 2016-10-03 | 2019-09-30 |  |  |  | -781d | 0d | start no earlier than 2016-10-03 |  |  |  |  |  |  |  |  |
| 20 | 1.3.3.2 | MOU btw LANL and ALICE for R&D |  | 40d | 2016-10-03 | 2016-11-25 |  |  |  | -180d | 0d | start no earlier than 2016-10-03 | LDRD Physicist [10%] | 32h |  | 6,400 |  |  |  | LDRD |
| 21 | 1.3.3.3 | Setup ALICE Readout Test Stands | milestone | 0d | 2017-02-10 | 2017-02-10 | 33 |  |  | -95d | 0d |  |  |  |  |  |  |  |  |  |
| 22 | 1.3.3.4 | Complete final sPHENIX Readout Design Review | milestone | 0d | 2017-07-26 | 2017-07-26 | 73 |  |  | -213d | 0d |  |  |  |  |  |  |  |  |  |
| 23 | 1.3.3.5 | Complete Final MAPS Detector Design (CD-1) | milestone | 0d | 2017-11-16 | 2017-11-16 | 98 |  |  | -294d | 0d |  |  |  |  |  |  |  |  |  |
| 24 | 1.3.3.6 | sPHENIX Test Beam |  | 21d | 2019-02-01 | 2019-03-01 |  |  |  | -630d | 0d | start no earlier than 2019-02-01 |  |  |  |  |  |  |  | LDRD |
| 25 | 1.3.3.7 | MAPS Final Design (CD-2/CD-3)? | milestone | 0d | 2016-10-03 | 2016-10-03 |  |  |  | 0d |  |  |  |  |  |  |  |  |  |  |

Notes:
- 14: critical and lond lead time items can be purchased at CD3a
- 16: constructino fund available at CD-3b
- 17: commissioning 4/1-6/1, 2021; / ready for beam 6/1/2021
- 20: Use ITS production line to train local people and produce staves for sPHENIX; / provide 1 FTE from 1/2017 - 6/2018+ for LDRD and later for sPHENIX
- 22: LDRD complete full readout electronics final design

| ID | WBS | Task | Type | Duration | Start | Finish | Predecessors | Complete | Remaining | Total slack | Free slack | Constraint | Resources | Work | Actual work | Cost | Actual cost | Cost Center | Activity |
| --- | --- | --- | --- | --- | --- | --- | --- | --- | --- | --- | --- | --- | --- | --- | --- | --- | --- | --- | --- |
| 26 | 1.4 | **LANL LDRD** |  | 781d | 2016-10-03 A | 2019-09-30 |  | 1% | 770.46d | 436d |  |  |  | 10218h | 40h | 1,372,560 | 14,700 | LDRD | LANL R&D |
| 27 | 1.4.1 | **Obtain Designs from ALICE** |  | 1d | 2016-10-03 | 2016-10-03 |  |  |  | -225d | 0d |  |  | 9.6h |  | 960 |  |  |  |
| 28 | 1.4.1.1 | Obtain Test Stand Design from CERN | milestone | 1d | 2016-10-03 | 2016-10-03 |  |  |  | 916d | 0d | start no earlier than 2016-10-03 | LDRD Electronics Engineer [20%]; Physicist [20%] | 3.2h |  | 320 |  | LDRD |  |
| 29 | 1.4.1.2 | Obtain ALICE Readout Unit Design | milestone | 1d | 2016-10-03 | 2016-10-03 |  |  |  | -225d | 0d |  | Physicist [20%]; LDRD Electronics Engineer [20%] | 3.2h |  | 320 |  | LDRD |  |
| 30 | 1.4.1.3 | obtain ALICE CAD model | milestone | 1d | 2016-10-03 | 2016-10-03 |  |  |  | -175d | 0d | start no earlier than 2016-06-01 | Physicist [20%]; LDRD Mechnical Engineer [20%] | 3.2h |  | 320 |  | LDRD | ALICE CAD model |
| 31 | 1.4.2 | **Setup Alice Readout Test Stand** |  | 95d | 2016-10-03 A | 2017-02-10 |  | 32% | 65d | -5d | 0d |  |  | 108h | 40h | 44,000 | 14,700 | LDRD |  |
| 32 | 1.4.2.1 | Procure 2 Test Stands |  | 90d | 2016-10-03 A | 2017-02-03 | 30 | 33% | 60d | -80d | 0d |  | Elec tech [5%]; Physicist [5%] | 64h | 40h | 39,600 | 14,700 | LDRD |  |
| 33 | 1.4.2.2 | Setup Test Stands |  | 5d | 2017-02-06 | 2017-02-10 | 32 |  |  | -219d | 0d |  | Physicist [30%]; Elec tech [50%]; LDRD PostDoc [50%] | 44h |  | 4,400 |  | LDRD |  |
| 34 | 1.4.3 | **Procure R&D ALICE Staves** |  | 180d | 2016-11-28 | 2017-08-04 |  |  |  | -174d | 0d |  |  | 1020h |  | 154,200 |  | LDRD |  |
| 35 | 1.4.3.1 | Procure and Produce 4 Staves |  | 60d | 2016-11-28 | 2017-02-17 | 20, 9SS-60d |  |  | -174d | 0d |  | Physicist [50%]; LDRD Electronics Tech; LDRD PostDoc [50%] | 960h |  | 127,000 |  | LDRD |  |
| 36 | 1.4.3.2 | Test Staves |  | 5d | 2017-02-13 | 2017-02-17 | 35FS-5d |  |  | -174d | 0d |  | LDRD Physicist [20%]; LDRD PostDoc [50%]; LDRD Electronics Tech [30%] | 60h |  | 7,200 |  | LDRD |  |
| 37 | 1.4.3.3 | Travel and Per Diem Support |  | 180d | 2016-11-28 | 2017-08-04 | 35SS |  |  | 997d |  |  |  |  |  | 20,000 |  | LDRD |  |
| 38 | 1.4.4 | **Procure ALICE Electronics & Cabels** |  | 107d | 2016-10-03 | 2017-02-28 |  |  |  | -181d | 0d |  |  | 331.2h |  | 81,360 |  | LDRD |  |
| 39 | 1.4.4.1 | **ALICE Readout Electronics Boards** |  | 65d | 2016-11-30 | 2017-02-28 |  |  |  | -181d | 0d |  |  | 199.2h |  | 31,160 |  |  |  |
| 40 | 1.4.4.1.1 | **Readout Units (RDOs)** |  | 65d | 2016-11-30 | 2017-02-28 |  |  |  | -181d | 0d |  |  | 136h |  | 15,400 |  |  |  |
| 41 | 1.4.4.1.1.1 | Procure 4 RDOs |  | 60d | 2016-11-30 | 2017-02-21 | 10SS-60d, 20FS+1d |  |  | -181d | 0d |  | Physicist [5%]; LDRD Electronics Tech [5%] | 48h |  | 7,400 |  | LDRD |  |
| 42 | 1.4.4.1.1.2 | Test RDOs |  | 10d | 2017-02-15 | 2017-02-28 | 41FS-5d |  |  | -181d | 0d |  | Physicist [20%]; LDRD Electronics Tech [30%]; LDRD PostDoc [50%]; LDRD Physicist [10%] | 88h |  | 8,000 |  | LDRD |  |
| 43 | 1.4.4.1.2 | **Common Readout Units (CRUs)** |  | 65d | 2016-11-30 | 2017-02-28 |  |  |  | -181d | 0d |  |  | 63.2h |  | 15,760 |  |  |  |
| 44 | 1.4.4.1.2.1 | Procure 2 CRUs |  | 60d | 2016-11-30 | 2017-02-21 | 20FS+1d, 10SS-60d |  |  | -181d | 0d |  | Physicist [2%]; LDRD Electronics Tech [2%] | 19.2h |  | 10,960 |  | LDRD |  |
| 45 | 1.4.4.1.2.2 | Test CRUs |  | 5d | 2017-02-22 | 2017-02-28 | 44 |  |  | -181d | 0d |  | Physicist [10%]; LDRD Electronics Tech [30%]; LDRD PostDoc [50%]; LDRD Physicist [20%] | 44h |  | 4,800 |  | LDRD |  |
| 46 | 1.4.4.2 | **SamTec Cables** |  | 11d | 2016-10-03 | 2016-10-17 |  |  |  | -86d | 0d |  |  | 8h |  | 2,800 |  |  |  |
| 47 | 1.4.4.2.1 | Procure 7 SamTec Cables |  | 10d | 2016-10-03 | 2016-10-14 |  |  |  | -86d | 0d |  | LDRD Electronics Tech [5%] | 4h |  | 2,400 |  | LDRD |  |
| 48 | 1.4.4.2.2 | Test Cables |  | 1d | 2016-10-17 | 2016-10-17 | 47 |  |  | -85d | 0d |  | LDRD Electronics Tech [50%] | 4h |  | 400 |  | LDRD |  |
| 49 | 1.4.4.3 | **Optical Cables** |  | 11d | 2016-10-04 | 2016-10-18 |  |  |  | -86d | 0d |  |  | 4h |  | 800 |  |  |  |
| 50 | 1.4.4.3.1 | Procure 4 Optical Cables |  | 10d | 2016-10-04 | 2016-10-17 | 47SS+1d |  |  | -86d | 0d |  | LDRD Electronics Tech [2%] | 1.6h |  | 560 |  | LDRD |  |
| 51 | 1.4.4.3.2 | Test Optical Cables |  | 1d | 2016-10-18 | 2016-10-18 | 50 |  |  | -86d | 0d |  | LDRD Electronics Tech [30%] | 2.4h |  | 240 |  | LDRD |  |

Notes:
- 26: LANL LDRD activities
- 28: The readout test stand design has already been completed by ALICE.
- 30: Walt already obtained CAD model
- 32: Cost from Leo. Only a few custom boards, standard items standard: power supplies, etc. One stand would be procured early, one late, both under LDRD. / CERN-LANL MOU comes later in 2016, ~Dec. 2016? / Time needed to setup an CERN accout etc. may delay the actual procument date. MXL
- 33: LDRD PD + Tech, working with external collaorators/physicists
- 35: work on MOU to get 4 staves as early as possible; within 60 from the production ; / train LANL staff for MAPS assembly and test. M&S $20K for 6 months
- 36: assume testing 1 stave every two days;
- 37: $3K/month including lodging and per diem 1 FTE (combination of PD and staff) / for 6 months;
- 39: critical tasks
- 47: from DigiKey?

| ID | WBS | Task | Type | Duration | Start | Finish | Predecessors | Total slack | Free slack | Constraint | Resources | Work | Cost | Cost Center |
| --- | --- | --- | --- | --- | --- | --- | --- | --- | --- | --- | --- | --- | --- | --- |
| 52 | 1.4.4.4 | **Procure Ancillaries** |  | 64d | 2016-10-04 | 2016-12-30 |  | -159d | 0d |  |  | 120h | 46,600 | LDRD |
| 53 | 1.4.4.4.1 | Procure LV,HV,etc |  | 60d | 2016-10-04 | 2016-12-26 | 31SS+1d | -159d | 0d | start no earlier than 2016-10-03 | Physicist [5%]; LDRD Electronics Tech [5%] | 48h | 27,400 | LDRD |
| 54 | 1.4.4.4.2 | Procure Racks |  | 60d | 2016-10-06 | 2016-12-28 | 53SS+2d | -159d | 0d | start no earlier than 2016-10-03 | LDRD Electronics Tech [5%] | 24h | 7,400 | LDRD |
| 55 | 1.4.4.4.3 | Procure Chiller |  | 60d | 2016-10-10 | 2016-12-30 | 54SS+2d | -159d | 0d |  | Physicist [5%]; Elec tech [5%] | 48h | 11,800 | LDRD |
| 56 | 1.4.5 | **sPHENIX Readout Electronics Integration** |  | 270d | 2016-10-04 | 2017-10-16 |  | -225d | 0d |  |  | 920h | 178,000 |  |
| 57 | 1.4.5.1 | Initial FEM Design (modify ALICE) |  | 40d | 2016-10-04 | 2016-11-28 | 29 | -225d | 0d |  | LDRD Electronics Engineer [50%]; LDRD Physicist [10%] | 192h | 38,400 | LDRD |
| 58 | 1.4.5.2 | Prototype FEM |  | 60d | 2016-11-29 | 2017-02-20 | 57 | -225d | 0d |  | LDRD Electronics Tech [10%]; LDRD Electronics Engineer [10%]; LDRD Physicist [20%] | 192h | 38,600 | LDRD |
| 59 | 1.4.5.3 | FEM test-I |  | 5d | 2017-02-21 | 2017-02-27 | 58, 33 | -225d | 0d |  | LDRD PostDoc [30%]; LDRD Electronics Engineer [50%]; LDRD Electronics Tech [20%]; LDRD Physicist [20%] | 48h | 7,600 | LDRD |
| 60 | 1.4.5.4 | Revised FEM Design |  | 20d | 2017-02-28 | 2017-03-27 | 59 | -225d | 0d |  | LDRD Electronics Engineer [60%] | 96h | 19,200 | LDRD |
| 61 | 1.4.5.5 | Prototype FEM-II |  | 60d | 2017-03-28 | 2017-06-19 | 60 | -225d | 0d |  | LDRD Electronics Tech [20%]; LDRD PostDoc [20%] | 192h | 24,200 | LDRD |
| 62 | 1.4.5.6 | FEM test-II |  | 5d | 2017-06-20 | 2017-06-26 | 61 | -225d | 0d |  | LDRD Electronics Engineer [20%]; LDRD Electronics Tech [20%]; LDRD PostDoc [50%] | 36h | 4,400 | LDRD |
| 63 | 1.4.5.7 | Final FEM design (CD-1) | milestone | 10d | 2017-06-26 | 2017-07-10 | 62 | -225d | 0d |  | Physicist [5%]; LDRD Electronics Engineer [50%]; LDRD PostDoc; LDRD Physicist [20%] | 60h | 11,200 | LDRD |
| 64 | 1.4.5.8 | Procure 4 FEMs |  | 60d | 2017-07-11 | 2017-10-02 | 63 | 946d | 0d |  | LDRD Electronics Tech [5%] | 24h | 22,400 | LDRD |
| 65 | 1.4.5.9 | Final FEM Test |  | 10d | 2017-10-03 | 2017-10-16 | 64 | 946d |  |  | LDRD Electronics Engineer [30%]; LDRD Physicist [20%]; LDRD PostDoc [30%]; LDRD Electronics Tech [20%] | 80h | 12,000 | LDRD |
| 66 | 1.4.6 | **sPHENIX DAQ System Integration** |  | 70d | 2016-11-29 | 2017-03-06 |  | -185d | 0d |  |  | 528h | 82,200 |  |
| 67 | 1.4.6.1 | Slow Control Design |  | 60d | 2016-11-29 | 2017-02-20 | 57 | -185d | 0d |  | Physicist [10%]; LDRD Physicist [10%]; LDRD PostDoc [20%]; LDRD Electronics Engineer [20%] | 288h | 43,400 | LDRD |
| 68 | 1.4.6.2 | Trigger Interface Design |  | 60d | 2016-12-06 | 2017-02-27 | 57, 67SS+5d | -185d | 0d |  | Physicist [10%]; LDRD Electronics Engineer [10%]; LDRD Physicist [10%] | 144h | 24,200 | LDRD |
| 69 | 1.4.6.3 | DAQ Interface Design |  | 60d | 2016-12-13 | 2017-03-06 | 57, 68SS+5d | -185d | 0d |  | Physicist [10%]; LDRD Electronics Engineer [10%] | 96h | 14,600 | LDRD |
| 70 | 1.4.7 | **Electronics Final Design Review** |  | 12d | 2017-07-11 | 2017-07-26 |  | -225d | 0d |  |  | 53.6h | 10,720 |  |
| 71 | 1.4.7.1 | Electronics Design Review |  | 1d | 2017-07-11 | 2017-07-11 | 63, 62 | -225d | 0d |  | LDRD Electronics Engineer; LDRD Physicist | 16h | 3,200 | LDRD |
| 72 | 1.4.7.2 | Incorporate Review Comments |  | 10d | 2017-07-12 | 2017-07-25 | 71 | -225d | 0d |  | LDRD Physicist [10%]; LDRD Electronics Engineer [30%] | 32h | 6,400 | LDRD |
| 73 | 1.4.7.3 | Complete Final Electronics Design | milestone | 1d | 2017-07-26 | 2017-07-26 | 72 | -225d | 0d |  | LDRD Physicist [20%]; LDRD Electronics Engineer [50%] | 5.6h | 1,120 | LDRD |
| 74 | 1.4.8 | **Mechanical Support and Cooling** |  | 160d | 2016-10-04 | 2017-05-15 |  | -175d | 0d |  |  | 976h | 182,400 |  |
| 75 | 1.4.8.1 | **Specifications** |  | 60d | 2016-10-04 | 2016-12-26 |  | -175d | 0d |  |  | 336h | 58,800 |  |
| 76 | 1.4.8.1.1 | Review & Simulate Heat Load |  | 40d | 2016-10-04 | 2016-11-28 | 30 | -175d | 0d | start no earlier than 2016-10-03 | LDRD Mechnical Engineer [30%]; LDRD Physicist [20%]; LDRD PostDoc [20%] | 224h | 38,400 | LDRD |
| 77 | 1.4.8.1.2 | review mechanical tolerances/distortions |  | 10d | 2016-11-29 | 2016-12-12 | 76 | -175d | 0d | start no earlier than 2004-10-01 | LDRD Mechnical Engineer [30%]; LDRD Physicist [30%] | 48h | 9,600 | LDRD |
| 78 | 1.4.8.1.3 | review disassembly/repair options |  | 10d | 2016-12-13 | 2016-12-26 | 77 | -175d | 0d | start no earlier than 2004-10-01 | LDRD Mechnical Tech [50%]; LDRD Physicist [30%] | 64h | 10,800 | LDRD |
| 79 | 1.4.8.2 | Prototype Stave Frame Design |  | 20d | 2016-12-27 | 2017-01-23 | 78 | -175d | 0d |  | LDRD Mechnical Engineer [50%]; LDRD Physicist [20%]; LDRD Mechnical Tech [30%] | 160h | 29,600 | LDRD |

Notes:
- 56: critical tasks
- 63: very tight schedule for CD-1
- 71: for CD-2

| ID | WBS | Task | Type | Duration | Start | Finish | Predecessors | Total slack | Free slack | Constraint | Resources | Work | Cost | Cost Center | DOE Cost |
| --- | --- | --- | --- | --- | --- | --- | --- | --- | --- | --- | --- | --- | --- | --- | --- |
| 80 | 1.4.8.3 | **Safety Systems** |  | 60d | 2017-02-21 | 2017-05-15 |  | 1056d |  |  |  | 144h | 29,200 |  |  |
| 81 | 1.4.8.3.1 | review sensors & interlocks |  | 20d | 2017-02-21 | 2017-03-20 | 86 | 1056d | 0d |  | LDRD Electronics Tech [30%] | 48h | 4,800 | LDRD |  |
| 82 | 1.4.8.3.2 | electrical interlock design |  | 20d | 2017-03-21 | 2017-04-17 | 81 | 1056d | 0d |  | LDRD Electronics Tech [30%] | 48h | 9,800 | LDRD |  |
| 83 | 1.4.8.3.3 | cooling interlocks design |  | 20d | 2017-04-18 | 2017-05-15 | 82 | 1056d |  |  | LDRD Mechnical Engineer [30%] | 48h | 14,600 | LDRD |  |
| 84 | 1.4.8.4 | **Cooling System** |  | 20d | 2017-01-24 | 2017-02-20 | 55, 78 | -175d | 0d |  |  | 120h | 30,400 |  |  |
| 85 | 1.4.8.4.1 | Prototype Design (modify ALICE) |  | 10d | 2017-01-24 | 2017-02-06 | 76, 79 | -175d | 0d |  | LDRD Mechnical Engineer [30%]; LDRD Physicist [20%] | 40h | 8,000 | LDRD |  |
| 86 | 1.4.8.4.2 | Mock up Testing |  | 10d | 2017-02-07 | 2017-02-20 | 85 | -125d | 0d |  | LDRD Mechnical Tech [50%]; LDRD Physicist [30%]; LDRD PostDoc [20%] | 80h | 22,400 | LDRD |  |
| 87 | 1.4.8.5 | **Stave Assembly Tooling** |  | 60d | 2017-02-07 | 2017-05-01 |  | -175d | 0d |  |  | 216h | 34,400 |  |  |
| 88 | 1.4.8.5.1 | Jig Design (modify ALICE) |  | 10d | 2017-02-07 | 2017-02-20 | 79, 85 | -175d | 0d |  | LDRD Mechnical Engineer [30%]; LDRD Physicist [10%] | 32h | 6,400 | LDRD |  |
| 89 | 1.4.8.5.2 | Prototype Jigs |  | 30d | 2017-02-21 | 2017-04-03 | 88 | -175d | 0d |  | LDRD PostDoc [20%]; LDRD Mechnical Tech [30%] | 120h | 17,600 | LDRD |  |
| 90 | 1.4.8.5.3 | Final Jigs Design and Production |  | 20d | 2017-04-04 | 2017-05-01 | 89 | -175d | 0d |  | LDRD Mechnical Engineer [10%]; LDRD Mechnical Tech [30%] | 64h | 10,400 | LDRD |  |
| 91 | 1.4.9 | **Mechanical Coneptual Design Review** |  | 12d | 2017-05-16 | 2017-05-31 |  | -185d | 0d |  |  | 53.6h | 10,720 |  |  |
| 92 | 1.4.9.1 | Mechanics Design Review |  | 1d | 2017-05-16 | 2017-05-16 | 86, 90, 101 | -185d | 0d |  | LDRD Mechnical Engineer; LDRD Physicist | 16h | 3,200 | LDRD |  |
| 93 | 1.4.9.2 | Incorporate Review Comments |  | 10d | 2017-05-17 | 2017-05-30 | 92 | -185d | 0d |  | LDRD Mechnical Engineer [30%]; LDRD Physicist [10%] | 32h | 6,400 | LDRD |  |
| 94 | 1.4.9.3 | Complete Mechanical Conceptual Design (for CD-1) | milestone | 1d | 2017-05-31 | 2017-05-31 | 93 | -185d | 0d |  | LDRD Physicist [20%]; LDRD Mechnical Engineer [50%] | 5.6h | 1,120 | LDRD |  |
| 95 | 1.4.10 | **MAPS Inner Barrel Review (CD-1)** |  | 12d | 2017-11-01 | 2017-11-16 |  | -294d | 0d |  |  | 108h | 21,600 |  |  |
| 96 | 1.4.10.1 | Final Design Review |  | 1d | 2017-11-01 | 2017-11-01 | 73, 94 | -294d | 0d | start no earlier than 2017-11-01 | LDRD Electronics Engineer; LDRD Mechnical Engineer; LDRD Physicist | 24h | 4,800 |  | DOE |
| 97 | 1.4.10.2 | Incorporate Review Comments |  | 10d | 2017-11-02 | 2017-11-15 | 96 | -294d | 0d |  | LDRD Electronics Engineer [30%]; LDRD Mechnical Engineer [30%]; LDRD Physicist [30%] | 72h | 14,400 |  | DOE |
| 98 | 1.4.10.3 | Complete Final CD-1 MAPS Design | milestone | 1d | 2017-11-16 | 2017-11-16 | 97 | -294d | 0d |  | LDRD Electronics Engineer [50%]; LDRD Mechnical Engineer [50%]; LDRD Physicist [50%] | 12h | 2,400 |  | DOE |
| 99 | 1.4.11 | **Prototype Assembly and Test** |  | 50d | 2017-03-07 | 2017-05-15 |  | -185d | 0d |  |  | 312h | 39,200 | LDRD |  |
| 100 | 1.4.11.1 | Assemble prototype |  | 30d | 2017-03-07 | 2017-04-17 | 79, 67, 68, 69, 36, 42, 45, 48, 51 | -185d | 0d |  | LDRD Electronics Tech [20%]; LDRD Mechnical Tech [20%]; LDRD Physicist [10%]; LDRD PostDoc [20%] | 168h | 21,600 | LDRD |  |
| 101 | 1.4.11.2 | Prototype Full System Test |  | 20d | 2017-04-18 | 2017-05-15 | 100 | -185d | 0d |  | Physicist [20%]; LDRD Physicist [20%]; LDRD PostDoc [30%]; LDRD Electronics Engineer [10%]; LDRD Mechnical Engineer [10%] | 144h | 17,600 | LDRD |  |
| 102 | 1.4.12 | **Softrware Development** |  | 300d | 2016-10-04 | 2017-11-27 |  | 916d |  |  |  | 2080h | 112,000 |  |  |
| 103 | 1.4.12.1 | Online Monitoring and Contorls |  | 100d | 2016-10-04 | 2017-02-20 | 28 | 916d | 0d |  | LDRD PostDoc [20%]; LDRD Physicist [10%]; Physicist [50%] | 640h | 32,000 |  |  |
| 104 | 1.4.12.2 | Offline Software and Analysis |  | 200d | 2017-02-21 | 2017-11-27 | 103 | 916d |  |  | LDRD PostDoc [30%]; LDRD Physicist [10%]; Physicist [50%] | 1440h | 80,000 |  |  |
| 105 | 1.4.13 | Detector Optimizaation and Physics Simulations (CD-1) |  | 300d | 2016-10-03 | 2017-11-24 |  | 917d |  | start no earlier than 2016-10-03 | LDRD Physicist [50%]; LDRD PostDoc [50%] | 2400h | 360,000 |  |  |

Notes:
- 80: monitoring temp, flow rates, I, V etc.
- 91: For CD-1 review, 11/2017, conceptuall design of mechanis system

| ID | WBS | Task | Duration | Start | Finish | Predecessors | Total slack | Free slack | Constraint | Resources | Work | Cost | Cost Center | Activity | DOE Cost |
| --- | --- | --- | --- | --- | --- | --- | --- | --- | --- | --- | --- | --- | --- | --- | --- |
| 106 | 1.4.14 | **Test Beam Operation** | 187d | 2019-01-11 | 2019-09-30 |  | 0d |  |  |  | 1318h | 95,200 | LDRD |  |  |
| 107 | 1.4.14.1 | Shipping/Transport | 10d | 2019-01-11 | 2019-01-24 | 101 | 0d |  | as late as possible | LDRD Mechnical Tech [20%] | 16h | 12,400 | LDRD |  |  |
| 108 | 1.4.14.2 | Setup | 5d | 2019-01-25 | 2019-01-31 | 107 | 0d |  | as late as possible | Physicist [50%]; LDRD Electronics Tech [50%]; LDRD Mechnical Tech [50%]; LDRD PostDoc [50%]; LDRD Physicist [10%] | 84h | 7,800 | LDRD |  |  |
| 109 | 1.4.14.3 | Operations | 20d | 2019-02-01 | 2019-02-28 | 108 | 0d |  | must start on 2019-02-01 | Physicist; LDRD Physicist [50%]; LDRD PostDoc [50%] | 160h | 12,000 | LDRD |  |  |
| 110 | 1.4.14.4 | Test Beam Data Analysis & Publication | 152d | 2019-03-01 | 2019-09-30 | 109 | 436d |  | finish no earlier than 2019-09-30 | LDRD Physicist [50%]; LDRD PostDoc [50%]; Physicist [50%] | 1058h | 63,000 |  |  |  |
| 111 | 1.5 | **sPHENIX Project** | 1217d? | 2016-10-03 | 2021-06-01 |  | 0d |  |  |  | 17647.6h | 3,926,337.33 |  |  |  |
| 112 | 1.5.1 | **sPHENIX Project Management** | 1217d | 2016-10-03 | 2021-06-01 |  | 0d |  |  |  | 2920.8h | 671,784 |  | sPHENIX MAPS Project |  |
| 113 | 1.5.1.1 | Level 3 Project Manager | 1217d | 2016-10-03 | 2021-06-01 |  | 0d |  | start no earlier than 2016-10-03 | Project Manager [20%] | 1947.2h | 447,856 |  |  |  |
| 114 | 1.5.1.2 | Mechanical Liason Engineer | 1217d | 2016-10-03 | 2021-06-01 |  | 0d |  | finish no earlier than 2021-06-01 | Mech Liason Eng [5%] | 486.8h | 111,964 |  |  | DOE |
| 115 | 1.5.1.3 | Electronics Liason Engineer | 1217d | 2016-10-03 | 2021-06-01 |  | 0d |  | finish no earlier than 2021-06-01 | Elec Liason Eng [5%] | 486.8h | 111,964 |  |  | DOE |
| 116 | 1.5.2 | **sPHENIX Mechanics Integration** | 289d | 2017-11-02 | 2018-12-11 |  | 119d |  |  |  | 1280h | 307,000 |  |  |  |
| 117 | 1.5.2.1 | **Stave Support Frame & Global Interface to sPHENIX** | 115d | 2017-11-02 | 2018-04-11 |  | 119d |  |  |  | 696h | 158,600 |  |  |  |
| 118 | 1.5.2.1.1 | initial design (modify ALICE) | 30d | 2017-11-02 | 2017-12-13 | 14FS+1d | 119d | 0d |  | Mechanical Engineer [50%]; Physicist [10%] | 144h | 30,000 |  |  |  |
| 119 | 1.5.2.1.2 | prototype | 60d | 2017-12-14 | 2018-03-07 | 118 | 119d | 0d |  | Mech Tech; Physicist [10%] | 336h | 82,600 |  |  |  |
| 120 | 1.5.2.1.3 | test | 10d | 2018-03-08 | 2018-03-21 | 119 | 119d | 0d |  | Mech Tech; Physicist [20%] | 96h | 16,000 |  |  |  |
| 121 | 1.5.2.1.4 | final design | 15d | 2018-03-22 | 2018-04-11 | 120 | 119d | 0d |  | Mechanical Engineer | 120h | 30,000 |  |  |  |
| 122 | 1.5.2.2 | **Cooling System** | 25d | 2018-08-01 | 2018-09-04 |  | 645d |  |  |  | 180h | 51,000 |  |  |  |
| 123 | 1.5.2.2.1 | Design (modify ALICE) | 10d | 2018-08-01 | 2018-08-14 | 76, 16, 121 | 645d | 0d |  | Mechanical Engineer | 80h | 20,000 |  |  |  |
| 124 | 1.5.2.2.2 | Mock up Testing | 10d | 2018-08-15 | 2018-08-28 | 123 | 645d | 0d |  | Mech Tech | 80h | 26,000 |  |  |  |
| 125 | 1.5.2.2.3 | Final Desgin of Cooling System | 5d | 2018-08-29 | 2018-09-04 | 124 | 645d | 0d |  | Mechanical Engineer [50%] | 20h | 5,000 |  |  |  |
| 126 | 1.5.2.3 | **Safety Systems** | 70d | 2018-09-05 | 2018-12-11 |  | 645d |  |  |  | 184h | 56,000 |  |  |  |
| 127 | 1.5.2.3.1 | review sensors & interlocks | 10d | 2018-09-05 | 2018-09-18 | 125 | 645d | 0d |  | Mechanical Engineer [50%] | 40h | 10,000 |  |  |  |
| 128 | 1.5.2.3.2 | electrical interlock design | 30d | 2018-09-19 | 2018-10-30 | 127 | 645d | 0d |  | Electronics Engineer [30%] | 72h | 23,000 |  |  |  |
| 129 | 1.5.2.3.3 | cooling interlocks design | 30d | 2018-10-31 | 2018-12-11 | 128 | 645d |  |  | Mechanical Engineer [30%] | 72h | 23,000 |  |  |  |

Notes:
- 116: critical to have early R&D fund to finish mechanics for CD-2/CD3
- 118: Early R&D fund is required, CD1/CD-3a 11/2017; / production fund only available after CD-3b 8/2018
- 126: monitoring temp, flow rates, I, V etc.

| ID | WBS | Task | Type | Duration | Start | Finish | Predecessors | Total slack | Free slack | Constraint | Resources | Work | Cost | DOE Cost | Activity |
| --- | --- | --- | --- | --- | --- | --- | --- | --- | --- | --- | --- | --- | --- | --- | --- |
| 130 | 1.5.2.4 | **Stave Assembly Tooling** |  | 45d | 2018-04-12 | 2018-06-13 |  | 119d |  |  |  | 220h | 41,400 |  |  |
| 131 | 1.5.2.4.1 | design |  | 10d | 2018-04-12 | 2018-04-25 | 121 | 119d | 0d |  | Mechanical Engineer | 80h | 20,000 |  |  |
| 132 | 1.5.2.4.2 | prototype |  | 30d | 2018-04-26 | 2018-06-06 | 131 | 119d | 0d |  | Physicist [20%]; Mech Tech [30%] | 120h | 16,400 |  |  |
| 133 | 1.5.2.4.3 | final jig design |  | 5d | 2018-06-07 | 2018-06-13 | 132 | 119d | 0d |  | Mechanical Engineer [50%] | 20h | 5,000 |  |  |
| 134 | 1.5.3 | **Mechanics Final Design Review** |  | 12d | 2018-06-14 | 2018-06-29 |  | 119d |  |  |  | 77.6h | 11,000 |  |  |
| 135 | 1.5.3.1 | Mechanics Final Design Review |  | 1d | 2018-06-14 | 2018-06-14 | 133 | 119d | 0d |  | Mechanical Engineer; Physicist | 16h | 2,000 |  |  |
| 136 | 1.5.3.2 | Incorporate Review Comments |  | 10d | 2018-06-15 | 2018-06-28 | 135 | 119d | 0d |  | LDRD Mechnical Engineer [50%]; Physicist [20%] | 56h | 8,000 |  |  |
| 137 | 1.5.3.3 | Complete Final Mechanical Design | milestone | 1d | 2018-06-29 | 2018-06-29 | 136 | 119d | 0d |  | Physicist [20%]; Mechanical Engineer [50%] | 5.6h | 1,000 |  |  |
| 138 | 1.5.4 | **MAPS Inner Barrel Review (CD-2/CD-3)** |  | 12d | 2018-07-02 | 2018-07-17 |  | 119d |  |  |  | 181.33h | 28,000 |  |  |
| 139 | 1.5.4.1 | MAPS Final Design Review |  | 1d | 2018-07-02 | 2018-07-02 | 137, 22 | 119d | 0d |  | Electronics Engineer; Mechanical Engineer; Physicist | 24h | 4,000 | DOE |  |
| 140 | 1.5.4.2 | Incorporate Review Comments |  | 10d | 2018-07-03 | 2018-07-16 | 139 | 119d | 0d |  | Electronics Engineer [50%]; Mechanical Engineer [50%]; Physicist | 133.33h | 20,000 | DOE |  |
| 141 | 1.5.4.3 | Complete Final Design (CD-2) | milestone | 1d | 2018-07-17 | 2018-07-17 | 140 | 119d | 10d |  | Electronics Engineer; Mechanical Engineer; Physicist | 24h | 4,000 | DOE |  |
| 142 | 1.5.5 | **Productions** |  | 534d? | 2018-06-14 | 2020-06-30 |  | 36d |  |  |  | 9939.87h | 2,660,153.33 |  | Production |
| 143 | 1.5.5.1 | Full Pre-Production-Mechnical System Mock Up Test |  | 90d | 2018-06-14 | 2018-10-17 | 133 | 684d |  |  | Mechanical Engineer [13.3%]; Mech Tech [20%]; Physicist [30%] | 259.2h | 52,800 |  |  |
| 144 | 1.5.5.2 | **Procurements** |  | 180d? | 2018-08-01 | 2019-04-09 |  | 2d |  |  |  | 4080h | 2,246,020 |  |  |
| 145 | 1.5.5.2.1 | **CERN Procuments** |  | 180d? | 2018-08-01 | 2019-04-09 |  | 109d |  |  |  | 3667.2h | 1,097,840 |  |  |
| 146 | 1.5.5.2.1.1 | Produce 68 Inner Staves |  | 180d | 2018-08-01 | 2019-04-09 | 141, 16 | 109d | 0d | start no earlier than 2018-02-22 | Physicist [200%]; Elec tech [50%] | 3600h | 1,064,000 | DOE |  |
| 147 | 1.5.5.2.1.2 | Other ITS/CERN items |  | 120d | 2018-08-01 | 2019-01-15 | 146SS | 560d | 0d |  | Physicist [5%]; Mech Tech [2%] | 67.2h | 13,840 |  |  |
| 148 | 1.5.5.2.1.3 | Travel and Per Diem at CERN |  | 180d? | 2018-08-01 | 2019-04-09 | 147SS | 560d |  |  |  |  | 20,000 |  |  |
| 149 | 1.5.5.2.2 | Procure 68 Readout / FEM Units |  | 100d | 2018-08-01 | 2018-12-18 | 16, 141SS+1d | 447d | 0d |  | Physicist [10%]; Elec tech [20%] | 240h | 354,000 | DOE |  |
| 150 | 1.5.5.2.3 | Procure Optical Links 68 |  | 60d | 2018-08-02 | 2018-10-24 | 149SS+1d | 447d | 0d |  | Physicist [1%]; Elec tech [1%] | 9.6h | 43,160 | DOE |  |
| 151 | 1.5.5.2.4 | Procure 34 Common Readout Units | manual | 100d | 2018-08-03 | 2018-12-20 | 150SS+1d |  |  |  | Physicist [1%]; Elec tech [1%] | 16h | 183,300 | DOE |  |
| 152 | 1.5.5.2.5 | Procure 100 SamTec Cables | manual | 60d | 2018-08-06 | 2018-10-26 | 151SS+1d |  |  |  | Physicist [1%]; Elec tech [1%] | 9.6h | 27,960 | DOE |  |
| 153 | 1.5.5.2.6 | Procure Ancillary Materials (LVPS and cables etc) |  | 100d | 2018-08-07 | 2018-12-24 | 152SS+1d | 445d | 0d |  | Physicist [1%]; Mech Tech [1%] | 16h | 61,600 | DOE |  |
| 154 | 1.5.5.2.7 | Procure Cooling Plant |  | 100d | 2018-08-01 | 2018-12-18 | 16 | 332d | 0d |  | Physicist [1%]; Mech Tech [1%] | 16h | 118,600 | DOE |  |
| 155 | 1.5.5.2.8 | Procure Assembly Fixtures & Jigs |  | 60d | 2018-08-02 | 2018-10-24 | 154SS+1d | 332d | 0d |  | Physicist [1%]; Mech Tech [1%] | 9.6h | 100,960 | DOE |  |
| 156 | 1.5.5.2.9 | Procure End Wheels |  | 100d | 2018-08-03 | 2018-12-20 | 155SS+1d | 332d | 0d |  | Physicist [1%]; Mech Tech [1%] | 16h | 35,600 | DOE |  |
| 157 | 1.5.5.2.10 | Procure Cylindrical Structural Shells |  | 100d | 2018-08-06 | 2018-12-21 | 156SS+1d | 332d | 0d |  | Physicist [1%]; Mech Tech [1%] | 16h | 12,600 | DOE |  |
| 158 | 1.5.5.2.11 | Procure Detector Half Barrels |  | 100d | 2018-08-07 | 2018-12-24 | 157SS+1d | 332d | 0d |  | Physicist [1%]; Mech Tech [1%] | 16h | 14,600 | DOE |  |
| 159 | 1.5.5.2.12 | Procure Service Half Barrels |  | 100d | 2018-08-08 | 2018-12-25 | 158SS+1d | 332d | 0d |  | Physicist [1%]; Mech Tech [1%] | 16h | 121,600 | DOE |  |
| 160 | 1.5.5.2.13 | Procure Detector and Service Half Barrels |  | 100d | 2018-08-09 | 2018-12-26 | 159SS+1d | 332d | 0d |  | Physicist [1%]; Mech Tech [1%] | 16h | 22,600 | DOE |  |
| 161 | 1.5.5.2.14 | Procure Two Half Support Structures |  | 100d | 2018-08-10 | 2018-12-27 | 160SS+1d | 332d | 213d |  | Physicist [1%]; Mech Tech [1%] | 16h | 51,600 | DOE |  |

Notes:
- 143: Mechnics production test run; / may not needed?
- 146: 48+20% = 58; consider to have 40% spare: 68 in total / could start early right after ITS production end, ~2/23/18 (final electronics review finished) assuming sPHENIX can morgage with CERN to produce staves, can gain 6 months of advanced production; / production length ~ 6 months = 20x6days
- 147: other small items related to MAPS testing etc.
- 148: 1 FTE lodging and per diem for 6 months; / $3K/month
- 149: 48+40% spares; / obtain desgin files and produce them in US

| ID | WBS | Task | Type | Duration | Start | Finish | Predecessors | Total slack | Free slack | Resources | Work | Cost | DOE Cost |
| --- | --- | --- | --- | --- | --- | --- | --- | --- | --- | --- | --- | --- | --- |
| 162 | 1.5.5.3 | **Assembly and Testing at BNL** |  | 400d | 2018-12-19 | 2020-06-30 |  | 189d |  |  | 5600.67h | 361,333.33 |  |
| 163 | 1.5.5.3.1 | Test Production FEMS, e-Links, CRU, LV, optical links |  | 60d | 2018-12-25 | 2019-03-18 | 149, 150, 151, 152, 153 | 576d |  | Elec tech [30%]; Physicist [200%] | 1104h | 28,800 |  |
| 164 | 1.5.5.3.2 | Test Cooling System |  | 20d | 2018-12-19 | 2019-01-15 | 154 | 620d |  | Mech Tech [50%]; Physicist [50%] | 160h | 16,000 |  |
| 165 | 1.5.5.3.3 | Stave Reciept Inspection |  | 10d | 2019-04-10 | 2019-04-23 | 146 | 109d | 0d | Physicist [20%]; Elec tech [10.8%] | 24.67h | 1,733.33 | DOE |
| 166 | 1.5.5.3.4 | Individual Stave Readout Test |  | 70d | 2019-04-24 | 2019-07-30 | 165 | 109d | 0d | Physicist [300%]; Elec tech [20%] | 352h | 22,400 | DOE |
| 167 | 1.5.5.3.5 | Metrology on Stave Assemblies |  | 70d | 2019-07-31 | 2019-11-05 | 166 | 109d | 0d | Mechanical Engineer [30%] | 168h | 42,000 | DOE |
| 168 | 1.5.5.3.6 | Assemble full Ladders into Half support |  | 100d | 2019-11-06 | 2020-03-24 | 167, 155, 156, 157, 158, 159, 160, 161 | 109d | 0d | Mech Tech [150%]; Physicist [200%] | 1792h | 38,400 | DOE |
| 169 | 1.5.5.3.7 | Metrology on Final Assembly |  | 10d | 2020-03-25 | 2020-04-07 | 168 | 109d | 0d | Mechanical Engineer | 80h | 20,000 | DOE |
| 170 | 1.5.5.3.8 | Half detector Assembly Readout and Cooling Test |  | 60d | 2020-04-08 | 2020-06-30 | 149, 150, 151, 152, 153, 169 | 109d | 0d | Physicist [200%]; Mech Tech; Elec tech | 1920h | 192,000 | DOE |
| 171 | 1.5.6 | **Installation** |  | 131d | 2020-07-01 | 2020-12-30 |  | 109d | 108d |  | 3248h | 248,400 |  |
| 172 | 1.5.6.1 | Installation Prep |  | 10d | 2020-07-01 | 2020-07-14 | 170 | 109d | 0d | Mech Tech; Physicist | 160h | 16,000 | DOE |
| 173 | 1.5.6.2 | Installation Review |  | 1d | 2020-07-15 | 2020-07-15 | 172 | 109d | 0d | Physicist; Mechanical Engineer | 16h | 2,000 | DOE |
| 174 | 1.5.6.3 | Installation |  | 60d | 2020-07-16 | 2020-10-07 | 173 | 109d | 0d | Physicist [200%]; Mech Tech; Elec tech | 1920h | 192,000 |  |
| 175 | 1.5.6.4 | Commissioning |  | 60d | 2020-10-08 | 2020-12-30 | 174 | 109d | 0d | Physicist [200%]; Mech Tech [20%]; Elec tech [20%] | 1152h | 38,400 |  |
| 176 | 1.5.7 | Ready for beam | milestone | 0d | 2020-12-30 | 2020-12-30 | 175 | 109d |  |  |  |  |  |

Notes:
- 165: start the assembly at partrial delivery of staves, 60days from the start of stave production ; / allow 10days for shipping from CERN to BNL; / partial delivery every month
- 166: Statve test starts 10 days after reciept of staves
- 168: can start earlier if procument (stave production) can be morgaged, by up to ~ 1 month in time.! / can start work as early as 2 days after the start of metrologly on stave assembly;
- 171: installatino by 6/2021
- 174: commissioning starts 4/1/2021, last 2 months, ends on 6/1/2021 to be ready for beam
