# MAPS Inner Barrel

Schedule from MS Project, 2016-08-01 to 2021-06-01, costs in $, A marks actual dates.
Guest Scientist, LANL

## Calendars

- Standard: Mon-Fri 08:00-12:00, 13:00-17:00; Sat-Sun off.

## Resources

| Resource | Rate | Cost per use |
| --- | --- | --- |
| Mech Liason Eng | 100 |  |
| Elec Liason Eng | 100 |  |
| Project Manager | 100 |  |
| Physicist |  |  |
| Elec tech | 80 |  |
| Mech Tech | 80 |  |
| Electronics Engineer | 100 |  |
| Mechanical Engineer | 100 |  |
| M&S |  | 1 |
| Electrical Engineer | 100 |  |
| LDRD Physicist | 230 |  |
| LDRD PostDoc | 90 |  |
| LDRD Electronics Engineer | 230 |  |
| LDRD Mechnical Engineer | 230 |  |
| LDRD Mechnical Tech | 90 |  |
| LDRD Electronics Tech | 90 |  |

## Schedule

| ID | WBS | Task | Type | Duration | Start | Finish | Predecessors | Remaining | Actual start | Total slack | Free slack | Constraint | Work | Actual work | Cost | Actual cost | DOE Cost | Activity | Cost Center |
| --- | --- | --- | --- | --- | --- | --- | --- | --- | --- | --- | --- | --- | --- | --- | --- | --- | --- | --- | --- |
| 1 | 1 | **MAPS Inner Barrel** |  | 1217d | 2016-10-03 | 2021-06-01 |  | 1213.43d | 2016-08-01 |  |  | start no earlier than 2005-10-21 | 35638.8h | 40h | 4,492,254.86 | 11,820 |  |  |  |
| 2 | 1.1 | MAPS Inner Barrel Starts | milestone | 0d | 2016-10-01 | 2016-10-01 |  |  |  | 0d |  | must start on 2016-10-01 |  |  |  |  | DOE |  |  |
| 3 | 1.2 | MAPS Inner Barrel Ends | milestone | 0d | 2021-06-01 | 2021-06-01 |  |  |  | 0d |  | must finish on 2021-06-01 |  |  |  |  | DOE |  |  |
| 4 | 1.3 | **Milestones & Key Tasks** |  | 0d | 2016-10-03 | 2016-10-03 |  |  |  |  |  |  |  |  |  |  |  |  |  |
| 5 | 1.3.1 | **ALICE ITS Key Tasks** |  | 0d | 2017-01-02 | 2017-01-02 |  |  |  |  |  |  |  |  |  |  |  |  |  |
| 6 | 1.3.1.1 | ALICE MAPS Production (7/17) |  | 240d? | 2016-08-01 | 2017-06-30 |  |  |  | 1022d |  | finish no earlier than 2017-06-30 |  |  |  |  |  |  |  |
| 7 | 1.3.1.2 | ALICE ITS IB FPC Production (9/17) |  | 90d | 2017-05-01 | 2017-09-01 |  |  |  | 977d |  | finish no earlier than 2017-09-01 |  |  |  |  |  |  |  |
| 8 | 1.3.1.3 | ALICE ITS IB Stave Production (1/18) |  | 1d? | 2018-01-02 | 2018-01-02 |  |  |  | 890d |  | finish no earlier than 2018-01-02 |  |  |  |  |  |  |  |
| 9 | 1.3.1.4 | ALICE ITS IB Stave Assembly (3/18) |  | 262d | 2017-01-02 | 2018-01-02 |  |  |  | -139d | 0d | start no earlier than 2017-01-01 |  |  |  |  |  | ITS construction |  |
| 10 | 1.3.1.5 | ALICE ITS Electronics Pre-Production (7/17) |  | 100d | 2017-02-22 | 2017-07-11 |  |  |  | -181d | 0d | start no earlier than 2017-02-22 |  |  |  |  |  | ITS Electronics Pre-Production |  |
| 11 | 1.3.1.6 | ALICE ITS Electronics Production (6/18) |  | 240d | 2017-07-13 | 2018-06-13 | 10 |  |  | 774d |  | start no earlier than 2017-07-13 |  |  |  |  |  | ITS Electronics Production |  |
| 12 | 1.3.2 | **sPHENIX Milestones** |  | 1195d | 2016-11-01 | 2021-06-01 |  |  |  |  |  |  |  |  |  |  |  |  |  |
| 13 | 1.3.2.1 | sPHENIX Technical Design CD-0 | milestone | 0d | 2016-11-01 | 2016-11-01 |  |  |  | 1196d |  | start no earlier than 2016-11-01 |  |  |  |  |  | CD-0 (11/2016) |  |
| 14 | 1.3.2.2 | sPHENIX Technical Design (CD-1/CD-3a) | milestone | 0d | 2017-11-01 | 2017-11-01 |  |  |  | 119d | 0d | start no earlier than 2017-11-01 |  |  |  |  |  | CD-1 (11/2017) |  |
| 15 | 1.3.2.3 | sPHENIX Technical Dewsgin (CD-2) | milestone | 0d | 2018-07-02 | 2018-07-02 | 140 |  |  | 761d |  | start no earlier than 2018-06-01 |  |  |  |  |  | CD-2 (7/2018) |  |
| 16 | 1.3.2.4 | sPHENIX Start Construction (CD-3b) | milestone | 0d | 2018-08-01 | 2018-08-01 |  |  |  | 109d | 0d | start no earlier than 2018-08-01 |  |  |  |  |  | CD-3b (8/2018) |  |
| 17 | 1.3.2.5 | sPHENIX Installed and Ready for Beam | milestone | 0d | 2021-06-01 | 2021-06-01 | 172 |  |  | 1d |  | start no earlier than 2021-06-01 |  |  |  |  |  | ready for beam (6/2021) |  |
| 18 | 1.3.3 | **LDRD Milestones & Critical Tasks** |  | 781d | 2016-10-03 | 2019-09-30 |  |  |  | -781d | 0d |  |  |  |  |  |  |  |  |
| 19 | 1.3.3.1 | LDRD Start and End |  | 781d | 2016-10-03 | 2019-09-30 |  |  |  | -781d | 0d | start no earlier than 2016-10-03 |  |  |  |  |  |  |  |
| 20 | 1.3.3.2 | Complete MoU LANL-ALICE | milestone | 0d | 2016-12-09 | 2016-12-09 | 27 |  |  | -50d | 0d |  |  |  |  |  |  |  |  |
| 21 | 1.3.3.3 | Setup ALICE Readout Test Stands | milestone | 0d | 2017-02-17 | 2017-02-17 | 34 |  |  | -100d | 0d |  |  |  |  |  |  |  |  |
| 22 | 1.3.3.4 | Complete final sPHENIX Readout Design Review | milestone | 0d | 2017-07-26 | 2017-07-26 | 74 |  |  | -213d | 0d |  |  |  |  |  |  |  |  |
| 23 | 1.3.3.5 | Complete Final MAPS Detector Design (CD-1) | milestone | 0d | 2017-11-16 | 2017-11-16 | 99 |  |  | -294d | 0d |  |  |  |  |  |  |  |  |
| 24 | 1.3.3.6 | sPHENIX Test Beam |  | 21d | 2019-02-01 | 2019-03-01 |  |  |  | -630d | 0d | start no earlier than 2019-02-01 |  |  |  |  |  |  | LDRD |
| 25 | 1.3.3.7 | MAPS Final Design (CD-2/CD-3)? | milestone | 0d | 2016-10-03 | 2016-10-03 |  |  |  | 0d |  |  |  |  |  |  |  |  |  |

Notes:
- 14: critical and lond lead time items can be purchased at CD3a
- 16: constructino fund available at CD-3b
- 17: commissioning 4/1-6/1, 2021; / ready for beam 6/1/2021
- 22: LDRD complete full readout electronics final design

| ID | WBS | Task | Type | Duration | Start | Finish | Predecessors | Complete | Remaining | Total slack | Free slack | Constraint | Resources | Work | Actual work | Cost | Actual cost | Cost Center | Activity |
| --- | --- | --- | --- | --- | --- | --- | --- | --- | --- | --- | --- | --- | --- | --- | --- | --- | --- | --- | --- |
| 26 | 1.4 | **LANL LDRD** |  | 781d | 2016-10-03 A | 2019-09-30 |  | 1% | 770.71d | 436d |  |  |  | 10770.8h | 40h | 1,518,812 | 11,820 | LDRD | LANL R&D |
| 27 | 1.4.1 | MOU btw LANL and ALICE for R&D |  | 50d | 2016-10-03 | 2016-12-09 |  |  |  | -190d | 0d | start no earlier than 2016-10-03 | LDRD Physicist [20%] | 80h |  | 18,400 |  | LDRD |  |
| 28 | 1.4.2 | **Obtain Designs from ALICE** |  | 1d | 2016-10-03 | 2016-10-03 |  |  |  | -225d | 0d |  |  | 24h |  | 2,760 |  |  |  |
| 29 | 1.4.2.1 | Obtain Test Stand Design from CERN | milestone | 1d | 2016-10-03 | 2016-10-03 |  |  |  | 916d | 0d | start no earlier than 2016-10-03 | LDRD Electronics Engineer [50%]; Physicist [50%] | 8h |  | 920 |  | LDRD |  |
| 30 | 1.4.2.2 | Obtain ALICE Readout Unit Design | milestone | 1d | 2016-10-03 | 2016-10-03 |  |  |  | -225d | 0d |  | Physicist [50%]; LDRD Electronics Engineer [50%] | 8h |  | 920 |  | LDRD |  |
| 31 | 1.4.2.3 | obtain ALICE CAD model | milestone | 1d | 2016-10-03 | 2016-10-03 |  |  |  | -175d | 0d | start no earlier than 2016-06-01 | Physicist [50%]; LDRD Mechnical Engineer [50%] | 8h |  | 920 |  | LDRD | ALICE CAD model |
| 32 | 1.4.3 | **Setup Alice Readout Test Stand** |  | 100d | 2016-10-03 A | 2017-02-17 |  | 30% | 70d | -10d | 0d |  |  | 200h | 40h | 49,640 | 11,820 | LDRD |  |
| 33 | 1.4.3.1 | Procure 2 Test Stands |  | 90d | 2016-10-03 A | 2017-02-03 | 31 | 33% | 60d | -80d | 0d |  | Elec tech [5%]; Physicist [5%] | 64h | 40h | 33,840 | 11,820 | LDRD |  |
| 34 | 1.4.3.2 | Setup Test Stands |  | 10d | 2017-02-06 | 2017-02-17 | 33 |  |  | -224d | 0d |  | Physicist [20%]; LDRD PostDoc; LDRD Electronics Tech [50%] | 136h |  | 15,800 |  | LDRD |  |
| 35 | 1.4.4 | **Procure R&D ALICE Staves** |  | 180d | 2016-12-12 | 2017-08-18 |  |  |  | -184d | 0d |  |  | 1260h |  | 175,480 |  | LDRD |  |
| 36 | 1.4.4.1 | Procure and Produce 4 Staves |  | 60d | 2016-12-12 | 2017-03-03 | 27, 9SS-60d |  |  | -184d | 0d |  | Physicist [50%]; LDRD Electronics Tech; LDRD PostDoc | 1200h |  | 141,400 |  | LDRD |  |
| 37 | 1.4.4.2 | Test Staves |  | 5d | 2017-02-27 | 2017-03-03 | 36FS-5d |  |  | -184d | 0d |  | LDRD Physicist [20%]; LDRD PostDoc [50%]; LDRD Electronics Tech [30%] | 60h |  | 7,080 |  | LDRD |  |
| 38 | 1.4.4.3 | Travel and Per Diem Support |  | 180d | 2016-12-12 | 2017-08-18 | 36SS |  |  | 987d |  |  |  |  |  | 27,000 |  | LDRD |  |
| 39 | 1.4.5 | **Procure ALICE Electronics & Cabels** |  | 116d | 2016-10-03 | 2017-03-13 |  |  |  | -190d | 0d |  |  | 331.2h |  | 77,064 |  | LDRD |  |
| 40 | 1.4.5.1 | **ALICE Readout Electronics Boards** |  | 65d | 2016-12-13 | 2017-03-13 |  |  |  | -190d | 0d |  |  | 199.2h |  | 30,344 |  |  |  |
| 41 | 1.4.5.1.1 | **Readout Units (RDOs)** |  | 65d | 2016-12-13 | 2017-03-13 |  |  |  | -190d | 0d |  |  | 136h |  | 14,760 |  |  |  |
| 42 | 1.4.5.1.1.1 | Procure 4 RDOs |  | 60d | 2016-12-13 | 2017-03-06 | 10SS-60d, 27FS+1d |  |  | -190d | 0d |  | Physicist [5%]; LDRD Electronics Tech [5%] | 48h |  | 7,160 |  | LDRD |  |
| 43 | 1.4.5.1.1.2 | Test RDOs |  | 10d | 2017-02-28 | 2017-03-13 | 42FS-5d |  |  | -190d | 0d |  | Physicist [20%]; LDRD Electronics Tech [30%]; LDRD PostDoc [50%]; LDRD Physicist [10%] | 88h |  | 7,600 |  | LDRD |  |
| 44 | 1.4.5.1.2 | **Common Readout Units (CRUs)** |  | 65d | 2016-12-13 | 2017-03-13 |  |  |  | -190d | 0d |  |  | 63.2h |  | 15,584 |  |  |  |
| 45 | 1.4.5.1.2.1 | Procure 2 CRUs |  | 60d | 2016-12-13 | 2017-03-06 | 27FS+1d, 10SS-60d |  |  | -190d | 0d |  | Physicist [2%]; LDRD Electronics Tech [2%] | 19.2h |  | 10,864 |  | LDRD |  |
| 46 | 1.4.5.1.2.2 | Test CRUs |  | 5d | 2017-03-07 | 2017-03-13 | 45 |  |  | -190d | 0d |  | Physicist [10%]; LDRD Electronics Tech [30%]; LDRD PostDoc [50%]; LDRD Physicist [20%] | 44h |  | 4,720 |  | LDRD |  |
| 47 | 1.4.5.2 | **SamTec Cables** |  | 11d | 2016-10-03 | 2016-10-17 |  |  |  | -86d | 0d |  |  | 8h |  | 2,720 |  |  |  |
| 48 | 1.4.5.2.1 | Procure 7 SamTec Cables |  | 10d | 2016-10-03 | 2016-10-14 |  |  |  | -86d | 0d |  | LDRD Electronics Tech [5%] | 4h |  | 2,360 |  | LDRD |  |
| 49 | 1.4.5.2.2 | Test Cables |  | 1d | 2016-10-17 | 2016-10-17 | 48 |  |  | -85d | 0d |  | LDRD Electronics Tech [50%] | 4h |  | 360 |  | LDRD |  |

Notes:
- 26: LANL LDRD activities
- 27: Use ITS production line to train local people and produce staves for sPHENIX; / provide 1 FTE from 1/2017 - 6/2018+ for LDRD and later for sPHENIX
- 29: The readout test stand design has already been completed by ALICE.
- 31: Walt already obtained CAD model
- 33: Cost from Leo. Only a few custom boards, standard items standard: power supplies, etc. One stand would be procured early, one late, both under LDRD. / CERN-LANL MOU comes later in 2016, ~Dec. 2016? / Time needed to setup an CERN accout etc. may delay the actual procument date. MXL
- 34: LDRD PD + Tech, working with external collaorators/physicists
- 36: work on MOU to get 4 staves as early as possible; within 60 from the production ; / train LANL staff for MAPS assembly and test. M&S $20K for 6 months
- 37: assume testing 1 stave every two days;
- 38: $4.5K/month including lodging(100) and per diem (50) 1 FTE (combination of PD and staff) / for 6 months;
- 40: critical tasks
- 48: from DigiKey?

| ID | WBS | Task | Type | Duration | Start | Finish | Predecessors | Total slack | Free slack | Constraint | Resources | Work | Cost | Cost Center |
| --- | --- | --- | --- | --- | --- | --- | --- | --- | --- | --- | --- | --- | --- | --- |
| 50 | 1.4.5.3 | **Optical Cables** |  | 11d | 2016-10-04 | 2016-10-18 |  | -86d | 0d |  |  | 4h | 760 |  |
| 51 | 1.4.5.3.1 | Procure 4 Optical Cables |  | 10d | 2016-10-04 | 2016-10-17 | 48SS+1d | -86d | 0d |  | LDRD Electronics Tech [2%] | 1.6h | 544 | LDRD |
| 52 | 1.4.5.3.2 | Test Optical Cables |  | 1d | 2016-10-18 | 2016-10-18 | 51 | -86d | 0d |  | LDRD Electronics Tech [30%] | 2.4h | 216 | LDRD |
| 53 | 1.4.5.4 | **Procure Ancillaries** |  | 64d | 2016-10-04 | 2016-12-30 |  | -159d | 0d |  |  | 120h | 43,240 | LDRD |
| 54 | 1.4.5.4.1 | Procure LV,HV,etc |  | 60d | 2016-10-04 | 2016-12-26 | 32SS+1d | -159d | 0d | start no earlier than 2016-10-03 | Physicist [5%]; LDRD Electronics Tech [5%] | 48h | 27,160 | LDRD |
| 55 | 1.4.5.4.2 | Procure Racks |  | 60d | 2016-10-06 | 2016-12-28 | 54SS+2d | -159d | 0d | start no earlier than 2016-10-03 | LDRD Electronics Tech [5%] | 24h | 7,160 | LDRD |
| 56 | 1.4.5.4.3 | Procure Chiller |  | 60d | 2016-10-10 | 2016-12-30 | 55SS+2d | -159d | 0d |  | Physicist [5%]; Elec tech [5%] | 48h | 8,920 | LDRD |
| 57 | 1.4.6 | **sPHENIX Readout Electronics Integration** |  | 270d | 2016-10-04 | 2017-10-16 |  | -225d | 0d |  |  | 920h | 191,400 |  |
| 58 | 1.4.6.1 | Initial FEM Design (modify ALICE) |  | 40d | 2016-10-04 | 2016-11-28 | 30 | -225d | 0d |  | LDRD Electronics Engineer [50%]; LDRD Physicist [10%] | 192h | 44,160 | LDRD |
| 59 | 1.4.6.2 | Prototype FEM |  | 60d | 2016-11-29 | 2017-02-20 | 58 | -225d | 0d |  | LDRD Electronics Tech [10%]; LDRD Electronics Engineer [10%]; LDRD Physicist [20%] | 192h | 42,440 | LDRD |
| 60 | 1.4.6.3 | FEM test-I |  | 5d | 2017-02-21 | 2017-02-27 | 59, 34 | -225d | 0d |  | LDRD PostDoc [30%]; LDRD Electronics Engineer [50%]; LDRD Electronics Tech [20%]; LDRD Physicist [20%] | 48h | 8,240 | LDRD |
| 61 | 1.4.6.4 | Revised FEM Design |  | 20d | 2017-02-28 | 2017-03-27 | 60 | -225d | 0d |  | LDRD Electronics Engineer [60%] | 96h | 22,080 | LDRD |
| 62 | 1.4.6.5 | Prototype FEM-II |  | 60d | 2017-03-28 | 2017-06-19 | 61 | -225d | 0d |  | LDRD Electronics Tech [20%]; LDRD PostDoc [20%] | 192h | 22,280 | LDRD |
| 63 | 1.4.6.6 | FEM test-II |  | 5d | 2017-06-20 | 2017-06-26 | 62 | -225d | 0d |  | LDRD Electronics Engineer [20%]; LDRD Electronics Tech [20%]; LDRD PostDoc [50%] | 36h | 4,360 | LDRD |
| 64 | 1.4.6.7 | Final FEM design (CD-1) | milestone | 10d | 2017-06-26 | 2017-07-10 | 63 | -225d | 0d |  | Physicist [5%]; LDRD Electronics Engineer [50%]; LDRD PostDoc; LDRD Physicist [20%] | 60h | 12,880 | LDRD |
| 65 | 1.4.6.8 | Procure 4 FEMs |  | 60d | 2017-07-11 | 2017-10-02 | 64 | 946d | 0d |  | LDRD Electronics Tech [5%] | 24h | 22,160 | LDRD |
| 66 | 1.4.6.9 | Final FEM Test |  | 10d | 2017-10-03 | 2017-10-16 | 65 | 946d |  |  | LDRD Electronics Engineer [30%]; LDRD Physicist [20%]; LDRD PostDoc [30%]; LDRD Electronics Tech [20%] | 80h | 12,800 | LDRD |
| 67 | 1.4.7 | **sPHENIX DAQ System Integration** |  | 70d | 2016-11-29 | 2017-03-06 |  | -185d | 0d |  |  | 528h | 104,880 |  |
| 68 | 1.4.7.1 | Slow Control Design |  | 60d | 2016-11-29 | 2017-02-20 | 58 | -185d | 0d |  | Physicist [10%]; LDRD Physicist [10%]; LDRD PostDoc [20%]; LDRD Electronics Engineer [20%] | 288h | 51,760 | LDRD |
| 69 | 1.4.7.2 | Trigger Interface Design |  | 60d | 2016-12-06 | 2017-02-27 | 58, 68SS+5d | -185d | 0d |  | Physicist [10%]; LDRD Electronics Engineer [10%]; LDRD Physicist [10%] | 144h | 32,080 | LDRD |
| 70 | 1.4.7.3 | DAQ Interface Design |  | 60d | 2016-12-13 | 2017-03-06 | 58, 69SS+5d | -185d | 0d |  | Physicist [10%]; LDRD Electronics Engineer [10%] | 96h | 21,040 | LDRD |
| 71 | 1.4.8 | **Electronics Final Design Review** |  | 12d | 2017-07-11 | 2017-07-26 |  | -225d | 0d |  |  | 65.6h | 15,088 |  |
| 72 | 1.4.8.1 | Electronics Design Review |  | 1d | 2017-07-11 | 2017-07-11 | 64, 63 | -225d | 0d |  | LDRD Electronics Engineer; LDRD Physicist | 16h | 3,680 | LDRD |
| 73 | 1.4.8.2 | Incorporate Review Comments |  | 10d | 2017-07-12 | 2017-07-25 | 72 | -225d | 0d |  | LDRD Physicist [20%]; LDRD Electronics Engineer [30%] | 40h | 9,200 | LDRD |
| 74 | 1.4.8.3 | Complete Final Electronics Design | milestone | 1d | 2017-07-26 | 2017-07-26 | 73 | -225d | 0d |  | LDRD Physicist [20%]; LDRD Electronics Engineer | 9.6h | 2,208 | LDRD |

Notes:
- 57: critical tasks
- 64: very tight schedule for CD-1
- 72: for CD-2

| ID | WBS | Task | Type | Duration | Start | Finish | Predecessors | Total slack | Free slack | Constraint | Resources | Work | Cost | Cost Center | DOE Cost |
| --- | --- | --- | --- | --- | --- | --- | --- | --- | --- | --- | --- | --- | --- | --- | --- |
| 75 | 1.4.9 | **Mechanical Support and Cooling** |  | 160d | 2016-10-04 | 2017-05-15 |  | -175d | 0d |  |  | 992h | 193,720 |  |  |
| 76 | 1.4.9.1 | **Specifications** |  | 60d | 2016-10-04 | 2016-12-26 |  | -175d | 0d |  |  | 336h | 62,720 |  |  |
| 77 | 1.4.9.1.1 | Review & Simulate Heat Load |  | 40d | 2016-10-04 | 2016-11-28 | 31 | -175d | 0d | start no earlier than 2016-10-03 | LDRD Mechnical Engineer [30%]; LDRD Physicist [20%]; LDRD PostDoc [20%] | 224h | 42,560 | LDRD |  |
| 78 | 1.4.9.1.2 | review mechanical tolerances/distortions |  | 10d | 2016-11-29 | 2016-12-12 | 77 | -175d | 0d | start no earlier than 2004-10-01 | LDRD Mechnical Engineer [30%]; LDRD Physicist [30%] | 48h | 11,040 | LDRD |  |
| 79 | 1.4.9.1.3 | review disassembly/repair options |  | 10d | 2016-12-13 | 2016-12-26 | 78 | -175d | 0d | start no earlier than 2004-10-01 | LDRD Mechnical Tech [50%]; LDRD Physicist [30%] | 64h | 9,120 | LDRD |  |
| 80 | 1.4.9.2 | Prototype Stave Frame Design |  | 20d | 2016-12-27 | 2017-01-23 | 79 | -175d | 0d |  | LDRD Mechnical Engineer [50%]; LDRD Physicist [20%]; LDRD Mechnical Tech [30%] | 160h | 30,080 | LDRD |  |
| 81 | 1.4.9.3 | **Safety Systems** |  | 60d | 2017-02-21 | 2017-05-15 |  | 1056d |  |  |  | 144h | 29,680 |  |  |
| 82 | 1.4.9.3.1 | review sensors & interlocks |  | 20d | 2017-02-21 | 2017-03-20 | 87 | 1056d | 0d |  | LDRD Electronics Tech [30%] | 48h | 4,320 | LDRD |  |
| 83 | 1.4.9.3.2 | electrical interlock design |  | 20d | 2017-03-21 | 2017-04-17 | 82 | 1056d | 0d |  | LDRD Electronics Tech [30%] | 48h | 9,320 | LDRD |  |
| 84 | 1.4.9.3.3 | cooling interlocks design |  | 20d | 2017-04-18 | 2017-05-15 | 83 | 1056d |  |  | LDRD Mechnical Engineer [30%] | 48h | 16,040 | LDRD |  |
| 85 | 1.4.9.4 | **Cooling System** |  | 20d | 2017-01-24 | 2017-02-20 | 56, 79 | -175d | 0d |  |  | 136h | 30,080 |  |  |
| 86 | 1.4.9.4.1 | Prototype Design (modify ALICE) |  | 10d | 2017-01-24 | 2017-02-06 | 77, 80 | -175d | 0d |  | LDRD Mechnical Engineer [30%]; LDRD Physicist [20%] | 40h | 9,200 | LDRD |  |
| 87 | 1.4.9.4.2 | Mock up Testing |  | 10d | 2017-02-07 | 2017-02-20 | 86 | -125d | 0d |  | LDRD Mechnical Tech [50%]; LDRD Physicist [20%]; LDRD PostDoc [50%] | 96h | 20,880 | LDRD |  |
| 88 | 1.4.9.5 | **Stave Assembly Tooling** |  | 60d | 2017-02-07 | 2017-05-01 |  | -175d | 0d |  |  | 216h | 41,160 |  |  |
| 89 | 1.4.9.5.1 | Jig Design (modify ALICE) |  | 10d | 2017-02-07 | 2017-02-20 | 80, 86 | -175d | 0d |  | LDRD Mechnical Engineer [30%]; LDRD Physicist [10%] | 32h | 7,360 | LDRD |  |
| 90 | 1.4.9.5.2 | Prototype Jigs |  | 30d | 2017-02-21 | 2017-04-03 | 89 | -175d | 0d |  | LDRD PostDoc [20%]; LDRD Mechnical Tech [30%] | 120h | 15,800 | LDRD |  |
| 91 | 1.4.9.5.3 | Final Jigs Design and Production |  | 20d | 2017-04-04 | 2017-05-01 | 90 | -175d | 0d |  | LDRD Mechnical Engineer [10%]; LDRD Mechnical Tech [30%] | 64h | 18,000 | LDRD |  |
| 92 | 1.4.10 | **Mechanical Coneptual Design Review** |  | 12d | 2017-05-23 | 2017-06-07 |  | -190d | 0d |  |  | 104h | 23,920 |  |  |
| 93 | 1.4.10.1 | Mechanics Design Review |  | 1d | 2017-05-23 | 2017-05-23 | 87, 91, 102 | -190d | 0d |  | LDRD Mechnical Engineer; LDRD Physicist | 16h | 3,680 | LDRD |  |
| 94 | 1.4.10.2 | Incorporate Review Comments |  | 10d | 2017-05-24 | 2017-06-06 | 93 | -190d | 0d |  | LDRD Mechnical Engineer [50%]; LDRD Physicist [50%] | 80h | 18,400 | LDRD |  |
| 95 | 1.4.10.3 | Complete Mechanical Conceptual Design (for CD-1) | milestone | 1d | 2017-06-07 | 2017-06-07 | 94 | -190d | 0d |  | LDRD Physicist [50%]; LDRD Mechnical Engineer [50%] | 8h | 1,840 | LDRD |  |
| 96 | 1.4.11 | **MAPS Inner Barrel Review (CD-1)** |  | 12d | 2017-11-01 | 2017-11-16 |  | -294d | 0d |  |  | 156h | 35,880 |  |  |
| 97 | 1.4.11.1 | Final Design Review |  | 1d | 2017-11-01 | 2017-11-01 | 74, 95 | -294d | 0d | start no earlier than 2017-11-01 | LDRD Electronics Engineer; LDRD Mechnical Engineer; LDRD Physicist | 24h | 5,520 | LDRD | DOE |
| 98 | 1.4.11.2 | Incorporate Review Comments |  | 10d | 2017-11-02 | 2017-11-15 | 97 | -294d | 0d |  | LDRD Electronics Engineer [50%]; LDRD Mechnical Engineer [50%]; LDRD Physicist [50%] | 120h | 27,600 | LDRD | DOE |
| 99 | 1.4.11.3 | Complete Final CD-1 MAPS Design | milestone | 1d | 2017-11-16 | 2017-11-16 | 98 | -294d | 0d |  | LDRD Electronics Engineer [50%]; LDRD Mechnical Engineer [50%]; LDRD Physicist [50%] | 12h | 2,760 | LDRD | DOE |

Notes:
- 81: monitoring temp, flow rates, I, V etc.
- 92: For CD-1 review, 11/2017, conceptuall design of mechanis system

| ID | WBS | Task | Duration | Start | Finish | Predecessors | Total slack | Free slack | Constraint | Resources | Work | Cost | Cost Center | Activity | DOE Cost |
| --- | --- | --- | --- | --- | --- | --- | --- | --- | --- | --- | --- | --- | --- | --- | --- |
| 100 | 1.4.12 | **Prototype Assembly and Test** | 50d | 2017-03-14 | 2017-05-22 |  | -190d | 0d |  |  | 312h | 37,520 | LDRD |  |  |
| 101 | 1.4.12.1 | Assemble prototype | 30d | 2017-03-14 | 2017-04-24 | 80, 68, 69, 70, 37, 43, 46, 49, 52 | -190d | 0d |  | LDRD Electronics Tech [20%]; LDRD Mechnical Tech [20%]; LDRD Physicist [10%]; LDRD PostDoc [20%] | 168h | 18,480 | LDRD |  |  |
| 102 | 1.4.12.2 | Prototype Full System Test | 20d | 2017-04-25 | 2017-05-22 | 101 | -190d | 0d |  | Physicist [20%]; LDRD Physicist [20%]; LDRD PostDoc [30%]; LDRD Electronics Engineer [10%]; LDRD Mechnical Engineer [10%] | 144h | 19,040 | LDRD |  |  |
| 103 | 1.4.13 | **Softrware Development** | 300d | 2016-10-04 | 2017-11-27 |  | 916d |  |  |  | 2080h | 112,800 |  |  |  |
| 104 | 1.4.13.1 | Online Monitoring and Contorls | 100d | 2016-10-04 | 2017-02-20 | 29 | 916d | 0d |  | LDRD PostDoc [20%]; LDRD Physicist [10%]; Physicist [50%] | 640h | 32,800 |  |  |  |
| 105 | 1.4.13.2 | Offline Software and Analysis | 200d | 2017-02-21 | 2017-11-27 | 104 | 916d |  |  | LDRD PostDoc [30%]; LDRD Physicist [10%]; Physicist [50%] | 1440h | 80,000 |  |  |  |
| 106 | 1.4.14 | Detector Optimizaation and Physics Simulations (CD-1) | 300d | 2016-10-03 | 2017-11-24 |  | 917d |  | start no earlier than 2016-10-03 | LDRD Physicist [50%]; LDRD PostDoc [50%] | 2400h | 384,000 |  |  |  |
| 107 | 1.4.15 | **Test Beam Operation** | 187d | 2019-01-11 | 2019-09-30 |  | 0d |  |  |  | 1318h | 96,260 | LDRD |  |  |
| 108 | 1.4.15.1 | Shipping/Transport | 10d | 2019-01-11 | 2019-01-24 | 102 | 0d |  | as late as possible | LDRD Mechnical Tech [20%] | 16h | 11,440 | LDRD |  |  |
| 109 | 1.4.15.2 | Setup | 5d | 2019-01-25 | 2019-01-31 | 108 | 0d |  | as late as possible | Physicist [50%]; LDRD Electronics Tech [50%]; LDRD Mechnical Tech [50%]; LDRD PostDoc [50%]; LDRD Physicist [10%] | 84h | 6,320 | LDRD |  |  |
| 110 | 1.4.15.3 | Operations | 20d | 2019-02-01 | 2019-02-28 | 109 | 0d |  | must start on 2019-02-01 | Physicist; LDRD Physicist [50%]; LDRD PostDoc [50%] | 160h | 12,800 | LDRD |  |  |
| 111 | 1.4.15.4 | Test Beam Data Analysis & Publication | 152d | 2019-03-01 | 2019-09-30 | 110 | 436d |  | finish no earlier than 2019-09-30 | LDRD Physicist [50%]; LDRD PostDoc [50%]; Physicist [50%] | 1058h | 65,700 |  |  |  |
| 112 | 1.5 | **sPHENIX Project** | 1217d? | 2016-10-03 | 2021-06-01 |  | 0d |  |  |  | 24868h | 2,973,442.86 |  |  |  |
| 113 | 1.5.1 | **sPHENIX Project Management** | 1217d | 2016-10-03 | 2021-06-01 |  | 0d |  |  |  | 2920.8h | 97,360 |  | sPHENIX MAPS Project |  |
| 114 | 1.5.1.1 | Level 3 Project Manager | 1217d | 2016-10-03 | 2021-06-01 |  | 0d |  | start no earlier than 2016-10-03 | Physicist [20%] | 1947.2h |  |  |  |  |
| 115 | 1.5.1.2 | Mechanical Liason Engineer | 1217d | 2016-10-03 | 2021-06-01 |  | 0d |  | finish no earlier than 2021-06-01 | Mech Liason Eng [5%] | 486.8h | 48,680 |  |  | DOE |
| 116 | 1.5.1.3 | Electronics Liason Engineer | 1217d | 2016-10-03 | 2021-06-01 |  | 0d |  | finish no earlier than 2021-06-01 | Elec Liason Eng [5%] | 486.8h | 48,680 |  |  | DOE |
| 117 | 1.5.2 | **sPHENIX Mechanics Integration** | 289d | 2017-11-02 | 2018-12-11 |  | 119d |  |  |  | 1684h | 229,040 |  |  |  |
| 118 | 1.5.2.1 | **Stave Support Frame & Global Interface to sPHENIX** | 115d | 2017-11-02 | 2018-04-11 |  | 119d |  |  |  | 864h | 113,040 |  |  |  |
| 119 | 1.5.2.1.1 | initial design (modify ALICE) | 30d | 2017-11-02 | 2017-12-13 | 14FS+1d | 119d | 0d |  | Mechanical Engineer [50%]; Physicist [10%]; Mech Tech [50%] | 264h | 21,600 |  |  |  |
| 120 | 1.5.2.1.2 | prototype | 60d | 2017-12-14 | 2018-03-07 | 119 | 119d | 0d |  | Mech Tech; Physicist [20%] | 384h | 73,040 |  |  |  |
| 121 | 1.5.2.1.3 | test | 10d | 2018-03-08 | 2018-03-21 | 120 | 119d | 0d |  | Mech Tech; Physicist [20%] | 96h | 6,400 |  |  |  |
| 122 | 1.5.2.1.4 | final design | 15d | 2018-03-22 | 2018-04-11 | 121 | 119d | 0d |  | Mechanical Engineer | 120h | 12,000 |  |  |  |
| 123 | 1.5.2.2 | **Cooling System** | 25d | 2018-08-01 | 2018-09-04 |  | 645d |  |  |  | 200h | 38,400 |  |  |  |
| 124 | 1.5.2.2.1 | Design (modify ALICE) | 10d | 2018-08-01 | 2018-08-14 | 77, 16, 122 | 645d | 0d |  | Mechanical Engineer | 80h | 8,000 |  |  |  |
| 125 | 1.5.2.2.2 | Mock up Testing | 10d | 2018-08-15 | 2018-08-28 | 124 | 645d | 0d |  | Mech Tech | 80h | 26,400 |  |  |  |
| 126 | 1.5.2.2.3 | Final Desgin of Cooling System | 5d | 2018-08-29 | 2018-09-04 | 125 | 645d | 0d |  | Mechanical Engineer | 40h | 4,000 |  |  |  |

Notes:
- 114: L3 project manager is off the project, zero cost, paid by home institute
- 117: critical to have early R&D fund to finish mechanics for CD-2/CD3
- 119: Early R&D fund is required, CD1/CD-3a 11/2017; / production fund only available after CD-3b 8/2018

| ID | WBS | Task | Type | Duration | Start | Finish | Predecessors | Total slack | Free slack | Constraint | Resources | Work | Cost | DOE Cost | Activity |
| --- | --- | --- | --- | --- | --- | --- | --- | --- | --- | --- | --- | --- | --- | --- | --- |
| 127 | 1.5.2.3 | **Safety Systems** |  | 70d | 2018-09-05 | 2018-12-11 |  | 645d |  |  |  | 280h | 48,000 |  |  |
| 128 | 1.5.2.3.1 | review sensors & interlocks |  | 10d | 2018-09-05 | 2018-09-18 | 126 | 645d | 0d |  | Electrical Engineer [50%] | 40h | 4,000 |  |  |
| 129 | 1.5.2.3.2 | electrical interlock design |  | 30d | 2018-09-19 | 2018-10-30 | 128 | 645d | 0d |  | Electrical Engineer [50%] | 120h | 22,000 |  |  |
| 130 | 1.5.2.3.3 | cooling interlocks design |  | 30d | 2018-10-31 | 2018-12-11 | 129 | 645d |  |  | Mechanical Engineer [50%] | 120h | 22,000 |  |  |
| 131 | 1.5.2.4 | **Stave Assembly Tooling** |  | 45d | 2018-04-12 | 2018-06-13 |  | 119d |  |  |  | 340h | 29,600 |  |  |
| 132 | 1.5.2.4.1 | design |  | 10d | 2018-04-12 | 2018-04-25 | 122 | 119d | 0d |  | Mechanical Engineer | 80h | 8,000 |  |  |
| 133 | 1.5.2.4.2 | prototype |  | 30d | 2018-04-26 | 2018-06-06 | 132 | 119d | 0d |  | Physicist [50%]; Mech Tech [50%] | 240h | 19,600 |  |  |
| 134 | 1.5.2.4.3 | final jig design |  | 5d | 2018-06-07 | 2018-06-13 | 133 | 119d | 0d |  | Mechanical Engineer [50%] | 20h | 2,000 |  |  |
| 135 | 1.5.3 | **Mechanics Final Design Review** |  | 12d | 2018-06-14 | 2018-06-29 |  | 119d |  |  |  | 81.6h | 5,600 |  |  |
| 136 | 1.5.3.1 | Mechanics Final Design Review |  | 1d | 2018-06-14 | 2018-06-14 | 134 | 119d | 0d |  | Mechanical Engineer; Physicist | 16h | 800 |  |  |
| 137 | 1.5.3.2 | Incorporate Review Comments |  | 10d | 2018-06-15 | 2018-06-28 | 136 | 119d | 0d |  | Physicist [20%]; Mechanical Engineer [50%] | 56h | 4,000 |  |  |
| 138 | 1.5.3.3 | Complete Final Mechanical Design | milestone | 1d | 2018-06-29 | 2018-06-29 | 137 | 119d | 0d |  | Physicist [20%]; Mechanical Engineer | 9.6h | 800 |  |  |
| 139 | 1.5.4 | **MAPS Inner Barrel Review (CD-2/3)** |  | 12d | 2018-07-02 | 2018-07-17 |  | 119d |  |  |  | 181.33h | 11,200 |  |  |
| 140 | 1.5.4.1 | MAPS Final Design Review |  | 1d | 2018-07-02 | 2018-07-02 | 138, 22 | 119d | 0d |  | Electronics Engineer; Mechanical Engineer; Physicist | 24h | 1,600 | DOE |  |
| 141 | 1.5.4.2 | Incorporate Review Comments |  | 10d | 2018-07-03 | 2018-07-16 | 140 | 119d | 0d |  | Electronics Engineer [50%]; Mechanical Engineer [50%]; Physicist | 133.33h | 8,000 | DOE |  |
| 142 | 1.5.4.3 | Complete Final Design (CD-2) | milestone | 1d | 2018-07-17 | 2018-07-17 | 141 | 119d | 10d |  | Electronics Engineer; Mechanical Engineer; Physicist | 24h | 1,600 | DOE |  |
| 143 | 1.5.5 | **Productions** |  | 534d? | 2018-06-14 | 2020-06-30 |  | 36d |  |  |  | 15416.2h | 2,423,842.86 |  | Production |
| 144 | 1.5.5.1 | Full Pre-Production-Mechnical System Mock Up Test |  | 90d | 2018-06-14 | 2018-10-17 | 134 | 684d |  |  | Mechanical Engineer [20%]; Mech Tech [50%]; Physicist [50%] | 536h | 93,200 |  |  |
| 145 | 1.5.5.2 | **Procurements** |  | 180d? | 2018-08-01 | 2019-04-09 |  | 2d |  |  |  | 8984.23h | 2,163,602.86 |  |  |
| 146 | 1.5.5.2.1 | **CERN Procuments** |  | 180d? | 2018-08-01 | 2019-04-09 |  | 109d |  |  |  | 8398.63h | 1,038,078.86 |  |  |
| 147 | 1.5.5.2.1.1 | Produce 68 Inner Staves |  | 180d | 2018-08-01 | 2019-04-09 | 142, 16 | 109d | 0d | start no earlier than 2018-02-22 | Physicist [200%]; Elec tech [50%]; Electronics Engineer [200%]; Mech Tech [200%] | 8331.43h | 999,542.86 | DOE |  |
| 148 | 1.5.5.2.1.2 | Other ITS/CERN items |  | 120d | 2018-08-01 | 2019-01-15 | 147SS | 560d | 0d |  | Physicist [5%]; Mech Tech [2%] | 67.2h | 11,536 |  |  |
| 149 | 1.5.5.2.1.3 | Travel and Per Diem at CERN |  | 180d? | 2018-08-01 | 2019-04-09 | 148SS | 560d |  |  |  |  | 27,000 |  |  |
| 150 | 1.5.5.2.2 | Procure 68 Readout / FEM Units |  | 100d | 2018-08-01 | 2018-12-18 | 16, 142SS+1d | 447d | 0d |  | Physicist [10%]; Elec tech [20%] | 240h | 334,800 | DOE |  |
| 151 | 1.5.5.2.3 | Procure Optical Links 68 |  | 60d | 2018-08-02 | 2018-10-24 | 150SS+1d | 447d | 0d |  | Physicist [2%]; Elec tech [2%] | 19.2h | 42,968 | DOE |  |
| 152 | 1.5.5.2.4 | Procure 34 Common Readout Units | manual | 100d | 2018-08-03 | 2018-12-20 | 151SS+1d |  |  |  | Physicist [2%]; Elec tech [2%] | 32h | 182,980 | DOE |  |
| 153 | 1.5.5.2.5 | Procure 100 SamTec Cables | manual | 60d | 2018-08-06 | 2018-10-26 | 152SS+1d |  |  |  | Physicist [2%]; Elec tech [2%] | 19.2h | 27,768 | DOE |  |
| 154 | 1.5.5.2.6 | Procure Ancillary Materials (LVPS and cables etc) |  | 100d | 2018-08-07 | 2018-12-24 | 153SS+1d | 445d | 0d |  | Physicist [2%]; Mech Tech [2%] | 32h | 61,280 | DOE |  |
| 155 | 1.5.5.2.7 | Procure Cooling Plant |  | 100d | 2018-08-01 | 2018-12-18 | 16 | 332d | 0d |  | Physicist [2%]; Mech Tech [2%] | 32h | 118,280 | DOE |  |
| 156 | 1.5.5.2.8 | Procure Assembly Fixtures & Jigs |  | 60d | 2018-08-02 | 2018-10-24 | 155SS+1d | 332d | 0d |  | Physicist [2%]; Mech Tech [2%] | 19.2h | 100,768 | DOE |  |
| 157 | 1.5.5.2.9 | Procure End Wheels |  | 100d | 2018-08-03 | 2018-12-20 | 156SS+1d | 332d | 0d |  | Physicist [2%]; Mech Tech [2%] | 32h | 35,280 | DOE |  |
| 158 | 1.5.5.2.10 | Procure Cylindrical Structural Shells |  | 100d | 2018-08-06 | 2018-12-21 | 157SS+1d | 332d | 0d |  | Physicist [2%]; Mech Tech [2%] | 32h | 12,280 | DOE |  |
| 159 | 1.5.5.2.11 | Procure Detector Half Barrels |  | 100d | 2018-08-07 | 2018-12-24 | 158SS+1d | 332d | 0d |  | Physicist [2%]; Mech Tech [2%] | 32h | 14,280 | DOE |  |
| 160 | 1.5.5.2.12 | Procure Service Half Barrels |  | 100d | 2018-08-08 | 2018-12-25 | 159SS+1d | 332d | 0d |  | Physicist [2%]; Mech Tech [2%] | 32h | 121,280 | DOE |  |
| 161 | 1.5.5.2.13 | Procure Detector and Service Half Barrels |  | 100d | 2018-08-09 | 2018-12-26 | 160SS+1d | 332d | 0d |  | Physicist [2%]; Mech Tech [2%] | 32h | 22,280 | DOE |  |
| 162 | 1.5.5.2.14 | Procure Two Half Support Structures |  | 100d | 2018-08-10 | 2018-12-27 | 161SS+1d | 332d | 223d |  | Physicist [2%]; Mech Tech [2%] | 32h | 51,280 | DOE |  |

Notes:
- 127: monitoring temp, flow rates, I, V etc.
- 144: Mechnics production test run; / may not needed?
- 147: 48+20% = 58; consider to have 40% spare: 68 in total / could start early right after ITS production end, ~2/23/18 (final electronics review finished) assuming sPHENIX can morgage with CERN to produce staves, can gain 6 months of advanced production; / production length ~ 6 months = 20x6days / fixed cost = 100K(chips) + 340K(staves) + 480K(full cost recovery) = $920K / split them into fixed cost 440 + 480 (full recovery cost, via 200% engineer + 200% mech techs)
- 148: other small items related to MAPS testing etc.
- 149: 1 FTE lodging(100) and per diem(50) for 6 months; / $4.5K/month x6 = 27,000
- 150: 48+40% spares; / obtain desgin files and produce them in US

| ID | WBS | Task | Type | Duration | Start | Finish | Predecessors | Total slack | Free slack | Resources | Work | Cost | DOE Cost |
| --- | --- | --- | --- | --- | --- | --- | --- | --- | --- | --- | --- | --- | --- |
| 163 | 1.5.5.3 | **Assembly and Testing at BNL** |  | 400d | 2018-12-19 | 2020-06-30 |  | 189d |  |  | 5896h | 167,040 |  |
| 164 | 1.5.5.3.1 | Test Production FEMS, e-Links, CRU, LV, optical links |  | 60d | 2018-12-25 | 2019-03-18 | 150, 151, 152, 153, 154 | 576d |  | Elec tech [30%]; Physicist [200%] | 1104h | 11,520 |  |
| 165 | 1.5.5.3.2 | Test Cooling System |  | 20d | 2018-12-19 | 2019-01-15 | 155 | 620d |  | Mech Tech [50%]; Physicist [50%] | 160h | 6,400 |  |
| 166 | 1.5.5.3.3 | Stave Reciept Inspection |  | 10d | 2019-04-10 | 2019-04-23 | 147 | 109d | 0d | Physicist [20%]; Elec tech [20%] | 32h | 1,280 | DOE |
| 167 | 1.5.5.3.4 | Individual Stave Readout Test |  | 70d | 2019-04-24 | 2019-07-30 | 166 | 109d | 0d | Physicist [300%]; Elec tech [20%] | 352h | 8,960 | DOE |
| 168 | 1.5.5.3.5 | Metrology on Stave Assemblies |  | 70d | 2019-07-31 | 2019-11-05 | 167 | 109d | 0d | Mechanical Engineer [20%]; Mech Tech [50%] | 392h | 33,600 | DOE |
| 169 | 1.5.5.3.6 | Assemble full Ladders into Half support |  | 100d | 2019-11-06 | 2020-03-24 | 168, 156, 157, 158, 159, 160, 161, 162 | 109d | 0d | Mech Tech [200%]; Physicist [200%] | 1856h | 20,480 | DOE |
| 170 | 1.5.5.3.7 | Metrology on Final Assembly |  | 10d | 2020-03-25 | 2020-04-07 | 169 | 109d | 0d | Mechanical Engineer | 80h | 8,000 | DOE |
| 171 | 1.5.5.3.8 | Half detector Assembly Readout and Cooling Test |  | 60d | 2020-04-08 | 2020-06-30 | 150, 151, 152, 153, 154, 170 | 109d | 0d | Physicist [200%]; Mech Tech; Elec tech | 1920h | 76,800 | DOE |
| 172 | 1.5.6 | **Installation** |  | 131d | 2020-07-01 | 2020-12-30 |  | 109d | 108d |  | 4584h | 206,400 |  |
| 173 | 1.5.6.1 | Installation Prep |  | 10d | 2020-07-01 | 2020-07-14 | 171 | 109d | 0d | Mech Tech; Physicist; Elec tech | 240h | 12,800 | DOE |
| 174 | 1.5.6.2 | Installation Review |  | 1d | 2020-07-15 | 2020-07-15 | 173 | 109d | 0d | Physicist; Mechanical Engineer; Electrical Engineer | 24h | 1,600 | DOE |
| 175 | 1.5.6.3 | Installation |  | 60d | 2020-07-16 | 2020-10-07 | 174 | 109d | 0d | Physicist [200%]; Mech Tech [200%]; Elec tech [200%] | 2880h | 153,600 |  |
| 176 | 1.5.6.4 | Commissioning |  | 60d | 2020-10-08 | 2020-12-30 | 175 | 109d | 0d | Physicist [200%]; Mech Tech [50%]; Elec tech [50%] | 1440h | 38,400 |  |
| 177 | 1.5.7 | Ready for beam | milestone | 0d | 2020-12-30 | 2020-12-30 | 176 | 109d |  |  |  |  |  |

Notes:
- 166: start the assembly at partrial delivery of staves, 60days from the start of stave production ; / allow 10days for shipping from CERN to BNL; / partial delivery every month
- 167: Statve test starts 10 days after reciept of staves
- 169: can start earlier if procument (stave production) can be morgaged, by up to ~ 1 month in time.! / can start work as early as 2 days after the start of metrologly on stave assembly;
- 172: installatino by 6/2021
- 175: commissioning starts 4/1/2021, last 2 months, ends on 6/1/2021 to be ready for beam
