# MAPS Inner Barrel

Schedule from MS Project, 2016-08-01 to 2021-06-01, costs in $.
Guest Scientist, LANL

## Calendars

- Standard: Mon-Fri 08:00-12:00, 13:00-17:00; Sat-Sun off.

## Resources

| Resource | Rate | Cost per use |
| --- | --- | --- |
| Mech Liason Eng | 100 |  |
| Elec Liason Eng | 100 |  |
| Project Manager | 100 |  |
| Physicist |  |  |
| Elec tech | 80 |  |
| Mech Tech | 80 |  |
| Electronics Engineer | 100 |  |
| Mechanical Engineer | 100 |  |
| M&S |  | 1 |
| Electrical Engineer | 100 |  |
| LDRD Physicist | 230 |  |
| LDRD PostDoc | 90 |  |
| LDRD Electronics Engineer | 230 |  |
| LDRD Mechnical Engineer | 230 |  |
| LDRD Mechnical Tech | 90 |  |
| LDRD Electronics Tech | 90 |  |

## Schedule

| ID | WBS | Task | Type | Duration | Start | Finish | Predecessors | Total slack | Free slack | Constraint | Work | Cost | DOE Cost | Activity | Cost Center |
| --- | --- | --- | --- | --- | --- | --- | --- | --- | --- | --- | --- | --- | --- | --- | --- |
| 1 | 1 | **MAPS Inner Barrel** |  | 1217d | 2016-10-03 | 2021-06-01 |  |  |  | start no earlier than 2005-10-21 | 24868h | 2,973,442.86 |  |  |  |
| 2 | 1.1 | MAPS Inner Barrel Starts | milestone | 0d | 2016-10-01 | 2016-10-01 |  | 0d |  | must start on 2016-10-01 |  |  | DOE |  |  |
| 3 | 1.2 | MAPS Inner Barrel Ends | milestone | 0d | 2021-06-01 | 2021-06-01 |  | 0d |  | must finish on 2021-06-01 |  |  | DOE |  |  |
| 4 | 1.3 | **Milestones & Key Tasks** |  | 0d | 2016-10-03 | 2016-10-03 |  |  |  |  |  |  |  |  |  |
| 5 | 1.3.1 | **ALICE ITS Key Tasks** |  | 0d | 2017-01-02 | 2017-01-02 |  |  |  |  |  |  |  |  |  |
| 6 | 1.3.1.1 | ALICE MAPS Production (7/17) |  | 240d? | 2016-08-01 | 2017-06-30 |  | 1022d |  | finish no earlier than 2017-06-30 |  |  |  |  |  |
| 7 | 1.3.1.2 | ALICE ITS IB FPC Production (9/17) |  | 90d | 2017-05-01 | 2017-09-01 |  | 977d |  | finish no earlier than 2017-09-01 |  |  |  |  |  |
| 8 | 1.3.1.3 | ALICE ITS IB Stave Production (1/18) |  | 1d? | 2018-01-02 | 2018-01-02 |  | 890d |  | finish no earlier than 2018-01-02 |  |  |  |  |  |
| 9 | 1.3.1.4 | ALICE ITS IB Stave Assembly (3/18) |  | 262d | 2017-01-02 | 2018-01-02 |  | 890d |  | start no earlier than 2017-01-01 |  |  |  | ITS construction |  |
| 10 | 1.3.1.5 | ALICE ITS Electronics Pre-Production (7/17) |  | 100d | 2017-02-22 | 2017-07-11 |  | 775d | 1d | start no earlier than 2017-02-22 |  |  |  | ITS Electronics Pre-Production |  |
| 11 | 1.3.1.6 | ALICE ITS Electronics Production (6/18) |  | 240d | 2017-07-13 | 2018-06-13 | 10 | 774d |  | start no earlier than 2017-07-13 |  |  |  | ITS Electronics Production |  |
| 12 | 1.3.2 | **sPHENIX Milestones** |  | 1195d | 2016-11-01 | 2021-06-01 |  |  |  |  |  |  |  |  |  |
| 13 | 1.3.2.1 | sPHENIX Technical Design CD-0 | milestone | 0d | 2016-11-01 | 2016-11-01 |  | 1196d |  | start no earlier than 2016-11-01 |  |  |  | CD-0 (11/2016) |  |
| 14 | 1.3.2.2 | sPHENIX Technical Design (CD-1/CD-3a) | milestone | 0d | 2017-11-01 | 2017-11-01 |  | 119d | 0d | start no earlier than 2017-11-01 |  |  |  | CD-1 (11/2017) |  |
| 15 | 1.3.2.3 | sPHENIX Technical Dewsgin (CD-2) | milestone | 0d | 2018-07-02 | 2018-07-02 | 54 | 761d |  | start no earlier than 2018-06-01 |  |  |  | CD-2 (7/2018) |  |
| 16 | 1.3.2.4 | sPHENIX Start Construction (CD-3b) | milestone | 0d | 2018-08-01 | 2018-08-01 |  | 109d | 0d | start no earlier than 2018-08-01 |  |  |  | CD-3b (8/2018) |  |
| 17 | 1.3.2.5 | sPHENIX Installed and Ready for Beam | milestone | 0d | 2021-06-01 | 2021-06-01 | 86 | 1d |  | start no earlier than 2021-06-01 |  |  |  | ready for beam (6/2021) |  |
| 18 | 1.3.3 | **LDRD Milestones & Critical Tasks** |  | 781d | 2016-10-03 | 2019-09-30 |  | -781d | 0d |  |  |  |  |  |  |
| 19 | 1.3.3.1 | LDRD Start and End |  | 781d | 2016-10-03 | 2019-09-30 |  | -781d | 0d | start no earlier than 2016-10-03 |  |  |  |  |  |
| 20 | 1.3.3.2 | Complete MoU LANL-ALICE | milestone | 0d | 2016-10-03 | 2016-10-03 |  | 0d |  |  |  |  |  |  |  |
| 21 | 1.3.3.3 | Setup ALICE Readout Test Stands | milestone | 0d | 2016-10-03 | 2016-10-03 |  | 0d |  |  |  |  |  |  |  |
| 22 | 1.3.3.4 | Complete final sPHENIX Readout Design Review | milestone | 0d | 2016-10-03 | 2016-10-03 |  | 0d |  |  |  |  |  |  |  |
| 23 | 1.3.3.5 | Complete Final MAPS Detector Design (CD-1) | milestone | 0d | 2016-10-03 | 2016-10-03 |  | 0d |  |  |  |  |  |  |  |
| 24 | 1.3.3.6 | sPHENIX Test Beam |  | 21d | 2019-02-01 | 2019-03-01 |  | -630d | 0d | start no earlier than 2019-02-01 |  |  |  |  | LDRD |
| 25 | 1.3.3.7 | MAPS Final Design (CD-2/CD-3)? | milestone | 0d | 2016-10-03 | 2016-10-03 |  | 0d |  |  |  |  |  |  |  |

Notes:
- 14: critical and lond lead time items can be purchased at CD3a
- 16: constructino fund available at CD-3b
- 17: commissioning 4/1-6/1, 2021; / ready for beam 6/1/2021
- 22: LDRD complete full readout electronics final design

| ID | WBS | Task | Type | Duration | Start | Finish | Predecessors | Total slack | Free slack | Constraint | Resources | Work | Cost | Activity | DOE Cost |
| --- | --- | --- | --- | --- | --- | --- | --- | --- | --- | --- | --- | --- | --- | --- | --- |
| 26 | 1.4 | **sPHENIX Project** |  | 1217d? | 2016-10-03 | 2021-06-01 |  | 0d |  |  |  | 24868h | 2,973,442.86 |  |  |
| 27 | 1.4.1 | **sPHENIX Project Management** |  | 1217d | 2016-10-03 | 2021-06-01 |  | 0d |  |  |  | 2920.8h | 97,360 | sPHENIX MAPS Project |  |
| 114 | 1.4.1.1 | Level 3 Project Manager |  | 1217d | 2016-10-03 | 2021-06-01 |  | 0d |  | start no earlier than 2016-10-03 | Physicist [20%] | 1947.2h |  |  |  |
| 115 | 1.4.1.2 | Mechanical Liason Engineer |  | 1217d | 2016-10-03 | 2021-06-01 |  | 0d |  | finish no earlier than 2021-06-01 | Mech Liason Eng [5%] | 486.8h | 48,680 |  | DOE |
| 116 | 1.4.1.3 | Electronics Liason Engineer |  | 1217d | 2016-10-03 | 2021-06-01 |  | 0d |  | finish no earlier than 2021-06-01 | Elec Liason Eng [5%] | 486.8h | 48,680 |  | DOE |
| 31 | 1.4.2 | **sPHENIX Mechanics Integration** |  | 289d | 2017-11-02 | 2018-12-11 |  | 119d |  |  |  | 1684h | 229,040 |  |  |
| 32 | 1.4.2.1 | **Stave Support Frame & Global Interface to sPHENIX** |  | 115d | 2017-11-02 | 2018-04-11 |  | 119d |  |  |  | 864h | 113,040 |  |  |
| 119 | 1.4.2.1.1 | initial design (modify ALICE) |  | 30d | 2017-11-02 | 2017-12-13 | 14FS+1d | 119d | 0d |  | Mechanical Engineer [50%]; Physicist [10%]; Mech Tech [50%] | 264h | 21,600 |  |  |
| 34 | 1.4.2.1.2 | prototype |  | 60d | 2017-12-14 | 2018-03-07 | 119 | 119d | 0d |  | Mech Tech; Physicist [20%] | 384h | 73,040 |  |  |
| 35 | 1.4.2.1.3 | test |  | 10d | 2018-03-08 | 2018-03-21 | 34 | 119d | 0d |  | Mech Tech; Physicist [20%] | 96h | 6,400 |  |  |
| 36 | 1.4.2.1.4 | final design |  | 15d | 2018-03-22 | 2018-04-11 | 35 | 119d | 0d |  | Mechanical Engineer | 120h | 12,000 |  |  |
| 37 | 1.4.2.2 | **Cooling System** |  | 25d | 2018-08-01 | 2018-09-04 |  | 645d |  |  |  | 200h | 38,400 |  |  |
| 124 | 1.4.2.2.1 | Design (modify ALICE) |  | 10d | 2018-08-01 | 2018-08-14 | 16, 36 | 645d | 0d |  | Mechanical Engineer | 80h | 8,000 |  |  |
| 39 | 1.4.2.2.2 | Mock up Testing |  | 10d | 2018-08-15 | 2018-08-28 | 124 | 645d | 0d |  | Mech Tech | 80h | 26,400 |  |  |
| 40 | 1.4.2.2.3 | Final Desgin of Cooling System |  | 5d | 2018-08-29 | 2018-09-04 | 39 | 645d | 0d |  | Mechanical Engineer | 40h | 4,000 |  |  |
| 41 | 1.4.2.3 | **Safety Systems** |  | 70d | 2018-09-05 | 2018-12-11 |  | 645d |  |  |  | 280h | 48,000 |  |  |
| 42 | 1.4.2.3.1 | review sensors & interlocks |  | 10d | 2018-09-05 | 2018-09-18 | 40 | 645d | 0d |  | Electrical Engineer [50%] | 40h | 4,000 |  |  |
| 43 | 1.4.2.3.2 | electrical interlock design |  | 30d | 2018-09-19 | 2018-10-30 | 42 | 645d | 0d |  | Electrical Engineer [50%] | 120h | 22,000 |  |  |
| 44 | 1.4.2.3.3 | cooling interlocks design |  | 30d | 2018-10-31 | 2018-12-11 | 43 | 645d |  |  | Mechanical Engineer [50%] | 120h | 22,000 |  |  |
| 45 | 1.4.2.4 | **Stave Assembly Tooling** |  | 45d | 2018-04-12 | 2018-06-13 |  | 119d |  |  |  | 340h | 29,600 |  |  |
| 46 | 1.4.2.4.1 | design |  | 10d | 2018-04-12 | 2018-04-25 | 36 | 119d | 0d |  | Mechanical Engineer | 80h | 8,000 |  |  |
| 47 | 1.4.2.4.2 | prototype |  | 30d | 2018-04-26 | 2018-06-06 | 46 | 119d | 0d |  | Physicist [50%]; Mech Tech [50%] | 240h | 19,600 |  |  |
| 48 | 1.4.2.4.3 | final jig design |  | 5d | 2018-06-07 | 2018-06-13 | 47 | 119d | 0d |  | Mechanical Engineer [50%] | 20h | 2,000 |  |  |
| 49 | 1.4.3 | **Mechanics Final Design Review** |  | 12d | 2018-06-14 | 2018-06-29 |  | 119d |  |  |  | 81.6h | 5,600 |  |  |
| 50 | 1.4.3.1 | Mechanics Final Design Review |  | 1d | 2018-06-14 | 2018-06-14 | 48 | 119d | 0d |  | Mechanical Engineer; Physicist | 16h | 800 |  |  |
| 51 | 1.4.3.2 | Incorporate Review Comments |  | 10d | 2018-06-15 | 2018-06-28 | 50 | 119d | 0d |  | Physicist [20%]; Mechanical Engineer [50%] | 56h | 4,000 |  |  |
| 52 | 1.4.3.3 | Complete Final Mechanical Design | milestone | 1d | 2018-06-29 | 2018-06-29 | 51 | 119d | 0d |  | Physicist [20%]; Mechanical Engineer | 9.6h | 800 |  |  |

Notes:
- 114: L3 project manager is off the project, zero cost, paid by home institute
- 31: critical to have early R&D fund to finish mechanics for CD-2/CD3
- 119: Early R&D fund is required, CD1/CD-3a 11/2017; / production fund only available after CD-3b 8/2018
- 41: monitoring temp, flow rates, I, V etc.

| ID | WBS | Task | Type | Duration | Start | Finish | Predecessors | Total slack | Free slack | Constraint | Resources | Work | Cost | DOE Cost | Activity |
| --- | --- | --- | --- | --- | --- | --- | --- | --- | --- | --- | --- | --- | --- | --- | --- |
| 53 | 1.4.4 | **MAPS Inner Barrel Review (CD-2/3)** |  | 12d | 2018-07-02 | 2018-07-17 |  | 119d |  |  |  | 181.33h | 11,200 |  |  |
| 54 | 1.4.4.1 | MAPS Final Design Review |  | 1d | 2018-07-02 | 2018-07-02 | 52, 22 | 119d | 0d |  | Electronics Engineer; Mechanical Engineer; Physicist | 24h | 1,600 | DOE |  |
| 55 | 1.4.4.2 | Incorporate Review Comments |  | 10d | 2018-07-03 | 2018-07-16 | 54 | 119d | 0d |  | Electronics Engineer [50%]; Mechanical Engineer [50%]; Physicist | 133.33h | 8,000 | DOE |  |
| 56 | 1.4.4.3 | Complete Final Design (CD-2) | milestone | 1d | 2018-07-17 | 2018-07-17 | 55 | 119d | 10d |  | Electronics Engineer; Mechanical Engineer; Physicist | 24h | 1,600 | DOE |  |
| 57 | 1.4.5 | **Productions** |  | 534d? | 2018-06-14 | 2020-06-30 |  | 36d |  |  |  | 15416.2h | 2,423,842.86 |  | Production |
| 144 | 1.4.5.1 | Full Pre-Production-Mechnical System Mock Up Test |  | 90d | 2018-06-14 | 2018-10-17 | 48 | 684d |  |  | Mechanical Engineer [20%]; Mech Tech [50%]; Physicist [50%] | 536h | 93,200 |  |  |
| 59 | 1.4.5.2 | **Procurements** |  | 180d? | 2018-08-01 | 2019-04-09 |  | 2d |  |  |  | 8984.23h | 2,163,602.86 |  |  |
| 60 | 1.4.5.2.1 | **CERN Procuments** |  | 180d? | 2018-08-01 | 2019-04-09 |  | 109d |  |  |  | 8398.63h | 1,038,078.86 |  |  |
| 147 | 1.4.5.2.1.1 | Produce 68 Inner Staves |  | 180d | 2018-08-01 | 2019-04-09 | 56, 16 | 109d | 0d | start no earlier than 2018-02-22 | Physicist [200%]; Elec tech [50%]; Electronics Engineer [200%]; Mech Tech [200%] | 8331.43h | 999,542.86 | DOE |  |
| 148 | 1.4.5.2.1.2 | Other ITS/CERN items |  | 120d | 2018-08-01 | 2019-01-15 | 147SS | 560d | 0d |  | Physicist [5%]; Mech Tech [2%] | 67.2h | 11,536 |  |  |
| 149 | 1.4.5.2.1.3 | Travel and Per Diem at CERN |  | 180d? | 2018-08-01 | 2019-04-09 | 148SS | 560d |  |  |  |  | 27,000 |  |  |
| 150 | 1.4.5.2.2 | Procure 68 Readout / FEM Units |  | 100d | 2018-08-01 | 2018-12-18 | 16, 56SS+1d | 447d | 0d |  | Physicist [10%]; Elec tech [20%] | 240h | 334,800 | DOE |  |
| 65 | 1.4.5.2.3 | Procure Optical Links 68 |  | 60d | 2018-08-02 | 2018-10-24 | 150SS+1d | 447d | 0d |  | Physicist [2%]; Elec tech [2%] | 19.2h | 42,968 | DOE |  |
| 66 | 1.4.5.2.4 | Procure 34 Common Readout Units | manual | 100d | 2018-08-03 | 2018-12-20 | 65SS+1d |  |  |  | Physicist [2%]; Elec tech [2%] | 32h | 182,980 | DOE |  |
| 67 | 1.4.5.2.5 | Procure 100 SamTec Cables | manual | 60d | 2018-08-06 | 2018-10-26 | 66SS+1d |  |  |  | Physicist [2%]; Elec tech [2%] | 19.2h | 27,768 | DOE |  |
| 68 | 1.4.5.2.6 | Procure Ancillary Materials (LVPS and cables etc) |  | 100d | 2018-08-07 | 2018-12-24 | 67SS+1d | 445d | 0d |  | Physicist [2%]; Mech Tech [2%] | 32h | 61,280 | DOE |  |
| 155 | 1.4.5.2.7 | Procure Cooling Plant |  | 100d | 2018-08-01 | 2018-12-18 | 16 | 332d | 0d |  | Physicist [2%]; Mech Tech [2%] | 32h | 118,280 | DOE |  |
| 156 | 1.4.5.2.8 | Procure Assembly Fixtures & Jigs |  | 60d | 2018-08-02 | 2018-10-24 | 155SS+1d | 332d | 0d |  | Physicist [2%]; Mech Tech [2%] | 19.2h | 100,768 | DOE |  |
| 157 | 1.4.5.2.9 | Procure End Wheels |  | 100d | 2018-08-03 | 2018-12-20 | 156SS+1d | 332d | 0d |  | Physicist [2%]; Mech Tech [2%] | 32h | 35,280 | DOE |  |
| 158 | 1.4.5.2.10 | Procure Cylindrical Structural Shells |  | 100d | 2018-08-06 | 2018-12-21 | 157SS+1d | 332d | 0d |  | Physicist [2%]; Mech Tech [2%] | 32h | 12,280 | DOE |  |
| 159 | 1.4.5.2.11 | Procure Detector Half Barrels |  | 100d | 2018-08-07 | 2018-12-24 | 158SS+1d | 332d | 0d |  | Physicist [2%]; Mech Tech [2%] | 32h | 14,280 | DOE |  |
| 160 | 1.4.5.2.12 | Procure Service Half Barrels |  | 100d | 2018-08-08 | 2018-12-25 | 159SS+1d | 332d | 0d |  | Physicist [2%]; Mech Tech [2%] | 32h | 121,280 | DOE |  |
| 161 | 1.4.5.2.13 | Procure Detector and Service Half Barrels |  | 100d | 2018-08-09 | 2018-12-26 | 160SS+1d | 332d | 0d |  | Physicist [2%]; Mech Tech [2%] | 32h | 22,280 | DOE |  |
| 162 | 1.4.5.2.14 | Procure Two Half Support Structures |  | 100d | 2018-08-10 | 2018-12-27 | 161SS+1d | 332d | 223d |  | Physicist [2%]; Mech Tech [2%] | 32h | 51,280 | DOE |  |

Notes:
- 144: Mechnics production test run; / may not needed?
- 147: 48+20% = 58; consider to have 40% spare: 68 in total / could start early right after ITS production end, ~2/23/18 (final electronics review finished) assuming sPHENIX can morgage with CERN to produce staves, can gain 6 months of advanced production; / production length ~ 6 months = 20x6days / fixed cost = 100K(chips) + 340K(staves) + 480K(full cost recovery) = $920K / split them into fixed cost 440 + 480 (full recovery cost, via 200% engineer + 200% mech techs)
- 148: other small items related to MAPS testing etc.
- 149: 1 FTE lodging(100) and per diem(50) for 6 months; / $4.5K/month x6 = 27,000
- 150: 48+40% spares; / obtain desgin files and produce them in US

| ID | WBS | Task | Type | Duration | Start | Finish | Predecessors | Total slack | Free slack | Resources | Work | Cost | DOE Cost |
| --- | --- | --- | --- | --- | --- | --- | --- | --- | --- | --- | --- | --- | --- |
| 77 | 1.4.5.3 | **Assembly and Testing at BNL** |  | 400d | 2018-12-19 | 2020-06-30 |  | 189d |  |  | 5896h | 167,040 |  |
| 78 | 1.4.5.3.1 | Test Production FEMS, e-Links, CRU, LV, optical links |  | 60d | 2018-12-25 | 2019-03-18 | 150, 65, 66, 67, 68 | 576d |  | Elec tech [30%]; Physicist [200%] | 1104h | 11,520 |  |
| 79 | 1.4.5.3.2 | Test Cooling System |  | 20d | 2018-12-19 | 2019-01-15 | 155 | 620d |  | Mech Tech [50%]; Physicist [50%] | 160h | 6,400 |  |
| 80 | 1.4.5.3.3 | Stave Reciept Inspection |  | 10d | 2019-04-10 | 2019-04-23 | 147 | 109d | 0d | Physicist [20%]; Elec tech [20%] | 32h | 1,280 | DOE |
| 81 | 1.4.5.3.4 | Individual Stave Readout Test |  | 70d | 2019-04-24 | 2019-07-30 | 80 | 109d | 0d | Physicist [300%]; Elec tech [20%] | 352h | 8,960 | DOE |
| 82 | 1.4.5.3.5 | Metrology on Stave Assemblies |  | 70d | 2019-07-31 | 2019-11-05 | 81 | 109d | 0d | Mechanical Engineer [20%]; Mech Tech [50%] | 392h | 33,600 | DOE |
| 83 | 1.4.5.3.6 | Assemble full Ladders into Half support |  | 100d | 2019-11-06 | 2020-03-24 | 82, 156, 157, 158, 159, 160, 161, 162 | 109d | 0d | Mech Tech [200%]; Physicist [200%] | 1856h | 20,480 | DOE |
| 84 | 1.4.5.3.7 | Metrology on Final Assembly |  | 10d | 2020-03-25 | 2020-04-07 | 83 | 109d | 0d | Mechanical Engineer | 80h | 8,000 | DOE |
| 85 | 1.4.5.3.8 | Half detector Assembly Readout and Cooling Test |  | 60d | 2020-04-08 | 2020-06-30 | 150, 65, 66, 67, 68, 84 | 109d | 0d | Physicist [200%]; Mech Tech; Elec tech | 1920h | 76,800 | DOE |
| 86 | 1.4.6 | **Installation** |  | 131d | 2020-07-01 | 2020-12-30 |  | 109d | 108d |  | 4584h | 206,400 |  |
| 87 | 1.4.6.1 | Installation Prep |  | 10d | 2020-07-01 | 2020-07-14 | 85 | 109d | 0d | Mech Tech; Physicist; Elec tech | 240h | 12,800 | DOE |
| 88 | 1.4.6.2 | Installation Review |  | 1d | 2020-07-15 | 2020-07-15 | 87 | 109d | 0d | Physicist; Mechanical Engineer; Electrical Engineer | 24h | 1,600 | DOE |
| 89 | 1.4.6.3 | Installation |  | 60d | 2020-07-16 | 2020-10-07 | 88 | 109d | 0d | Physicist [200%]; Mech Tech [200%]; Elec tech [200%] | 2880h | 153,600 |  |
| 90 | 1.4.6.4 | Commissioning |  | 60d | 2020-10-08 | 2020-12-30 | 89 | 109d | 0d | Physicist [200%]; Mech Tech [50%]; Elec tech [50%] | 1440h | 38,400 |  |
| 177 | 1.4.7 | Ready for beam | milestone | 0d | 2020-12-30 | 2020-12-30 | 90 | 109d |  |  |  |  |  |

Notes:
- 80: start the assembly at partrial delivery of staves, 60days from the start of stave production ; / allow 10days for shipping from CERN to BNL; / partial delivery every month
- 81: Statve test starts 10 days after reciept of staves
- 83: can start earlier if procument (stave production) can be morgaged, by up to ~ 1 month in time.! / can start work as early as 2 days after the start of metrologly on stave assembly;
- 86: installatino by 6/2021
- 89: commissioning starts 4/1/2021, last 2 months, ends on 6/1/2021 to be ready for beam
